# Cronograma

Schedule from MS Project, 2023-12-01 to 2024-07-27, costs in S.

## Calendars

- LALO: Mon-Sun 08:00-12:00, 13:00-17:00.

## Resources

| Resource | Group | Rate | Cost per use |
| --- | --- | --- | --- |
| OPERARIO | Mano de Obra | 26.19 |  |
| OFICIAL | Mano de Obra | 20.6 |  |
| PEON | Mano de Obra | 18.63 |  |
| REJILLA METALICA S/ DISEÑO | Material |  | 95 |
| ASFALTO RC-250 | Material |  | 13.5 |
| NET DE VOLEY INC. TUBOS METALICOS | Material |  | 900 |
| FLETE TERRESTRE | Material |  | 265886 |
| ALAMBRE NEGRO N° 16 | Material |  | 7.96 |
| ALAMBRE NEGRO N° 8 | Material |  | 5.69 |
| ANGULO 2" x 2" x 3/16" | Material |  | 13.06 |
| ANGULO DE F° 1"x1"x1/8" | Material |  | 9.65 |
| ANGULO 1 1/2" x 1 1/2" x 1/8 | Material |  | 11.89 |
| ANGULO 1" x 1" x 3/16" | Material |  | 11.89 |
| ACERO Fy = 4200 KG/CM2 (GRADO 60) | Material |  | 3.93 |
| CLAVOS PARA MADERA CON CABEZA DE 3" | Material |  | 3.85 |
| CLAVOS P/ MADERA CON CABEZA 2" 2 1/2" 3" 4" | Material |  | 5.69 |
| CLAVOS PARA MADERA C/C 2" | Material |  | 3.82 |
| CLAVOS PARA MADERA C/C 1" | Material |  | 3.82 |
| MALLA DE ALAMBRE GALV. # 10 DE 2" X 2" | Material |  | 32.5 |
| PLATINA DE FIERRO 2" X 3/16" | Material |  | 5.2 |
| PLATINA DE FIERRO 3" X 3/16" | Material |  | 6.2 |
| PLATINA DE FIERRO 1/4" X 1" | Material |  | 3.92 |
| PLATINA DE FIERRO 1/8" X 1" | Material |  | 3.92 |
| PLANCHA DE ACERO 4"X8"X1/16" | Material |  | 83.8 |
| PLANCHA DE FIERRO E=1/2" X 1.20 X 2.40 | Material |  | 378.9 |
| TEE DE ACERO SCH-40 Ø2" | Material |  | 5.8 |
| TEE DE ACERO SCH-40 Ø1 1/4" | Material |  | 4 |
| ABRAZADERA DE F° P/TUBO DE 4" | Material |  | 16.45 |
| ABRAZADERA DE F°G° C/ DOS OREJAS 1" X 3/8" | Material |  | 8 |
| ABRAZADERA DE FIJACION DE 2" F°G° | Material |  | 9.4 |
| ABRAZADERA DE FIJACION DE 1.1/4" F°G° | Material |  | 6.8 |
| ABRAZADERA DE FIJACION DE 2" F°G° | Material |  | 10.2 |
| TUBERIA PVC-SAP ELECTRICA DE 3/4" X 3 m (20 mm) | Material |  | 2.6 |
| TUBERIA PVC-SAP ELECTRICA DE 1" X 3 m (25 mm) | Material |  | 4.1 |
| TUBERIA PVC-SAP ELECTRICA DE 1½" X 3 m (40 mm) | Material |  | 7.5 |
| TUBERIA PVC-SAP ELECTRICA DE 2" X 3 m (50 mm) | Material |  | 12.9 |
| CURVAS PVC-SAP ELECTRICAS 3/4" (20 mm) | Material |  | 1 |
| CURVAS PVC-SAP ELECTRICAS 1" (25 mm) | Material |  | 3.1 |
| CURVAS PVC-SAP ELECTRICAS 1½" (40 mm) | Material |  | 8.9 |
| CURVAS PVC-SAP ELECTRICAS 2" (50 mm) | Material |  | 9.9 |
| UNIONES PVC-SAP 3/4" ELECTRICAS (20 mm) | Material |  | 0.9 |
| UNIONES PVC-SAP 1" ELECTRICAS (25 mm) | Material |  | 1.6 |
| UNIONES PVC-SAP 1½" ELECTRICAS (40 mm) | Material |  | 3.4 |
| EMPALME DE AGUA POTABLE | Material |  | 600 |
| TUBERIA PVC C-10 Ø 1 1/2" | Material |  | 13.72 |
| TUBERIA PVC P/ DESAGUE DE 4" | Material |  | 10.6 |
| TUBERIA PVC C-10 Ø 1/2" X 5M. | Material |  | 3.56 |
| TUBERIA PVC C-10 Ø 1" X 5M. | Material |  | 6.69 |
| CODO PVC 1" X 90° | Material |  | 4.2 |
| CODO PVC DE 1/2" X 90° | Material |  | 1.7 |
| TEE PVC DE 1/2" | Material |  | 1.36 |
| CODO PVC SAP 2" X 90° | Material |  | 2.45 |
| CODO PVC SAP 4" X 90° | Material |  | 6.56 |
| CODO PVC SAP 4" X 45° | Material |  | 6.56 |
| CODO PVC SAP 2" X 45° | Material |  | 2.45 |
| YEE PVC SAP DE 2" | Material |  | 2.63 |
| YEE PVC SAP DE 4" A 2" | Material |  | 12.03 |
| REDUCCION PVC SAP DE 4" A 2" | Material |  | 9.2 |
| UNION UNIVERSAL PVC-SAP C/R 1 1/2" | Material |  | 9.5 |
| REDUCCION PVC DE 1" A 1/2" | Material |  | 1 |
| SOMBRERO DE VENTILACION PVC DE 2" | Material |  | 4.15 |
| PIEDRA CHANCADA 1/2" | Material |  | 95 |
| PIEDRA GRANDE DE 8" | Material |  | 65 |
| PIEDRA OVER | Material |  | 60 |
| GRAVA | Material |  | 63 |
| ARENA FINA | Material |  | 35 |
| ARENA GRUESA | Material |  | 63 |
| HORMIGON | Material |  | 45 |
| MATERIAL DE PRESTEMO (CANTERA) | Material |  | 30 |
| TIERRA DE CULTIVO | Material |  | 30 |
| FIERRO LISO DE 1/2" X 6.00 m. | Material |  | 22.26 |
| FIERRO LISO DE 5/8" | Material |  | 3.56 |
| FIERRO LISO DE 5/8" x 6m | Material |  | 34.58 |
| FIERRO LISO DE 1" x 6m | Material |  | 45.65 |
| MALLA PARA SOLDAR 3" | Material |  | 1.8 |
| MALLA PARA SOLDAR 2" | Material |  | 1.5 |
| TECNOPOR DE 1" | Material |  | 10.42 |
| GIGANTOGRAFIA DE 3.60X2.40 M. | Material |  | 150 |
| CODO DE ALUMINIO DE 30MM | Material |  | 5.5 |
| CODO DE ACERO SCH-40 Ø3" X90° | Material |  | 5.5 |
| CODO DE ACERO SCH-40 Ø2" X90° | Material |  | 4.1 |
| CODO DE ACERO SCH-40 Ø1 1/2" X90° | Material |  | 8.5 |
| CODO DE ACERO SCH-40 Ø1 1/4" X90° | Material |  | 1.8 |
| CEMENTO PORTLAND TIPO MS (42.5 kg) | Material |  | 28.82 |
| CALAMINON CU 06(CURVO) 1.08X180 E=0.4MM | Material |  | 103.27 |
| CALAMINON TAT TERMO AISLANTE e=25 MM. | Material |  | 72.8 |
| CALAMINA GALVANIZADA DE 0.22 mm X 0.80 X 3.60 m. | Material |  | 24.5 |
| YESO (25 KG) | Material |  | 8 |
| DILUYENTE PARA ESMALTE EPOXICO | Material |  | 20.34 |
| TEE PVC DE 1" | Material |  | 4.18 |
| TEE PVC DE 1/2" | Material |  | 1.36 |
| TEE PVC SAP DE 4" | Material |  | 6.36 |
| YEE PVC SAP DE 4" | Material |  | 12.03 |
| ADAPTADOR PVC DE 1/2" | Material |  | 0.7 |
| ADAPTADOR PVC DE 1" | Material |  | 2 |
| ANTENA PARA SERVICIO SATELITAL | Material |  | 1895 |
| ETIQUETAS DE IDENTIFICACION SEÑALIZACION Y ORDENAMIENTO | Material |  | 38.6 |
| INSTALACION CONFIGURACION Y PUESTA EN FUNCIONAMIENTO | Material |  | 141.5 |
| CERTIFICACION DEL CABLEADO ESTRUCTURADO CAT 6 | Material |  | 76.8 |
| CONTRATO DE SUMINISTRO DE DATOS CON SERVICIO SATELITAL | Material |  | 780 |
| UNION UNIVERSAL PVC DE 1/2" | Material |  | 7.12 |
| UNION UNIVERSAL PVC DE 1" | Material |  | 12.63 |
| LADRILLO KK TIPO IV DE 24X13X9 CM. | Material |  | 0.8 |
| LADRILLO PASTELERO DE 24 X 24 X 3 cm | Material |  | 1.7 |
| LADRILLO PARA TECHO 8H DE 15X30X30 cm | Material |  | 2.84 |
| TUBO DE ACERO SCH-40 DE Ø3" ROSCADA GALV. | Material |  | 27.9 |
| TUBO DE ACERO SCH-40 DE Ø2" ROSCADA GALV. | Material |  | 13 |
| TUBO DE ACERO SCH-40 DE Ø1 1/2" ROSCADA GALV. | Material |  | 10.2 |
| TUBO DE ACERO SCH-40 DE Ø1 1/4" ROSCADA GALV. | Material |  | 8.4 |
| TUBO DE ACERO NEGRO DE Ø 3" | Material |  | 150 |
| TUBO DE ACERO NEGRO DE Ø 2" | Material |  | 90 |
| TUBO DE ACERO NEGRO DE Ø 2 1/2" | Material |  | 100 |
| TUBO DE ACERO SCH-40 DE Ø 3/4" | Material |  | 15 |
| CODO DE ACERO SCH-40 DE Ø 3/4" | Material |  | 15 |
| TUBO DE ACERO SCH-40 DE Ø 6" | Material |  | 172 |
| CODO DE ACERO SCH-40 DE Ø 6" | Material |  | 200 |
| TUBO DE ALUMINIO DE 30MM. E=3MM. | Material |  | 10.5 |
| CANTONERA DE ALUMINIO | Material |  | 34.6 |
| CANTONERA DE PVC e=18 mm. | Material |  | 1.5 |
| PERNOS DE EXPANSION DE 3/8"X3" C/ARANDELA | Material |  | 0.5 |
| TAPA DE MADERA 0.20 X 0.25 M. C/ MARCO ALUMINIO 3/4" X 3/4" | Material |  | 20 |
| TAPA DE CONCRETO DE 57X57 CM INC. ACCESORIOS | Material |  | 50 |
| BUZON DE C°0.60 x 0.60 x 0.80 m. P/ RED ELECTRICA | Material |  | 900 |
| NIPLE PVC 1/2" X 2" | Material |  | 1.1 |
| NIPLE PVC 1" | Material |  | 2 |
| CAJA DE CONCRETO PREFABRICADA DE DESAGUE DE 12" X 24" | Material |  | 126.86 |
| CEMENTO PVC 32 OZ NARANJA | Material |  | 40.7 |
| PEGAMENTO PARA PVC | Material |  | 130.42 |
| PEGAMENTO DE CERAMICO (25 KG) | Material |  | 16 |
| SILICONA | Material |  | 21.18 |
| COLA SINTETICA | Material |  | 16.1 |
| ADITIVO DE FIJACION | Material |  | 54.6 |
| ADITIVO IMPERMEABILIZANTE | Material |  | 53.4 |
| ADITIVO CURADOR | Material |  | 28.73 |
| CURADOR MENBRANIL | Material |  | 26.15 |
| CERAMICO 0.30 X 0.30 m. | Material |  | 22.5 |
| CERAMICO 0.20 X 0.30 m. | Material |  | 24.52 |
| CERAMICO 0.45 X 0.45 m. | Material |  | 24.52 |
| RODOPLAST | Material |  | 6.7 |
| PORCELANA DE COLOR | Material |  | 13.55 |
| MADERA TORNILLO | Material |  | 7.21 |
| MADERA CEDRO | Material |  | 10.9 |
| TRIPLAY DE 1.20 X 2.40 m X 6 mm. | Material |  | 28 |
| TRIPLAY DE 1.20 X 2.40 m X 4 mm. | Material |  | 28 |
| TABLERO FENOLICO e=12mm. INC. APUNTALAMIENTO | Material |  | 77.02 |
| CERRADURA 2 GOLPES TIPO FORTE (INC. TIRADOR) | Material |  | 52 |
| BISAGRA ALUMINIZADA DE 2 1/2" X 2 1/2" | Material |  | 5.6 |
| BISAGRA ALUMINIZADA PESADA 4"X4" | Material |  | 10.2 |
| BISAGRA CON EJE 5/8" | Material |  | 5.2 |
| BISAGRA PIN DE ROTULACION | Material |  | 7.5 |
| BISAGRA DE ACERO | Material |  | 25 |
| TOPE DE TUBO SEL | Material |  | 0.2 |
| TOPE DE GOMA PARA PUERTA | Material |  | 4.5 |
| CERROJO "SAPITO" DE BRONCE | Material |  | 5 |
| CERROJO 1/2"X1"X5" | Material |  | 10.8 |
| CERROJO DE FIERRO | Material |  | 15 |
| CILINDRO VACIO ABIERTO | Material |  | 80 |
| TIRAFON GALVANIZADO 1 1/2"X2" | Material |  | 0.56 |
| TIRAFON DE 1/4" X 4" | Material |  | 0.65 |
| TIRADOR DE ACERO INOXIDABLE | Material |  | 10.2 |
| LIJA PARA MADERA | Material |  | 2.5 |
| LIJA DE FIERRO #80 | Material |  | 2 |
| LIJA DE FIERRO #8 | Material |  | 2 |
| LIJA | Material |  | 2.5 |
| CAPACITACION EN SEGURIDAD Y SALUD | Material |  | 16000 |
| ELECTROBOMBA DE PETROLEO 1HP INC. ACCESORIOS | Material |  | 2850 |
| PINTURA LATEX | Material |  | 38.14 |
| PINTURA ESMALTE | Material |  | 46.94 |
| PINTURA ANTICORROSIVA | Material |  | 50.85 |
| PINTURA ANTICORROSIVA CROMATO DE ZINC | Material |  | 50.85 |
| THINNER | Material |  | 20.35 |
| IMPRIMANTE | Material |  | 32.2 |
| IMPRIMANTE VINILICO P/SUPERFICIE GALVANIZADO | Material |  | 32.2 |
| BARNIZ MARINO | Material |  | 34.9 |
| CINTA AISLANTE 1700 NEGRO | Material |  | 7.5 |
| CINTA TEFLON | Material |  | 1.86 |
| CINTA SEÑALIZADORA AMARILLA | Material |  | 0.25 |
| BAÑOS QUIMICOS | Material |  | 1500 |
| VIDRIO SEMIDOBLE INC. LAMINA DE 4 MICRAS | Material |  | 5.8 |
| SUMIDERO DE BRONCE DE 2" | Material |  | 7.37 |
| SUMIDERO DE BRONCE DE 3" | Material |  | 11.9 |
| BARRA DE ACERO INOX. Ø 1 1/2" L=0.90 m. INC. SOPORTE Y FI JACION | Material |  | 120.6 |
| PERNOS DE ANCLAJE 5/8" X 0.3M | Material |  | 12.5 |
| REGISTRO DE BRONCE DE 2" | Material |  | 9.5 |
| REGISTRO DE BRONCE DE 4" | Material |  | 20.08 |
| GANCHO CON SOMBRERO TIPO "J" 1/4" X 4" | Material |  | 0.54 |
| TUBERIA PVC P/ DESAGUE DE 2" | Material |  | 4.72 |
| LAVATORIO DE LOSA VITRIFICADA INC. ACCESORIOS | Material |  | 128.9 |
| LAVARROPA DE LOSA VITRIFICADA INC. ACCESORIOS | Material |  | 328.9 |
| INODORO TANQUE BAJO NORMAL INC. ACCESORIOS | Material |  | 216.9 |
| BIODIGESTOR (5 000 L) | Material |  | 7864.54 |
| LAVADERO ACERO INOX. DE 2 POZAS C/ ESCURRIDERA DE 18"x35" ACCESORIOS | Material |  | 314.8 |
| LAVADERO ACERO INOX. 1 POZA DE 18"x18" | Material |  | 179.6 |
| URINARIO PICO BLANCO INC. ACCESORIOS | Material |  | 228.5 |
| BASE DE FAROLA TUBO DE 3"X 2.5 mm. | Material |  | 128 |
| TUBERIA DE FIERRO GALVANIZADO DE 1" | Material |  | 8.7 |
| UNION UNIVERSAL DE F° G° DE 3/4" | Material |  | 1.1 |
| UNION UNIVERSAL DE F° G° DE 2" | Material |  | 46.53 |
| UNION UNIVERSAL DE F° G° DE 11 /4" | Material |  | 2.2 |
| TAPON HEMBRA DE FIERRO GALVANIZADO DE 3/4" | Material |  | 2.2 |
| TAPON HEMBRA DE FIERRO GALVANIZADO DE 1 1/4" | Material |  | 3.9 |
| REDUCCION EXCENTRICA DE ACERO SCH-40 DE 1 1/4" A 1" | Material |  | 6 |
| REDUCCION EXCENTRICA DE ACERO SCH-40 DE 1 1/4" A 3/4" | Material |  | 5.4 |
| TORNILLOS 1" | Material |  | 0.07 |
| BRIDA DE ACERO INOX. PARA SOLDAR ROMPE AGUA DE 3" | Material |  | 118.5 |
| BRIDA DE ACERO INOX. PARA SOLDAR ROMPE AGUA DE 2" | Material |  | 84.7 |
| BRIDA DE ACERO INOX. PARA SOLDAR ROMPE AGUA DE 1 1/2" | Material |  | 70.8 |
| BRIDA DE ACERO INOX. PARA SOLDAR ROMPE AGUA DE 1 1/4" | Material |  | 64.1 |
| VALVULA CHECK 1 1/4" | Material |  | 105.1 |
| VALVULA CHECK HORIZONTAL DE 1" | Material |  | 66.05 |
| VALVULA CHECK VERTICAL DE 2" | Material |  | 209.8 |
| VALVULA DE PIE Y CANASTILLA DE BRONCE 11/2" | Material |  | 46.53 |
| VALVULA DE BOLA Ø2" | Material |  | 38.9 |
| VALVULA DE CIERRE Ø 3/4" | Material |  | 90 |
| VALVULA DE PIE CON CANASTILLA Ø 3/4" | Material |  | 150 |
| VALVULA DE SOBRELLENADO Ø 4" | Material |  | 500 |
| VALVULA COMPUERTA DE 1/2" | Material |  | 18.3 |
| VALVULA COMPUERTA DE BRONCE DE 3/4" | Material |  | 26.8 |
| VALVULA COMPUERTA DE BRONCE ROSCADA DE 1" | Material |  | 42.5 |
| VALVULA COMPUERTA DE BRONCE DE 2" | Material |  | 83.81 |
| VALVULA COMPUERTA DE BRONCE DE 1 1/4" | Material |  | 76.19 |
| MANGUERA 5/8" | Material |  | 1.13 |
| MITIGACION AMBIENTAL | Material |  | 10000 |
| PLAN DE MONITOREO ARQUEOLOGICO | Material |  | 10000 |
| PLAN DE CONTINGENCIA | Material |  | 25000 |
| SOLDADURA CELLOCORD | Material |  | 13 |
| GABINETE DE COMUNICACIONES DE 12 RU C/ ACCESORIOS DE INSTALACION | Material |  | 2789 |
| TABLERO MELAMINE e=18 mm. | Material |  | 46.53 |
| DUCHA CROMADA INC. ACCESORIOS | Material |  | 54.9 |
| LLAVE TIPO GANZO | Material |  | 26.6 |
| ELECTROBOMBA 1 HP INC. ACCESORIOS | Material |  | 400 |
| FACE PLATE HDMI | Material |  | 19.5 |
| ACCESS POINT | Material |  | 2895 |
| GRUPO ELECTROGENO 25kW Vn=380VAC Trifasico Insonoro. | Material |  | 44400 |
| SISTEMA DE EVACUACION DE GASES DE COMBUSTION | Material |  | 430 |
| TANQUE METALICO e=3 mm. PARA COMBUSTIBLE | Material |  | 8200 |
| GRUPO ELECTROGENO 5kW Inc. Accesorios | Material |  | 3999 |
| LUMINARIA FAROLA JP/250-72 70 W | Material |  | 130.5 |
| FLUORESC. CIRCULAR . C/LAMP. FLOURESC.1x32W. AFP | Material |  | 99.9 |
| INTERRUPTOR TERMOMAGNETICO 3 X100 A | Material |  | 390 |
| INTERRUPTOR TERMOMAGNETICO 3 X63 A. | Material |  | 149.5 |
| INTERRUPTOR TERMOMAGNETICO 3 X30 A | Material |  | 82.9 |
| INTERRUPTOR SIMPLE | Material |  | 15.9 |
| INTERRUPTOR DIFERENCIAL 2X25 A/30mm A | Material |  | 81.35 |
| INTERRUPTOR TIPO RIEL 2X20A | Material |  | 33 |
| INTERRUPTOR TIPO RIEL 2X16A | Material |  | 33 |
| INTERRUPTOR TIPO RIEL 2X30A | Material |  | 63.9 |
| INTERRUPTOR DOBLE | Material |  | 22.9 |
| INTERRUPTOR DE CONMUTACION | Material |  | 26.5 |
| TOMACORRIENTE DOBLE C/LINEA TIERRA | Material |  | 22.8 |
| PLACA DE ALUMINIO ANODIZADO 1 CAVIDAD | Material |  | 12.3 |
| PUERTA METALICA S/ DISEÑO | Material |  | 250 |
| TUBO DE F°G° DE Ø 1 1/2" | Material |  | 8.51 |
| TUBO DE F°G° DE Ø 2" | Material |  | 28.6 |
| TUBO FO.GALV.ST.ISO-I 1 1/2" | Material |  | 10.63 |
| PORTA ROLLO PAPEL DE 18 CM | Material |  | 21.9 |
| MANIJA DE BRONCE 4" P/PUERTA | Material |  | 15.1 |
| BOTIQUIN | Material |  | 200 |
| CAMILLA | Material |  | 253 |
| EXTINTOR DE POLVO SECO | Material |  | 63.56 |
| PROTECCION DE CONCRETO 0.15X0.15 M | Material |  | 30 |
| SEÑALIZACION TEMPORAL | Material |  | 1200 |
| CAJA DE PASE OCTOGONAL SAP 100 X 40 mm | Material |  | 2.9 |
| CAJA RECTANGULAR SAP DE 100 x 55 x 50 mm | Material |  | 2.9 |
| CONEXION A CAJA PVC ELECT. SAP 25 mm. | Material |  | 7.59 |
| CAJA DE REGISTRO DE CONCRETO 0.50 x 0.80 m. | Material |  | 198.58 |
| CAJA DE 200 X 200 X 100 mm | Material |  | 34.5 |
| CAJA DE PASE 150 X 150 X 80mm | Material |  | 23 |
| CAJA DE PASE 400 X 400 X 100mm | Material |  | 67.9 |
| TAPA METALICA DE 0.60X0.60 m. | Material |  | 180 |
| TAPAPOROS DE MADERA ACABADA C/BARNIZ O LACA | Material |  | 35 |
| GABINETE METALICO PARA EXTINTOR | Material |  | 106.6 |
| GABINETE METALICO T.G. | Material |  | 1200 |
| TOMA PARA RED DATA (DADO) | Material |  | 15.5 |
| CABLE 6 mm2 N2XOH | Material |  | 4.7 |
| CABLE 10 mm2 N2XOH | Material |  | 7.05 |
| CABLE 2.5 mm2 LSOH-80 | Material |  | 0.9 |
| CABLE 4 mm2 LSOH-80 | Material |  | 1.8 |
| CABLE 25 mm2 N2XOH | Material |  | 16.45 |
| CABLE 35mm2 N2XOH | Material |  | 21.88 |
| LUZ DE EMERGENCIA 2X20W HALOGENA 5H BAT. LIBRE MANTO | Material |  | 150 |
| ARTEFACTO FLUORESCENTE DE 2 X 36 W. A/F | Material |  | 169.9 |
| REFLECTOR METALICO LED C/EQUIPO Y LAMP. 200W | Material |  | 364.9 |
| REMACHE | Material |  | 0.05 |
| ARTEFACTO FLUORESCENTE DE 2 X 18 W. A/F | Material |  | 149.9 |
| BRAQUETE C/EQUIPO Y LAMPARA DE 70 W | Material |  | 180 |
| ARANDELA DE 1/4" | Material |  | 0.1 |
| ARANDELA DE 1" | Material |  | 1 |
| CABLE PATCH CORD UTP 6A DE 1M LSZH | Material |  | 55.9 |
| CABLE PATCH CORD UTP 6A DE 3M LSZH | Material |  | 72.8 |
| TUERCA HEXAGONAL 5/8" | Material |  | 2.5 |
| CANALETA METALICA 1/27 | Material |  | 35.85 |
| UNION TRANSICION AC. A PVC DE 2" | Material |  | 7.5 |
| TUERCA FIERRO 1" | Material |  | 2 |
| CONECTOR PVC 25 mm. | Material |  | 0.55 |
| CONECTOR HDMI | Material |  | 29.5 |
| CLAVE HDMI | Material |  | 5.3 |
| CONECTORES DE COBRE TIPO A/B | Material |  | 12.5 |
| VARILLA DE COBRE DE 3/4" X 2.40 m | Material |  | 250 |
| REGISTRO C/ TAPA POZO DE PUESTA A TIERRA | Material |  | 150 |
| DOSIS ECOGEL 8KG. | Material |  | 50 |
| CARBON VEJETAL (25KG) | Material |  | 35 |
| ELECTRODO E-6011-CELLOCORD | Material |  | 12.2 |
| BENTONITA SODICA (50 KG) | Material |  | 55 |
| CABLE UTP CAT 6 A 4 | Material |  | 3.5 |
| TARUGO DE PVC | Material |  | 0.05 |
| TABLERO METALICO DE 12 POLOS | Material |  | 134.66 |
| TABLERO METALICO DE 30 POLOS | Material |  | 479.9 |
| TABLERO DE CONTROL Y MANDO DE ELECTROBOMBA | Material |  | 600 |
| SUMINISTRO DE ENERGIA ELECTRICA (GE) | Material |  | 600 |
| APOYO METALICO EN CADA SOPORTE TEE Y CODO H=0.62-0.80 | Material |  | 15 |
| HOJA DE SIERRA | Material |  | 6.36 |
| RUEDA CON SOPORTE Y GUIA | Material |  | 26.8 |
| VENTANA METALICA INCLUYENDO ACCESORIOS | Material |  | 180 |
| JEBE MICROPOROSO 1"X1CM | Material |  | 218.5 |
| HIPOCLORITO DE CALCIO 70% | Material |  | 14.24 |
| SOMBRERO P/ TIRAFON DE 1/4" | Material |  | 0.13 |
| ARCOS DE FULBITO | Material |  | 3500 |
| SELLO BUTYL DE 3/32" x 3/4" | Material |  | 2.8 |
| PERFIL "L" DE 1"X1"X1/8" | Material |  | 6.24 |
| SWITCH 24 PUERTOS 10/100/1000 BASE-T PoE | Material |  | 2714 |
| SWITCH 48 PUERTOS 10/100/1000 BASE-T PoE | Material |  | 4169 |
| ROUTER 10/100/1000 Mbit/s MEMORIA 2048 MB | Material |  | 2540 |
| AGUA | Material |  | 6.36 |
| PEGAMENTO EN BASE A CAUCHO SISNTETICO | Material |  | 41.8 |
| PATCH PANEL 110 DE 24 PUERTOS CAT 6A | Material |  | 224 |
| PATCH PANEL 110 DE 48 PUERTOS CAT 6A | Material |  | 336 |
| ESPUMA PLASTICA DURA A/DENSIDAD 2.00x1.00 M. E=2" | Material |  | 31.1 |
| PRUEBA ELECTRICA Y PUESTA EN SERVICIO | Material |  | 1200 |
| LIMPIEZA PERMANENTE DE OBRA | Material |  | 900 |
| UPS-ESTABILIZADOR VOLTAJE 15KVA 3/220V 60Hz | Material |  | 2000 |
| ADAPTADOR ETHERNET | Material |  | 768 |
| PIZARRA ACRILICA INC. ACCESORIOS | Material |  | 350 |
| AUTOMATICOS DE NIVEL | Material |  | 59.24 |
| SENSOR CONTROL DE NIVEL DE COMBUSTIBLE | Material |  | 315 |
| MOVILIZACION Y DESMOVILIZACION DE EQUIPOS | Material |  | 12500.4 |
| CANDADO DE 60 mm. INC. ALDABAS | Material |  | 46 |
| AFIRMADO | Material |  | 40 |
| ELAB. IMPLEMNT. Y ADMINIST. DEL PLAN DE SEG. Y SALUD | Material |  | 2500 |
| BASE GRANULAR | Material |  | 60 |
| NIVEL | Equipo | 12 |  |
| ROTOMARTILLO | Equipo | 8 |  |
| TEODOLITO | Equipo | 15 |  |
| MIRAS y JALONES | Equipo | 6 |  |
| HERRAMIENTAS MANUALES | Equipo | 8 |  |
| VOLQUETE DE 10M3 | Equipo | 180 |  |
| SOLDADORA ELECTRICA | Equipo | 15 |  |
| MOTOBOMBA | Equipo | 16 |  |
| PLANCHA COMPACTADORA VIBRAT. 7 HP | Equipo | 12.5 |  |
| MARTILLO NEUMATICO (para compresora) | Equipo | 9 |  |
| COMPRESORA NEUMATICA | Equipo | 90 |  |
| CARGADOR FRONTAL | Equipo | 250 |  |
| RETROEXCAVADORA S/ LLANTAS | Equipo | 220 |  |
| TRACTOR DE ORUGAS DE 190-240 HP | Equipo | 330 |  |
| MOTONIVELADORA 130 - 135 HP | Equipo | 180 |  |
| GRUA | Equipo | 220 |  |
| VIBRADOR PARA CONCRETO | Equipo | 9 |  |
| VIBRADOR DE CONCRETO 4 HP 2.4" | Equipo | 9 |  |
| MEZCLADORA DE 9-11P3 | Equipo | 15 |  |
| ANDAMIO METALICO | Equipo | 10 |  |
| MOCHILA PULVERIZADORA | Equipo | 9.5 |  |
| TECLE 5 TON | Equipo | 12.5 |  |

## Schedule

| ID | WBS | Task | Type | Duration | Start | Finish | Predecessors | Total slack | Free slack | Constraint | Resources | Work | Cost | Text1 | Text8 | Text2 | Text3 | Text4 | Text6 |
| --- | --- | --- | --- | --- | --- | --- | --- | --- | --- | --- | --- | --- | --- | --- | --- | --- | --- | --- | --- |
| 1 | 1 | **PROGRAMACION GANTT DE LA I.E. N° 14970 - C.P. EL BARCO - SECHURA** |  | 240d | 2023-12-01 | 2024-07-27 |  |  |  |  |  | 36209.1h | 3,604,759.58 |  |  |  |  |  |  |
| 2 | 1.1 | INICIO DE OBRA | milestone | 0d | 2023-12-01 | 2023-12-01 |  | 0d |  |  |  |  |  |  |  |  |  |  |  |
| 3 | 1.2 | **OBRAS PROVISIONALES Y TRABAJOS PRELIMINARES** |  | 125d | 2023-12-01 | 2024-04-03 |  | 0d |  |  |  | 3284.03h | 178,202.36 | 01 | 000000000000001 |  |  |  |  |
| 4 | 1.2.1 | **OBRAS PROVISIONALES** |  | 7d | 2023-12-01 | 2023-12-07 |  | 0d |  |  |  | 123.5h | 45,001.95 | 01.01 | 000000000000002 |  |  |  |  |
| 5 | 1.2.1.1 | ALMACEN OFICINA Y CASETA DE GUARDIANIA |  | 1d | 2023-12-01 | 2023-12-01 | 2 | 0d |  | start no earlier than 2022-05-16 | OFICIAL [75%]; PEON [75%]; CLAVOS P/ MADERA CON CABEZA 2" 2 1/2" 3" 4" [150%]; MADERA TORNILLO [18000%]; CALAMINA GALVANIZADA DE 0.22 mm X 0.80 X 3.60 m. [1650%]; TRIPLAY DE 1.20 X 2.40 m X 6 mm. [2250%] | 6h | 2,458.28 | 01.01.01 | 000000000000003 | 30 | 94.18 | 2825.4 | 20 |
| 6 | 1.2.1.2 | CARTEL DE LA OBRA DE 3.60 X 2.40 m. |  | 1d | 2023-12-01 | 2023-12-02 | 5 | 0d |  | start no earlier than 2022-05-16 | CEMENTO PORTLAND TIPO MS (42.5 kg) [200%]; OPERARIO; PEON; CLAVOS P/ MADERA CON CABEZA 2" 2 1/2" 3" 4" [50%]; HORMIGON [36%]; MADERA TORNILLO [5000%]; GIGANTOGRAFIA DE 3.60X2.40 M.; TRIPLAY DE 1.20 X 2.40 m X 4 mm. [300%] | 10h | 895.28 | 01.01.02 | 000000000000004 |  | 1040.51 | 1040.51 |  |
| 7 | 1.2.1.3 | BAÑOS PORTATILES |  | 1d | 2023-12-02 | 2023-12-02 | 6SS | 237d | 0d | start no earlier than 2022-05-16 | BAÑOS QUIMICOS [200%] | 10h | 3,000 | 01.01.03 | 000000000000005 |  | 1500 | 3000 |  |
| 8 | 1.2.1.4 | CERCO PROVISIONAL DE TRIPLAY |  | 5d | 2023-12-02 | 2023-12-07 | 6 | 233d |  | start no earlier than 2022-05-16 | CEMENTO PORTLAND TIPO MS (42.5 kg) [7200%]; OFICIAL [10%]; PEON [200%]; ALAMBRE NEGRO N° 16 [4000%]; CLAVOS P/ MADERA CON CABEZA 2" 2 1/2" 3" 4" [4000%]; HORMIGON [800%]; AGUA [200%]; MADERA TORNILLO [112000%]; TRIPLAY DE 1.20 X 2.40 m X 4 mm. [33200%] | 52.5h | 21,347.96 | 01.01.04 | 000000000000006 | 400 | 83.32 | 33328 | 10 |
| 9 | 1.2.1.5 | MOVILIZACION Y DESMOVILIZACION DE EQUIPOS |  | 1d | 2023-12-02 | 2023-12-02 | 6SS | 237d | 0d | start no earlier than 2022-05-16 | MOVILIZACION Y DESMOVILIZACION DE EQUIPOS | 5h | 12,500.43 | 01.01.05 | 000000000000007 |  | 12500.43 | 12500.43 |  |
| 10 | 1.2.1.6 | SUMINISTRO DE ENERGIA ELECTRICA |  | 1d | 2023-12-03 | 2023-12-03 | 7 | 237d |  | start no earlier than 2022-05-16 | SUMINISTRO DE ENERGIA ELECTRICA (GE) [800%] | 40h | 4,800 | 01.01.06 | 000000000000008 |  | 600 | 4800 |  |
| 11 | 1.2.2 | **REMOCION** |  | 3d | 2023-12-03 | 2023-12-05 |  | 0d |  |  |  | 59.2h | 1,125.25 | 01.02 | 000000000000009 |  |  |  |  |
| 12 | 1.2.2.1 | DESMONTAJE DE COCINA DE TRIPLAY |  | 1d | 2023-12-03 | 2023-12-03 | 6 | 0d |  | start no earlier than 2022-05-16 | OPERARIO [9.3%]; PEON [186.7%]; ANDAMIO METALICO [46.7%] | 12.13h | 209.44 | 01.02.01 | 000000000000011 | 28 | 36.87 | 1032.36 | 10 |
| 13 | 1.2.2.2 | DESMONTAJE DE COBERTURA LIVIANA |  | 1d | 2023-12-03 | 2023-12-03 | 12SS | 0d |  | start no earlier than 2022-05-16 | OPERARIO [9.5%]; OFICIAL [94.8%]; PEON [94.8%]; SOLDADORA ELECTRICA [47.4%]; ANDAMIO METALICO [94.8%] | 17.06h | 281.31 | 01.02.02 | 000000000000012 | 47.4 | 9.7 | 459.78 | 50 |
| 14 | 1.2.2.3 | RETIRO DE JUEGOS INFANTILES |  | 2d | 2023-12-04 | 2023-12-05 | 18 | 0d |  | start no earlier than 2022-05-16 | OPERARIO; PEON [200%] | 30h | 634.5 | 01.02.03 | 000000000000014 |  | 261.41 | 1568.46 |  |
| 15 | 1.2.3 | **DEMOLICIONES** |  | 1d | 2023-12-03 | 2023-12-03 |  | 0d |  |  |  | 17.74h | 939.24 | 01.03 | 000000000000015 |  |  |  |  |
| 16 | 1.2.3.1 | DEMOLICION DE S.H. DE LADRILLO |  | 1d | 2023-12-03 | 2023-12-03 | 13SS | 0d |  | start no earlier than 2022-05-16 | OPERARIO [4.9%]; PEON [98.8%]; MARTILLO NEUMATICO (para compresora) [49.4%]; COMPRESORA NEUMATICA [49.4%]; TRACTOR DE ORUGAS DE 190-240 HP [24.7%] | 11.36h | 750.51 | 01.03.01 | 000000000000017 | 14.82 | 81.35 | 1205.61 | 30 |
| 17 | 1.2.3.2 | DEMOLICION DE LAVADERO DE CONCRETO |  | 1d | 2023-12-03 | 2023-12-03 | 16SS | 0d |  | start no earlier than 2022-05-16 | OPERARIO [1.8%]; PEON [72%]; MARTILLO NEUMATICO (para compresora) [18%]; COMPRESORA NEUMATICA [18%] | 5.49h | 158.53 | 01.03.02 | 000000000000018 | 3.6 | 71.39 | 257 | 20 |
| 18 | 1.2.3.3 | DEMOLICION DE PISOS Y VEREDAS DE CONCRETO |  | 1d | 2023-12-03 | 2023-12-03 | 17SS | 0d |  | start no earlier than 2022-05-16 | OPERARIO [0.4%]; PEON [8.7%]; MARTILLO NEUMATICO (para compresora) [4.3%]; COMPRESORA NEUMATICA [4.3%] | 0.89h | 30.21 | 01.03.03 | 000000000000019 | 3.48 | 14.01 | 48.75 | 80 |
| 19 | 1.2.4 | **SEGURIDAD Y SALUD EN LA OBRA** |  | 2d | 2023-12-03 | 2023-12-04 |  | 236d |  |  |  | 65h | 21,036.68 | 01.04 | 000000000000020 |  |  |  |  |
| 20 | 1.2.4.1 | ELAB., IMPLEMNT. Y ADMINIST. DEL PLAN DE SEG. Y SALUD |  | 1d | 2023-12-03 | 2023-12-03 | 6 | 236d | 0d | start no earlier than 2022-05-16 | ELAB. IMPLEMNT. Y ADMINIST. DEL PLAN DE SEG. Y SALUD | 5h | 2,500 | 01.04.01 | 000000000000021 |  | 2500 | 2500 |  |
| 21 | 1.2.4.2 | SEÑALIZACION TEMPORAL DE SEGURIDAD |  | 1d | 2023-12-04 | 2023-12-04 | 20 | 236d | 0d | start no earlier than 2022-05-16 | SEÑALIZACION TEMPORAL | 5h | 1,200 | 01.04.02 | 000000000000022 |  | 1200 | 1200 |  |
| 22 | 1.2.4.3 | CAPACITACION EN SEGURIDAD Y SALUD |  | 1d | 2023-12-04 | 2023-12-04 | 21SS | 236d | 0d | start no earlier than 2022-05-16 | CAPACITACION EN SEGURIDAD Y SALUD | 5h | 16,000 | 01.04.03 | 000000000000023 |  | 16000 | 16000 |  |
| 23 | 1.2.4.4 | RECURSOS PARA RESPUESTA ANTE EMERGENCIA EN SEGURIDAD Y SALUD EN EL TRABAJO |  | 1d | 2023-12-04 | 2023-12-04 | 22SS | 236d |  | start no earlier than 2022-05-16 | CILINDRO VACIO ABIERTO [300%]; BOTIQUIN [200%]; CAMILLA [200%]; EXTINTOR DE POLVO SECO [300%] | 50h | 1,336.68 | 01.04.04 | 000000000000024 |  | 1336.68 | 1336.68 |  |
| 24 | 1.2.5 | **MITIGACION AMBIENTAL** |  | 1d | 2023-12-03 | 2023-12-03 |  | 237d |  |  |  | 5h | 10,000 | 01.05 | 000000000000026 |  |  |  |  |
| 25 | 1.2.5.1 | MITIGACION DEL IMPACTO AMBIENTAL |  | 1d | 2023-12-03 | 2023-12-03 | 6 | 237d | 0d | start no earlier than 2022-05-16 | MITIGACION AMBIENTAL | 5h | 10,000 | 01.05.01 | 000000000000027 |  | 10000 | 10000 |  |

| ID | WBS | Task | Duration | Start | Finish | Predecessors | Total slack | Free slack | Constraint | Resources | Work | Cost | Text1 | Text8 | Text3 | Text4 | Text2 | Text6 |
| --- | --- | --- | --- | --- | --- | --- | --- | --- | --- | --- | --- | --- | --- | --- | --- | --- | --- | --- |
| 26 | 1.2.6 | **PROTECCION DE RESTOS ARQUEOLOGICOS** | 1d | 2023-12-03 | 2023-12-03 |  | 237d |  |  |  | 5h | 10,000 | 01.06 | 000000000000028 |  |  |  |  |
| 27 | 1.2.6.1 | PLAN DE MONITOREO ARQUEOLOGICO | 1d | 2023-12-03 | 2023-12-03 | 25SS | 237d |  | start no earlier than 2022-05-16 | PLAN DE MONITOREO ARQUEOLOGICO | 5h | 10,000 | 01.06.01 | 000000000000029 | 10000 | 10000 |  |  |
| 28 | 1.2.7 | **PLAN DE CONTINGENCIA** | 1d | 2023-12-03 | 2023-12-03 |  | 237d |  |  |  | 5h | 25,000 | 01.07 | 000000000000429 |  |  |  |  |
| 29 | 1.2.7.1 | PLAN DE CONTINGENCIA (600.00 m2) | 1d | 2023-12-03 | 2023-12-03 | 6 | 237d |  | start no earlier than 2022-05-16 | PLAN DE CONTINGENCIA | 5h | 25,000 | 01.07.01 | 000000000000430 | 25000 | 25000 |  |  |
| 30 | 1.2.8 | **TRABAJOS PRELIMINARES** | 120d | 2023-12-06 | 2024-04-03 |  | 0d |  |  |  | 3003.59h | 65,099.24 | 01.08 | 000000000000030 |  |  |  |  |
| 31 | 1.2.8.1 | LIMPIEZA DE TERRENO MANUAL | 2d | 2023-12-06 | 2023-12-07 | 14 | 0d |  | start no earlier than 2022-05-16 | PEON | 9.98h | 185.9 | 01.08.01 | 000000000000031 | 1.53 | 15267.41 | 9978.7 | 100 |
| 32 | 1.2.8.2 | TRAZO Y REPLANTEO PRELIMINAR | 120d | 2023-12-06 | 2024-04-03 | 31SS | 0d |  | start no earlier than 2022-05-16 | YESO (25 KG) [49893.5%]; NIVEL; TEODOLITO [49.9%]; MIRAS y JALONES [49.9%]; OPERARIO; PEON [199.6%]; ACERO Fy = 4200 KG/CM2 (GRADO 60) [189595%]; CLAVOS P/ MADERA CON CABEZA 2" 2 1/2" 3" 4" [4989.4%]; MADERA TORNILLO [23948.9%] | 2993.61h | 64,913.34 | 01.08.02 | 000000000000033 | 2.76 | 27541.21 | 9978.7 | 500 |
| 33 | 1.3 | **ESTRUCTURAS** | 152d | 2023-12-06 | 2024-05-05 |  | 0d |  |  |  | 26756.2h | 2,170,501.75 | 02 | 000000000000035 |  |  |  |  |
| 34 | 1.3.1 | **MOVIMIENTO DE TIERRAS** | 80d | 2023-12-06 | 2024-02-23 |  | 0d |  |  |  | 18981.8h | 694,814.47 | 02.01 | 000000000000036 |  |  |  |  |
| 35 | 1.3.1.1 | CORTE DE TERRENO A NIVEL DE PLATAFORMA | 1d | 2023-12-06 | 2023-12-06 | 32SS | 0d |  | start no earlier than 2022-05-16 | OPERARIO [84.7%]; PEON [169.4%]; MOTONIVELADORA 130 - 135 HP [84.7%] | 16.94h | 1,031.15 | 02.01.01 | 000000000000343 | 3.38 | 1659.85 | 491.08 | 580 |
| 36 | 1.3.1.2 | EXCAVACION DE ZANJAS P/ CIMIENTOS, VIGA DE CIMENT. Y ZAPATAS | 5d | 2023-12-07 | 2023-12-11 | 35 | 21d | 0d | start no earlier than 2022-05-16 | PEON | 24.95h | 464.87 | 02.01.02 | 000000000000037 | 43.86 | 22676.5 | 517.02 | 3.5 |
| 37 | 1.3.1.3 | EXCAVACION MASIVA PARA PLATEA | 10d | 2023-12-07 | 2023-12-16 | 35 | 0d |  | start no earlier than 2022-05-16 | PEON [195.9%]; RETROEXCAVADORA S/ LLANTAS [98.1%] | 147.02h | 12,620.06 | 02.01.03 | 000000000000038 | 6.89 | 16207.83 | 2352.37 | 300 |
| 38 | 1.3.1.4 | EXCAVACION DE ZANJAS PARA CISTERNA | 1d | 2023-12-17 | 2023-12-17 | 37 | 223d |  | start no earlier than 2022-05-16 | PEON [98.6%] | 4.93h | 91.83 | 02.01.04 | 000000000000347 | 76.76 | 1816.14 | 23.66 |  |
| 39 | 1.3.1.5 | ENTIBADO PARA EXCAVACIONES DE ZANJAS | 15d | 2023-12-12 | 2023-12-26 | 37FS-5d | 214d |  | start no earlier than 2022-05-16 | OPERARIO; OFICIAL; PEON; TABLERO FENOLICO e=12mm. INC. APUNTALAMIENTO [212040%] | 221.94h | 168,153.24 | 02.01.05 | 000000000000039 | 83.19 | 174649.92 | 2099.41 | 100 |
| 40 | 1.3.1.6 | RELLENO COMPACTADO C/ MATERIAL DE PRESTAMO | 5d | 2024-01-28 | 2024-02-02 | 74 | 116d | 0d | start no earlier than 2022-05-16 | PEON [99%]; PLANCHA COMPACTADORA VIBRAT. 7 HP [99%]; MATERIAL DE PRESTEMO (CANTERA) [37886.2%] | 49.52h | 12,136.7 | 02.01.06 | 000000000000040 | 79.76 | 24174.46 | 303.09 |  |
| 41 | 1.3.1.7 | CAPA DE PIEDRA OVER e=0.40 m. | 10d | 2023-12-21 | 2023-12-31 | 49 | 0d |  | start no earlier than 2022-05-16 | PEON; PLANCHA COMPACTADORA VIBRAT. 7 HP [49.9%]; PIEDRA OVER [59146.2%] | 74.87h | 36,729.56 | 02.01.07 | 000000000000041 | 108.92 | 51537.68 | 473.17 |  |
| 42 | 1.3.1.8 | RELLENO C/ MATERIAL GRANULAR e=0.30 m. | 5d | 2023-12-11 | 2023-12-16 | 36 | 21d | 0d | start no earlier than 2022-05-16 | OPERARIO [89.7%]; PEON [89.7%]; PLANCHA COMPACTADORA VIBRAT. 7 HP [89.7%]; AGUA [161.5%]; AFIRMADO [10092.5%] | 67.28h | 5,332.83 | 02.01.08 | 000000000000042 | 97.06 | 7836.62 | 80.74 | 10 |
| 43 | 1.3.1.9 | RELLENO C/ MATERIAL GRANULAR e=0.40 m. | 5d | 2023-12-31 | 2024-01-05 | 41 | 0d |  | start no earlier than 2022-05-16 | OPERARIO [98.6%]; PEON [98.6%]; PLANCHA COMPACTADORA VIBRAT. 7 HP [98.6%]; AGUA [946.3%]; AFIRMADO [59146.2%] | 73.93h | 25,131.3 | 02.01.09 | 000000000000043 | 97.06 | 45925.88 | 473.17 | 10 |
| 44 | 1.3.1.10 | RELLENO C/ MATERIAL GRANULAR e=0.70 m. | 1d | 2023-12-11 | 2023-12-12 | 36 | 228d |  | start no earlier than 2022-05-16 | OPERARIO [86.7%]; PEON [86.7%]; PLANCHA COMPACTADORA VIBRAT. 7 HP [86.7%]; AGUA [97.1%]; AFIRMADO [6068.8%] | 13h | 2,682.15 | 02.01.10 | 000000000000044 | 108.79 | 5281.75 | 48.55 |  |
| 45 | 1.3.1.11 | RELLENO COMPACTADO C/EQUIPO DE ARENA FINA | 5d | 2024-02-02 | 2024-02-07 | 40 | 116d | 0d | start no earlier than 2022-05-16 | PEON [99.3%]; PLANCHA COMPACTADORA VIBRAT. 7 HP [99.3%]; ARENA FINA [62587.5%]; AGUA [1001.4%] | 49.67h | 22,742.45 | 02.01.11 | 000000000000045 | 86.14 | 43130.3 | 500.7 |  |
| 46 | 1.3.1.12 | BASE GRANULAR P/ PISOS, PATIOS Y VEREDAS | 8d | 2024-02-15 | 2024-02-23 | 50 | 116d | 0d | start no earlier than 2022-05-16 | OFICIAL; PEON [199.2%]; PLANCHA COMPACTADORA VIBRAT. 7 HP; AGUA [3386.8%]; BASE GRANULAR [31751.6%] | 159.38h | 22,069.89 | 02.01.12 | 000000000000046 | 17.15 | 29042.15 | 1693.42 | 100 |
| 47 | 1.3.1.13 | BASE GRANULAR EN LOSA DEPORTIVA e=0.40 m. | 1d | 2024-02-15 | 2024-02-16 | 50 | 162d |  | start no earlier than 2022-05-16 | OFICIAL; PEON [200%]; PLANCHA COMPACTADORA VIBRAT. 7 HP; AGUA [1280%]; BASE GRANULAR [32000%] | 20h | 19,633.21 | 02.01.13 | 000000000000431 | 37.34 | 23897.6 | 640 | 80 |
| 48 | 1.3.1.14 | RIEGO DEL FONDO DE CIMENTACION | 5d | 2023-12-16 | 2023-12-21 | 37 | 0d |  | start no earlier than 2022-05-16 | PEON [76.1%]; MANGUERA 5/8" [152145%]; AGUA [15214.5%] | 19.02h | 3,041.19 | 02.01.14 | 000000000000047 | 2.08 | 3164.62 | 1521.45 | 500 |
| 49 | 1.3.1.15 | REFINE Y COMPACTACION DE FONDO DE CIMENTACION | 5d | 2023-12-16 | 2023-12-21 | 48SS | 0d |  | start no earlier than 2022-05-16 | OPERARIO [9.5%]; PEON [190.2%]; PLANCHA COMPACTADORA VIBRAT. 7 HP [95.1%]; AGUA [9128.7%] | 73.7h | 1,825.77 | 02.01.15 | 000000000000048 | 4.67 | 7105.17 | 1521.45 | 100 |
| 50 | 1.3.1.16 | PERFILADO Y COMPACTADO DE PISOS, PATIOS Y VEREDAS | 8d | 2024-02-07 | 2024-02-15 | 45 | 116d | 0d | start no earlier than 2022-05-16 | OPERARIO [9.7%]; PEON [97.2%]; PLANCHA COMPACTADORA VIBRAT. 7 HP [97.2%]; AGUA [4200.2%] | 81.67h | 1,579.64 | 02.01.16 | 000000000000049 | 2.86 | 6673.58 | 2333.42 | 100 |
| 51 | 1.3.1.17 | ACARREO DE MATERIAL EXCEDENTE Dp= 30 m. | 5d | 2023-12-17 | 2023-12-21 | 37 | 209d | 0d | start no earlier than 2022-05-16 | PEON [70409.4%] | 17602.3h | 327,931.81 | 02.01.17 | 000000000000050 | 25.59 | 108109.31 | 4224.67 |  |
| 52 | 1.3.1.18 | ELIMINACIÓN DE MATERIAL EXCEDENTE C/EQUIPO Dp=5 KM. | 10d | 2023-12-22 | 2023-12-31 | 51 | 209d |  | start no earlier than 2022-05-16 | OPERARIO [94%]; PEON [187.6%]; VOLQUETE DE 10M3 [187.6%]; CARGADOR FRONTAL [94%] | 281.64h | 31,616.82 | 02.01.18 | 000000000000051 | 18.01 | 76086.31 | 4224.67 | 300 |

| ID | WBS | Task | Duration | Start | Finish | Predecessors | Total slack | Free slack | Constraint | Resources | Work | Cost | Text1 | Text8 | Text2 | Text3 | Text4 | Text6 |
| --- | --- | --- | --- | --- | --- | --- | --- | --- | --- | --- | --- | --- | --- | --- | --- | --- | --- | --- |
| 53 | 1.3.2 | **OBRAS DE CONCRETO SIMPLE** | 85d | 2023-12-16 | 2024-03-10 |  | 20d |  |  |  | 1877.98h | 156,918.1 | 02.02 | 000000000000052 |  |  |  |  |
| 54 | 1.3.2.1 | SOLADO e=0.10 m., C:H 1:8 | 5d | 2023-12-16 | 2023-12-21 | 42 | 21d | 0d | start no earlier than 2022-05-16 | CEMENTO PORTLAND TIPO MS (42.5 kg) [10655.8%]; OPERARIO [170.1%]; OFICIAL [85%]; PEON [510.3%]; MEZCLADORA DE 9-11P3 [85%]; HORMIGON [3766.3%]; AGUA [566.5%] | 212.63h | 9,049.46 | 02.02.01 | 000000000000053 | 306.2 | 43.06 | 13184.97 | 60 |
| 55 | 1.3.2.2 | SOLADO e=0.10 m., CONCRETO F'c=140 KG/CM2 | 8d | 2024-01-05 | 2024-01-13 | 43 | 0d |  | start no earlier than 2022-05-16 | CEMENTO PORTLAND TIPO MS (42.5 kg) [87059%]; ADITIVO CURADOR [2363%]; OPERARIO [88.8%]; OFICIAL [88.8%]; PEON [533%]; VIBRADOR PARA CONCRETO [44.4%]; MEZCLADORA DE 9-11P3 [88.8%]; PIEDRA CHANCADA 1/2" [7959.7%]; ARENA GRUESA [6342.9%]; AGUA [2300.8%] | 337.58h | 43,800.93 | 02.02.02 | 000000000000054 | 124.37 | 374.44 | 46569.1 | 20 |
| 56 | 1.3.2.3 | CIMIENTOS CORRIDOS CONCRETO 1:8+30%P.G. | 10d | 2023-12-21 | 2023-12-31 | 54 | 21d | 0d | start no earlier than 2022-05-16 | CEMENTO PORTLAND TIPO MS (42.5 kg) [87964%]; OPERARIO [194.4%]; OFICIAL [97.2%]; PEON [777.8%]; MEZCLADORA DE 9-11P3 [97.2%]; PIEDRA GRANDE DE 8" [11880.2%]; HORMIGON [19716.1%]; AGUA [4676.2%] | 583.32h | 53,764.42 | 02.02.03 | 000000000000055 | 252.77 | 264.59 | 66880.41 | 20 |
| 57 | 1.3.2.4 | SOBREC. SIMPLES, CONCRETO F'c=175 KG/CM2 | 1d | 2024-02-24 | 2024-02-25 | 63 | 153d | 0d | start no earlier than 2022-05-16 | CEMENTO PORTLAND TIPO MS (42.5 kg) [539.5%]; ADITIVO CURADOR [12.2%]; OPERARIO [5.3%]; OFICIAL [5.3%]; PEON [32%]; VIBRADOR PARA CONCRETO [2.7%]; MEZCLADORA DE 9-11P3 [5.3%]; PIEDRA CHANCADA 1/2" [41.6%]; ARENA GRUESA [34.6%]; AGUA [11.8%] | 2.53h | 268.52 | 02.02.04 | 000000000000056 | 0.64 | 467.24 | 299.03 | 12 |
| 58 | 1.3.2.5 | SOBREC. SIMPLES, ENCOFRADO Y DESENCOFRADO | 1d | 2024-02-24 | 2024-02-25 | 57SS | 153d |  | start no earlier than 2022-05-16 | OPERARIO [53.1%]; OFICIAL [53.1%]; ALAMBRE NEGRO N° 8 [220.7%]; CLAVOS P/ MADERA CON CABEZA 2" 2 1/2" 3" 4" [110.4%]; MADERA TORNILLO [3056.4%] | 5.31h | 363.35 | 02.02.05 | 000000000000057 | 8.49 | 52.28 | 443.86 | 16 |
| 59 | 1.3.2.6 | CUNETA, CONCRETO F'c=175 KG/CM2 | 5d | 2024-03-04 | 2024-03-09 | 151 | 139d | 0d | start no earlier than 2022-05-16 | CEMENTO PORTLAND TIPO MS (42.5 kg) [10099.1%]; ADITIVO CURADOR [227.6%]; OPERARIO; OFICIAL; PEON [599%]; VIBRADOR PARA CONCRETO [49.9%]; MEZCLADORA DE 9-11P3; PIEDRA CHANCADA 1/2" [778.7%]; ARENA GRUESA [646.9%]; AGUA [221.6%] | 237.11h | 8,581.79 | 02.02.06 | 000000000000058 | 11.98 | 467.24 | 5597.54 | 12 |
| 60 | 1.3.2.7 | CUNETA, ENCOFRADO Y DESENCOFRADO | 5d | 2024-03-04 | 2024-03-09 | 59SS | 139d | 0d | start no earlier than 2022-05-16 | OPERARIO [89.7%]; OFICIAL [89.7%]; ALAMBRE NEGRO N° 8 [2611.4%]; CLAVOS P/ MADERA CON CABEZA 2" 2 1/2" 3" 4" [1305.7%]; MADERA TORNILLO [36158.4%] | 44.84h | 3,878.92 | 02.02.07 | 000000000000059 | 100.44 | 52.28 | 5251 | 16 |
| 61 | 1.3.2.8 | DADO, CONCRETO F'c=175 KG/CM2 | 1d | 2024-03-09 | 2024-03-10 | 60 | 139d |  | start no earlier than 2022-05-16 | CEMENTO PORTLAND TIPO MS (42.5 kg) [244.5%]; ADITIVO CURADOR [5.5%]; OPERARIO [2.4%]; OFICIAL [2.4%]; PEON [14.5%]; VIBRADOR PARA CONCRETO [1.2%]; MEZCLADORA DE 9-11P3 [2.4%]; PIEDRA CHANCADA 1/2" [18.9%]; ARENA GRUESA [15.7%]; AGUA [5.4%] | 1.15h | 121.67 | 02.02.08 | 000000000000060 | 0.29 | 467.24 | 135.5 | 12 |
| 62 | 1.3.2.9 | FALSO PISO, CONCRETO F'c=175 KG/CM2 e=0.10 m. | 8d | 2024-02-23 | 2024-03-02 | 46 | 147d | 0d | start no earlier than 2022-05-16 | CEMENTO PORTLAND TIPO MS (42.5 kg) [65075.4%]; OPERARIO [96.5%]; OFICIAL [96.5%]; PEON [772%]; VIBRADOR PARA CONCRETO [48.2%]; MEZCLADORA DE 9-11P3 [96.5%]; PIEDRA CHANCADA 1/2" [6175.6%]; ARENA GRUESA [4631.7%]; AGUA [1389.5%] | 443.87h | 35,939.09 | 02.02.09 | 000000000000061 | 771.95 | 53.49 | 41291.61 | 100 |
| 63 | 1.3.2.10 | CURADO EN PISOS Y VEREDAS C/ ADITIVO | 1d | 2024-02-23 | 2024-02-24 | 62SS | 153d | 0d | start no earlier than 2022-05-16 | CURADOR MENBRANIL [3859.7%]; PEON [96.5%]; MOCHILA PULVERIZADORA [96.5%]; AGUA [77.2%] | 9.65h | 1,149.95 | 02.02.10 | 000000000000062 | 771.95 | 3.61 | 2786.74 | 100 |
| 64 | 1.3.3 | **OBRAS DE CONCRETO ARMADO** | 90d | 2023-12-31 | 2024-03-30 |  | 13d |  |  |  | 4854.4h | 1,152,733.53 | 02.03 | 000000000000063 |  |  |  |  |
| 65 | 1.3.3.1 | ZAPATAS, CONCRETOF'C=210KG/CM2 | 1d | 2023-12-31 | 2024-01-01 | 56 | 21d | 0d | start no earlier than 2022-05-16 | CEMENTO PORTLAND TIPO MS (42.5 kg) [33639.6%]; ADITIVO CURADOR [658.9%]; OPERARIO [86.7%]; OFICIAL [86.7%]; PEON [867%]; VIBRADOR DE CONCRETO 4 HP 2.4" [43.4%]; MEZCLADORA DE 9-11P3 [86.7%]; PIEDRA CHANCADA 1/2" [2219.5%]; ARENA GRUESA [1803.4%]; AGUA [641.6%] | 58.52h | 14,264.68 | 02.03.01 | 000000000000064 | 34.68 | 483.59 | 16770.9 | 20 |
| 66 | 1.3.3.2 | ZAPATAS, ENCOFRADO Y DESENCOFRADO | 1d | 2023-12-31 | 2024-01-01 | 65SS | 208d | 0d | start no earlier than 2022-05-16 | OPERARIO [92.5%]; OFICIAL [92.5%]; ALAMBRE NEGRO N° 8 [2308.8%]; CLAVOS P/ MADERA CON CABEZA 2" 2 1/2" 3" 4" [1154.4%]; MADERA TORNILLO [31968%] | 9.25h | 2,718.35 | 02.03.02 | 000000000000065 | 88.8 | 52.28 | 4642.46 | 16 |
| 67 | 1.3.3.3 | ZAPATAS, ACERO Fy=4200KG/CM2 | 1d | 2023-12-31 | 2024-01-01 | 66SS | 208d |  | start no earlier than 2022-05-16 | OPERARIO; OFICIAL; ALAMBRE NEGRO N° 16 [2495.5%]; ACERO Fy = 4200 KG/CM2 (GRADO 60) [52405.5%] | 9.98h | 2,491.71 | 02.03.03 | 000000000000066 | 499.1 | 6.08 | 3034.53 | 250 |
| 68 | 1.3.3.4 | VIGA CIMENT., CONCRETOF'C=210KG/CM2 | 1d | 2024-01-01 | 2024-01-02 | 65 | 21d | 0d | start no earlier than 2022-05-16 | CEMENTO PORTLAND TIPO MS (42.5 kg) [1425.9%]; ADITIVO CURADOR [27.9%]; OPERARIO [9.2%]; OFICIAL [9.2%]; PEON [91.9%]; VIBRADOR DE CONCRETO 4 HP 2.4" [4.6%]; MEZCLADORA DE 9-11P3 [9.2%]; PIEDRA CHANCADA 1/2" [94.1%]; ARENA GRUESA [76.4%]; AGUA [27.2%] | 6.2h | 674.26 | 02.03.04 | 000000000000344 | 1.47 | 509.55 | 749.04 | 16 |
| 69 | 1.3.3.5 | VIGA CIMENT., ENCOFRADO Y DESENCOFRADO | 1d | 2024-01-01 | 2024-01-02 | 68SS | 21d | 0d | start no earlier than 2022-05-16 | OPERARIO [36.8%]; OFICIAL [36.8%]; ALAMBRE NEGRO N° 8 [152.9%]; CLAVOS P/ MADERA CON CABEZA 2" 2 1/2" 3" 4" [76.4%]; MADERA TORNILLO [2116.8%] | 3.67h | 251.65 | 02.03.05 | 000000000000345 | 5.88 | 52.28 | 307.41 | 16 |
| 70 | 1.3.3.6 | VIGA CIMENT., ACERO Fy=4200KG/CM2 | 1d | 2024-01-01 | 2024-01-02 | 69SS | 21d |  | start no earlier than 2022-05-16 | OPERARIO [45%]; OFICIAL [45%]; ALAMBRE NEGRO N° 16 [562.8%]; ACERO Fy = 4200 KG/CM2 (GRADO 60) [11818.8%] | 4.5h | 614.61 | 02.03.06 | 000000000000346 | 112.56 | 6.08 | 684.36 | 250 |
| 71 | 1.3.3.7 | PLATEA, CONCRETO F'C=210KG/CM2 | 10d | 2024-01-13 | 2024-01-23 | 55 | 0d |  | start no earlier than 2022-05-16 | CEMENTO PORTLAND TIPO MS (42.5 kg) [456356%]; ADITIVO CURADOR [8938.9%]; OPERARIO [98%]; OFICIAL [98%]; PEON [980.1%]; VIBRADOR DE CONCRETO 4 HP 2.4" [49%]; MEZCLADORA DE 9-11P3 [98%]; PIEDRA CHANCADA 1/2" [30110.1%]; ARENA GRUESA [24464.4%]; AGUA [8703.7%] | 661.6h | 191,039.41 | 02.03.07 | 000000000000067 | 470.47 | 483.59 | 227514.59 | 20 |
| 72 | 1.3.3.8 | PLATEA, ENCOFRADO Y DESENCOFRADO | 10d | 2024-01-13 | 2024-01-23 | 71SS | 186d | 0d | start no earlier than 2022-05-16 | OPERARIO [92.1%]; OFICIAL [92.1%]; ALAMBRE NEGRO N° 8 [4214.6%]; CLAVOS P/ MADERA CON CABEZA 2" 2 1/2" 3" 4" [2107.3%]; MADERA TORNILLO [58356%] | 92.1h | 6,721.92 | 02.03.08 | 000000000000068 | 162.1 | 52.28 | 8474.59 | 16 |
| 73 | 1.3.3.9 | PLATEA, ACERO F'y=4200KG/CM2 | 10d | 2024-01-13 | 2024-01-23 | 72SS | 186d |  | start no earlier than 2022-05-16 | OPERARIO; OFICIAL; ALAMBRE NEGRO N° 16 [208309%]; ACERO Fy = 4200 KG/CM2 (GRADO 60) | 99.79h | 190,833.6 | 02.03.09 | 000000000000069 | 41661.85 | 6.08 | 253304.05 | 250 |
| 74 | 1.3.3.10 | SOBREC. REF., CONCRETOF'C=210KG/CM2 | 5d | 2024-01-23 | 2024-01-28 | 71, 70 | 0d |  | start no earlier than 2022-05-16 | CEMENTO PORTLAND TIPO MS (42.5 kg) [111046%]; ADITIVO CURADOR [2175.1%]; OPERARIO [95.4%]; OFICIAL [95.4%]; PEON [954%]; VIBRADOR DE CONCRETO 4 HP 2.4" [47.7%]; MEZCLADORA DE 9-11P3 [95.4%]; PIEDRA CHANCADA 1/2" [7326.7%]; ARENA GRUESA [5953%]; AGUA [2117.9%] | 321.98h | 49,498.06 | 02.03.10 | 000000000000070 | 114.48 | 552.8 | 63284.54 | 12 |
| 75 | 1.3.3.11 | SOBREC. REF., ENCOFRADO Y DESENCOFRADO | 5d | 2024-01-23 | 2024-01-28 | 74SS | 181d | 0d | start no earlier than 2022-05-16 | OPERARIO [98.4%]; OFICIAL [98.4%]; ALAMBRE NEGRO N° 8 [16379%]; CLAVOS P/ MADERA CON CABEZA 2" 2 1/2" 3" 4" [8189.5%]; MADERA TORNILLO [226786%] | 49.22h | 18,900.59 | 02.03.11 | 000000000000071 | 629.96 | 52.28 | 32934.31 | 16 |
| 76 | 1.3.3.12 | SOBREC. REF., ACERO Fy=4200KG/CM2 | 5d | 2024-01-23 | 2024-01-28 | 75SS | 181d |  | start no earlier than 2022-05-16 | OPERARIO [98.3%]; OFICIAL [98.3%]; ALAMBRE NEGRO N° 16 [65109.7%]; ACERO Fy = 4200 KG/CM2 (GRADO 60) | 49.14h | 60,067.34 | 02.03.12 | 000000000000072 | 13021.93 | 6.08 | 79173.33 | 250 |
| 77 | 1.3.3.13 | COLUMNAS, CONCRETOF'C=210KG/CM2 | 10d | 2024-02-12 | 2024-02-22 | 126 | 0d |  | start no earlier than 2022-05-16 | CEMENTO PORTLAND TIPO MS (42.5 kg) [155578%]; ADITIVO CURADOR [3047.4%]; OPERARIO [94.3%]; OFICIAL [94.3%]; PEON [943.5%]; VIBRADOR DE CONCRETO 4 HP 2.4" [47.2%]; MEZCLADORA DE 9-11P3 [94.3%]; PIEDRA CHANCADA 1/2" [10265%]; ARENA GRUESA [8340.3%]; AGUA [2967.2%] | 636.84h | 72,823.55 | 02.03.13 | 000000000000073 | 160.39 | 587.41 | 94214.69 | 10 |
| 78 | 1.3.3.14 | COLUMNAS, ENCOFRADO Y DESENCOFRADO | 10d | 2024-02-12 | 2024-02-22 | 77SS | 156d | 0d | start no earlier than 2022-05-16 | OPERARIO; OFICIAL; ALAMBRE NEGRO N° 8 [50011.5%]; CLAVOS P/ MADERA CON CABEZA 2" 2 1/2" 3" 4" [28339.8%]; MADERA TORNILLO [700161%] | 99.95h | 57,278.08 | 02.03.14 | 000000000000074 | 1667.05 | 65.09 | 108508.28 | 12 |
| 79 | 1.3.3.15 | COLUMNAS, ACERO Fy=4200KG/CM2 | 10d | 2024-02-12 | 2024-02-22 | 78SS | 156d |  | start no earlier than 2022-05-16 | OPERARIO; OFICIAL; ALAMBRE NEGRO N° 16 [128142%]; ACERO Fy = 4200 KG/CM2 (GRADO 60) | 99.53h | 118,283.87 | 02.03.15 | 000000000000075 | 25628.34 | 6.08 | 155820.31 | 250 |
| 80 | 1.3.3.16 | VIGAS, CONCRETOF'C=210KG/CM2 | 10d | 2024-02-22 | 2024-03-03 | 77 | 0d |  | start no earlier than 2022-05-16 | CEMENTO PORTLAND TIPO MS (42.5 kg) [113694%]; ADITIVO CURADOR [2227%]; OPERARIO [97.7%]; OFICIAL [97.7%]; PEON [976.8%]; VIBRADOR DE CONCRETO 4 HP 2.4" [48.8%]; MEZCLADORA DE 9-11P3 [97.7%]; PIEDRA CHANCADA 1/2" [7501.4%]; ARENA GRUESA [6094.9%]; AGUA [2168.4%] | 659.31h | 56,846.28 | 02.03.16 | 000000000000076 | 117.21 | 483.59 | 56681.58 | 20 |
| 81 | 1.3.3.17 | VIGAS, ENCOFRADO Y DESENCOFRADO | 10d | 2024-02-22 | 2024-03-03 | 80SS | 146d | 0d | start no earlier than 2022-05-16 | OPERARIO; OFICIAL; ALAMBRE NEGRO N° 8 [29285.1%]; CLAVOS P/ MADERA CON CABEZA 2" 2 1/2" 3" 4" [23428.1%]; MADERA TORNILLO [409991%] | 99.61h | 34,890.12 | 02.03.17 | 000000000000077 | 976.17 | 71.91 | 70196.38 | 10 |
| 82 | 1.3.3.18 | VIGAS, ACERO Fy=4200KG/CM2 | 10d | 2024-02-22 | 2024-03-03 | 81SS | 146d |  | start no earlier than 2022-05-16 | OPERARIO; OFICIAL; ALAMBRE NEGRO N° 16 [102162%]; ACERO Fy = 4200 KG/CM2 (GRADO 60) | 99.67h | 94,778.36 | 02.03.18 | 000000000000078 | 20432.44 | 6.08 | 124229.24 | 250 |
| 83 | 1.3.3.19 | LOSA MACIZA, CONCRETOF'C=210KG/CM2 | 1d | 2024-03-13 | 2024-03-14 | 86 | 134d | 0d | start no earlier than 2022-05-16 | CEMENTO PORTLAND TIPO MS (42.5 kg) [2851.8%]; ADITIVO CURADOR [55.9%]; OPERARIO [14.7%]; OFICIAL [14.7%]; PEON [147%]; VIBRADOR DE CONCRETO 4 HP 2.4" [7.3%]; MEZCLADORA DE 9-11P3 [14.7%]; PIEDRA CHANCADA 1/2" [188.2%]; ARENA GRUESA [152.9%]; AGUA [54.4%] | 9.92h | 1,302.12 | 02.03.19 | 000000000000079 | 2.94 | 483.59 | 1421.75 | 20 |
| 84 | 1.3.3.20 | LOSA MACIZA, ENCOFRADO Y DESENCOFRADO | 1d | 2024-03-13 | 2024-03-14 | 83SS | 135d | 0d | start no earlier than 2022-05-16 | OPERARIO [92.1%]; OFICIAL [92.1%]; ALAMBRE NEGRO N° 8 [851.4%]; CLAVOS P/ MADERA CON CABEZA 2" 2 1/2" 3" 4" [928.8%]; MADERA TORNILLO [16254%] | 9.21h | 1,488.76 | 02.03.20 | 000000000000080 | 38.7 | 60.43 | 2338.64 | 14 |
| 85 | 1.3.3.21 | LOSA MACIZA, ACERO Fy=4200KG/CM2 | 1d | 2024-03-13 | 2024-03-14 | 84SS | 135d |  | start no earlier than 2022-05-16 | OPERARIO [72.7%]; OFICIAL [72.7%]; ALAMBRE NEGRO N° 16 [909.2%]; ACERO Fy = 4200 KG/CM2 (GRADO 60) [19093.2%] | 7.27h | 992.9 | 02.03.21 | 000000000000081 | 181.84 | 6.08 | 1105.59 | 250 |
| 86 | 1.3.3.22 | LOSA ALIGERADA, CONCRETO F'C=210KG/CM2 | 10d | 2024-03-03 | 2024-03-13 | 80 | 0d |  | start no earlier than 2022-05-16 | CEMENTO PORTLAND TIPO MS (42.5 kg) [96379.2%]; ADITIVO CURADOR [1887.8%]; OPERARIO [99.4%]; OFICIAL [99.4%]; PEON [993.6%]; VIBRADOR DE CONCRETO 4 HP 2.4" [49.7%]; MEZCLADORA DE 9-11P3 [99.4%]; PIEDRA CHANCADA 1/2" [6359%]; ARENA GRUESA [5166.7%]; AGUA [1838.2%] | 670.68h | 50,280.56 | 02.03.22 | 000000000000082 | 99.36 | 483.59 | 48049.5 | 20 |
| 87 | 1.3.3.23 | LOSA ALIGERADA , ENCOFRADO Y DESENCOFRADO | 10d | 2024-03-03 | 2024-03-13 | 86SS | 126d | 0d | start no earlier than 2022-05-16 | OPERARIO; OFICIAL; ALAMBRE NEGRO N° 8 [27057.4%]; CLAVOS P/ MADERA CON CABEZA 2" 2 1/2" 3" 4" [29517.1%]; MADERA TORNILLO [516550%] | 99.82h | 42,797.67 | 02.03.23 | 000000000000083 | 1229.88 | 60.43 | 74321.65 | 14 |
| 88 | 1.3.3.24 | LOSA ALIGERADA, ACERO Fy=4200KG/CM2 | 10d | 2024-03-13 | 2024-03-23 | 87 | 126d |  | start no earlier than 2022-05-16 | OPERARIO [97.5%]; OFICIAL [97.5%]; ALAMBRE NEGRO N° 16 [20714.2%]; ACERO Fy = 4200 KG/CM2 (GRADO 60) [434998%] | 97.48h | 21,024.79 | 02.03.24 | 000000000000084 | 4142.84 | 6.08 | 25188.47 | 250 |
| 89 | 1.3.3.25 | LOSA ALIGERADA, LADRILLO HUECO 15X30X30 CM. | 10d | 2024-03-13 | 2024-03-23 | 87 | 126d |  | start no earlier than 2022-05-16 | OPERARIO [98.3%]; PEON [786.3%]; LADRILLO PARA TECHO 8H DE 15X30X30 cm [990780%] | 442.31h | 36,749.98 | 02.03.25 | 000000000000085 | 9436 | 3.89 | 36706.04 | 1600 |
| 90 | 1.3.3.26 | ESCALERA, CONCRETO F'C=210KG/CM2 | 1d | 2024-03-13 | 2024-03-14 | 86 | 0d |  | start no earlier than 2022-05-16 | CEMENTO PORTLAND TIPO MS (42.5 kg) [6421.4%]; ADITIVO CURADOR [125.8%]; OPERARIO [55.2%]; OFICIAL [55.2%]; PEON [551.7%]; VIBRADOR DE CONCRETO 4 HP 2.4" [27.6%]; MEZCLADORA DE 9-11P3 [55.2%]; PIEDRA CHANCADA 1/2" [423.7%]; ARENA GRUESA [344.2%]; AGUA [122.5%] | 37.24h | 3,210.68 | 02.03.26 | 000000000000086 | 6.62 | 552.8 | 3659.54 | 12 |
| 91 | 1.3.3.27 | ESCALERA, ENCOFRADO Y DESENCOFRADO | 1d | 2024-03-13 | 2024-03-14 | 90SS | 135d | 0d | start no earlier than 2022-05-16 | OPERARIO [91%]; OFICIAL [91%]; ALAMBRE NEGRO N° 8 [841.1%]; CLAVOS P/ MADERA CON CABEZA 2" 2 1/2" 3" 4" [649.9%]; MADERA TORNILLO [16056.6%] | 9.1h | 1,455.46 | 02.03.27 | 000000000000087 | 38.23 | 60.03 | 2294.95 | 14 |
| 92 | 1.3.3.28 | ESCALERA, ACERO F'y=4200KG/CM2 | 1d | 2024-03-13 | 2024-03-14 | 91SS | 135d |  | start no earlier than 2022-05-16 | OPERARIO [61.9%]; OFICIAL [61.9%]; ALAMBRE NEGRO N° 16 [1548.2%]; ACERO Fy = 4200 KG/CM2 (GRADO 60) [32513.2%] | 6.19h | 1,545.9 | 02.03.28 | 000000000000088 | 309.65 | 6.08 | 1882.67 | 250 |
| 93 | 1.3.3.29 | CISTERNA, CONCRETO F'C=210KG/CM2 | 2d | 2024-01-13 | 2024-01-15 | 55 | 190d | 0d | start no earlier than 2022-05-16 | CEMENTO PORTLAND TIPO MS (42.5 kg) [5849.1%]; ADITIVO CURADOR [114.6%]; OPERARIO [60.3%]; OFICIAL [60.3%]; PEON [603%]; VIBRADOR DE CONCRETO 4 HP 2.4" [30.1%]; MEZCLADORA DE 9-11P3 [60.3%]; PIEDRA CHANCADA 1/2" [385.9%]; ARENA GRUESA [313.6%]; AGUA [111.6%] | 81.41h | 3,813.01 | 02.03.29 | 000000000000348 | 6.03 | 587.41 | 3542.08 | 10 |
| 94 | 1.3.3.30 | CISTERNA, ENCOFRADO Y DESENCOFRADO | 2d | 2024-01-13 | 2024-01-15 | 93SS | 194d | 0d | start no earlier than 2022-05-16 | OPERARIO [97.3%]; OFICIAL [97.3%]; ALAMBRE NEGRO N° 8 [599.5%]; CLAVOS P/ MADERA CON CABEZA 2" 2 1/2" 3" 4" [463.2%]; MADERA TORNILLO [11445%] | 19.46h | 1,341 | 02.03.30 | 000000000000349 | 27.25 | 60.03 | 1635.82 | 14 |
| 95 | 1.3.3.31 | CISTERNA, ACERO F'y=4200KG/CM2 | 2d | 2024-01-13 | 2024-01-15 | 94SS | 194d |  | start no earlier than 2022-05-16 | OPERARIO [79.8%]; OFICIAL [79.8%]; ALAMBRE NEGRO N° 16 [1994.2%]; ACERO Fy = 4200 KG/CM2 (GRADO 60) [41877.2%] | 15.95h | 2,177.73 | 02.03.31 | 000000000000350 | 398.83 | 6.08 | 2424.89 | 250 |
| 96 | 1.3.3.32 | TANQUE ELEVADO, CONCRETO F'C=210KG/CM2 | 4d | 2024-01-15 | 2024-01-19 | 93 | 190d | 0d | start no earlier than 2022-05-16 | CEMENTO PORTLAND TIPO MS (42.5 kg) [2735.4%]; ADITIVO CURADOR [53.6%]; OPERARIO [28.2%]; OFICIAL [28.2%]; PEON [282%]; VIBRADOR DE CONCRETO 4 HP 2.4" [14.1%]; MEZCLADORA DE 9-11P3 [28.2%]; PIEDRA CHANCADA 1/2" [180.5%]; ARENA GRUESA [146.6%]; AGUA [52.2%] | 76.14h | 2,495.5 | 02.03.32 | 000000000000351 | 2.82 | 587.41 | 1656.5 | 10 |
| 97 | 1.3.3.33 | TANQUE ELEVADO, ENCOFRADO Y DESENCOFRADO | 4d | 2024-01-15 | 2024-01-19 | 96SS | 190d | 0d | start no earlier than 2022-05-16 | OPERARIO [93.4%]; OFICIAL [93.4%]; ALAMBRE NEGRO N° 8 [575.1%]; CLAVOS P/ MADERA CON CABEZA 2" 2 1/2" 3" 4" [444.4%]; MADERA TORNILLO [10978.8%] | 37.34h | 1,723.17 | 02.03.33 | 000000000000352 | 26.14 | 60.03 | 1569.18 | 14 |
| 98 | 1.3.3.34 | TANQUE ELEVADO, ACERO F'y=4200KG/CM2 | 4d | 2024-01-15 | 2024-01-19 | 97SS | 190d |  | start no earlier than 2022-05-16 | OPERARIO [39.7%]; OFICIAL [39.7%]; ALAMBRE NEGRO N° 16 [496.1%]; ACERO Fy = 4200 KG/CM2 (GRADO 60) [10419.1%] | 15.88h | 820.41 | 02.03.34 | 000000000000353 | 99.23 | 6.08 | 603.32 | 250 |
| 99 | 1.3.3.35 | FALSA COLUMNA (0.25X0.20) F'C=175KG/CM2, INC. ENCOF. Y DESENC. | 4d | 2024-02-22 | 2024-02-26 | 77 | 152d |  | start no earlier than 2022-05-16 | CEMENTO PORTLAND TIPO MS (42.5 kg) [2269.8%]; OPERARIO [81.2%]; OFICIAL [81.2%]; PEON [487.5%]; MEZCLADORA DE 9-11P3 [40.6%]; ALAMBRE NEGRO N° 16 [2600%]; ALAMBRE NEGRO N° 8 [1300%]; ACERO Fy = 4200 KG/CM2 (GRADO 60) [5850%]; CLAVOS P/ MADERA CON CABEZA 2" 2 1/2" 3" 4" [650%]; PIEDRA CHANCADA 1/2" [182%]; ARENA GRUESA [143%]; AGUA [48.1%]; MADERA TORNILLO [24960%] | 138.12h | 5,966.28 | 02.03.35 | 000000000000089 | 26 | 296.52 | 7709.52 |  |
| 100 | 1.3.3.36 | GARGOLA DE CONCRETO S/ DISEÑO | 1d | 2024-03-29 | 2024-03-30 | 140 | 119d |  | start no earlier than 2022-05-16 | CEMENTO PORTLAND TIPO MS (42.5 kg) [96%]; OPERARIO; OFICIAL; PEON [200%]; ALAMBRE NEGRO N° 16 [28%]; ALAMBRE NEGRO N° 8 [32%]; ACERO Fy = 4200 KG/CM2 (GRADO 60) [600%]; CLAVOS P/ MADERA CON CABEZA 2" 2 1/2" 3" 4" [40%]; PIEDRA CHANCADA 1/2" [5.6%]; ARENA FINA [4.8%]; ARENA GRUESA [4%]; AGUA [3.2%]; MADERA TORNILLO [1160%] | 20h | 571.18 | 02.03.36 | 000000000000090 |  | 105.45 | 843.6 |  |

| ID | WBS | Task | Duration | Start | Finish | Predecessors | Total slack | Free slack | Constraint | Resources | Work | Cost | Text1 | Text8 | Text2 | Text3 | Text4 | Text6 |
| --- | --- | --- | --- | --- | --- | --- | --- | --- | --- | --- | --- | --- | --- | --- | --- | --- | --- | --- |
| 101 | 1.3.4 | **ESTRUCTURA METALICA Y COBERTURA EN LOSA** | 15d | 2024-04-15 | 2024-04-30 |  | 83d |  |  |  | 695.52h | 134,218.58 | 02.04 | 000000000000091 |  |  |  |  |
| 102 | 1.3.4.1 | TIJERAL T-1 C/ANG. 2" X 2" X 3/16" + FIERRO LISO 1/2" EN TECHO PARABOLICO | 10d | 2024-04-15 | 2024-04-25 | 169 | 83d | 0d | start no earlier than 2022-05-16 | PINTURA ESMALTE [1173.6%]; PINTURA ANTICORROSIVA [978%]; THINNER [978%]; OPERARIO [195.6%]; OFICIAL [97.8%]; PEON [195.6%]; SOLDADORA ELECTRICA [195.6%]; SOLDADURA CELLOCORD [29340%]; ANGULO 2" x 2" x 3/16" [80196%]; HOJA DE SIERRA [4498.8%]; FIERRO LISO DE 1/2" X 6.00 m. [68460%] | 342.3h | 37,918.08 | 02.04.01 | 000000000000092 | 195.6 | 302.35 | 59139.66 |  |
| 103 | 1.3.4.2 | VIGUETA DE FIERRO CORRUGADO Ø 1/2" - C/ANG. 1"X1"X1/8" EN TECHO PARABOLICO | 6d | 2024-04-21 | 2024-04-26 | 102FS-5d | 83d | 0d | start no earlier than 2022-05-16 | PINTURA ESMALTE [1206%]; PINTURA ANTICORROSIVA [1206%]; THINNER [402%]; OPERARIO [98.5%]; OFICIAL [98.5%]; PEON [98.5%]; SOLDADORA ELECTRICA [98.5%]; SOLDADURA CELLOCORD [8040%]; ANGULO DE F° 1"x1"x1/8" [82410%]; HOJA DE SIERRA [804%]; FIERRO LISO DE 1/2" X 6.00 m. [48642%] | 114.29h | 23,435.65 | 02.04.02 | 000000000000093 | 402 | 134.96 | 54253.92 |  |
| 104 | 1.3.4.3 | TENSOR DE FIERRO LISO Ø 5/8" | 1d | 2024-04-26 | 2024-04-27 | 103 | 83d | 0d | start no earlier than 2022-05-16 | PINTURA ESMALTE [128%]; PINTURA ANTICORROSIVA [128%]; THINNER [128%]; OPERARIO [19.7%]; PEON [19.7%]; SOLDADORA ELECTRICA [49.2%]; SOLDADURA CELLOCORD [1280%]; FIERRO LISO DE 5/8" x 6m [2560%] | 4.43h | 1,283.92 | 02.04.03 | 000000000000094 | 128 | 22.57 | 2888.96 | 10 |
| 105 | 1.3.4.4 | TENSOR DE FIERRO LISO Ø 1" | 1d | 2024-04-26 | 2024-04-27 | 104SS | 83d | 0d | start no earlier than 2022-05-16 | PINTURA ESMALTE [168%]; PINTURA ANTICORROSIVA [168%]; THINNER [168%]; OPERARIO [19.8%]; PEON [19.8%]; SOLDADORA ELECTRICA [49.4%]; SOLDADURA CELLOCORD [1680%]; ARANDELA DE 1" [16800%]; TUERCA FIERRO 1" [16800%]; FIERRO LISO DE 1" x 6m [3360%] | 4.45h | 2,536.07 | 02.04.04 | 000000000000095 | 168 | 27.78 | 4667.04 | 10 |
| 106 | 1.3.4.5 | TORNILLO SIN FIN PARA TENSOR LISO 1" | 1d | 2024-04-26 | 2024-04-27 | 105SS | 83d | 0d | start no earlier than 2022-05-16 | PINTURA ESMALTE [16%]; PINTURA ANTICORROSIVA [16%]; THINNER [16%]; OPERARIO [16%]; PEON [16%]; SOLDADORA ELECTRICA [40%]; SOLDADURA CELLOCORD [160%] | 3.6h | 105.56 | 02.04.05 | 000000000000096 | 16 | 15.65 | 250.4 | 10 |
| 107 | 1.3.4.6 | ARANDELA DE 5/8" C/OJO CHINO DE 1" | 1d | 2024-04-26 | 2024-04-27 | 106SS | 83d | 0d | start no earlier than 2022-05-16 | PINTURA ESMALTE [16%]; PINTURA ANTICORROSIVA [16%]; THINNER [16%]; OPERARIO [32%]; PEON [32%]; SOLDADORA ELECTRICA [16%]; FIERRO LISO DE 5/8" [6480%]; SOLDADURA CELLOCORD [160%] | 4h | 354.1 | 02.04.06 | 000000000000097 | 16 | 25.27 | 404.32 | 50 |
| 108 | 1.3.4.7 | ARRIOSTRES DE SAN ANDRES ENTRE TIJERALES Ø 3/8" | 1d | 2024-04-26 | 2024-04-27 | 107SS | 83d | 0d | start no earlier than 2022-05-16 | PINTURA ESMALTE [336%]; PINTURA ANTICORROSIVA [336%]; THINNER [1680%]; OPERARIO [28.2%]; PEON [28.2%]; SOLDADORA ELECTRICA [49.4%]; SOLDADURA CELLOCORD [3360%]; FIERRO LISO DE 1/2" X 6.00 m. [6048%] | 5.29h | 2,553.88 | 02.04.07 | 000000000000098 | 336 | 15.58 | 5234.88 | 20 |
| 109 | 1.3.4.8 | APOYO FIJO DE ARCO | 1d | 2024-04-26 | 2024-04-27 | 108SS | 83d | 0d | start no earlier than 2022-05-16 | PINTURA ESMALTE [48%]; PINTURA ANTICORROSIVA [40%]; THINNER [0.8%]; OPERARIO; OFICIAL; SOLDADORA ELECTRICA [10%]; SOLDADURA CELLOCORD [680%]; PLANCHA DE FIERRO E=1/2" X 1.20 X 2.40 [280%]; PERNOS DE ANCLAJE 5/8" X 0.3M [3200%]; TUERCA HEXAGONAL 5/8" [3200%]; FIERRO LISO DE 1/2" X 6.00 m. [200%] | 10.5h | 1,958.32 | 02.04.08 | 000000000000099 |  | 314.01 | 2512.08 |  |
| 110 | 1.3.4.9 | APOYO MOVIL DE ARCO | 1d | 2024-04-26 | 2024-04-27 | 109SS | 83d | 0d | start no earlier than 2022-05-16 | PINTURA ESMALTE [48%]; PINTURA ANTICORROSIVA [40%]; OPERARIO [88.9%]; OFICIAL [88.9%]; SOLDADORA ELECTRICA [8.9%]; SOLDADURA CELLOCORD [680%]; PLANCHA DE FIERRO E=1/2" X 1.20 X 2.40 [280%]; PERNOS DE ANCLAJE 5/8" X 0.3M [3200%]; TUERCA HEXAGONAL 5/8" [3200%] | 9.33h | 1,886.82 | 02.04.09 | 000000000000100 |  | 341.54 | 2732.32 |  |
| 111 | 1.3.4.10 | MONTAJE DE TIJERALES METALICOS PARABOLICOS | 1d | 2024-04-28 | 2024-04-28 | 110 | 83d | 0d | start no earlier than 2022-05-16 | OPERARIO [200%]; OFICIAL; PEON [400%]; GRUA [50%]; ANDAMIO METALICO; TECLE 5 TON | 47.5h | 1,400 | 02.04.10 | 000000000000101 |  | 1137.7 | 9101.6 |  |
| 112 | 1.3.4.11 | COBERTURA CALAMINON Cu 06 PERALTE=27 MM. INC. ANTICORR. Y ESMALTE | 2d | 2024-04-28 | 2024-04-30 | 111 | 83d | 0d | start no earlier than 2022-05-16 | PINTURA ESMALTE [7371%]; PINTURA ANTICORROSIVA CROMATO DE ZINC [6552%]; OPERARIO [199.8%]; OFICIAL; PEON [199.8%]; ANDAMIO METALICO [998.8%]; MADERA TORNILLO [40950%]; CALAMINON CU 06(CURVO) 1.08X180 E=0.4MM [45045%]; TOPE DE TUBO SEL [327600%]; GANCHO CON SOMBRERO TIPO "J" 1/4" X 4" [327600%] | 149.82h | 60,786.18 | 02.04.11 | 000000000000102 | 819 | 157.07 | 128640.33 | 20 |
| 113 | 1.3.5 | **ESTRUCTURA METALICA Y COBERTURA EN PATIO** | 5d | 2024-04-30 | 2024-05-05 |  | 83d |  |  |  | 346.43h | 31,817.08 | 02.05 | 000000000000103 |  |  |  |  |
| 114 | 1.3.5.1 | TIJERAL T-2 C/ANG. 1" X1" X 3/16" + FIERRO LISO 1/2" EN TECHO PATIO | 5d | 2024-04-30 | 2024-05-05 | 112 | 83d | 0d | start no earlier than 2022-05-16 | PINTURA ESMALTE [307.2%]; PINTURA ANTICORROSIVA [256%]; THINNER [256%]; OPERARIO [182.9%]; OFICIAL [91.4%]; PEON [182.9%]; SOLDADORA ELECTRICA [182.9%]; SOLDADURA CELLOCORD [7680%]; ANGULO 1" x 1" x 3/16" [20480%]; HOJA DE SIERRA [1177.6%]; FIERRO LISO DE 1/2" X 6.00 m. [17920%] | 160h | 11,029.32 | 02.05.01 | 000000000000104 | 51.2 | 296.36 | 15173.63 |  |
| 115 | 1.3.5.2 | VIGUETA DE FIERRO CORRUGADO Ø 1/2" - C/ANG. 1"X1"X1/8" EN TECHO PARABOLICO | 2d | 2024-04-30 | 2024-05-02 | 114SS | 85d | 0d | start no earlier than 2022-05-16 | PINTURA ESMALTE [236.2%]; PINTURA ANTICORROSIVA [236.2%]; THINNER [78.8%]; OPERARIO [98.4%]; OFICIAL [98.4%]; PEON [98.4%]; SOLDADORA ELECTRICA [98.4%]; SOLDADURA CELLOCORD [1575%]; ANGULO DE F° 1"x1"x1/8" [16143.8%]; HOJA DE SIERRA [157.5%]; FIERRO LISO DE 1/2" X 6.00 m. [9528.8%] | 39.38h | 4,932.43 | 02.05.02 | 000000000000105 | 78.75 | 134.96 | 10628.1 |  |
| 116 | 1.3.5.3 | TENSOR DE FIERRO LISO Ø 5/8" | 1d | 2024-04-30 | 2024-05-01 | 115SS | 85d | 0d | start no earlier than 2022-05-16 | PINTURA ESMALTE [24%]; PINTURA ANTICORROSIVA [24%]; THINNER [24%]; OPERARIO [16%]; PEON [16%]; SOLDADORA ELECTRICA [40%]; SOLDADURA CELLOCORD [240%]; FIERRO LISO DE 5/8" x 6m [480%] | 3.6h | 291.39 | 02.05.03 | 000000000000106 | 24 | 22.57 | 541.68 | 10 |
| 117 | 1.3.5.4 | TORNILLO SIN FIN PARA TENSOR LISO 1" | 1d | 2024-04-30 | 2024-05-01 | 116SS | 85d | 0d | start no earlier than 2022-05-16 | PINTURA ESMALTE [8%]; PINTURA ANTICORROSIVA [8%]; THINNER [8%]; OPERARIO [16%]; PEON [16%]; SOLDADORA ELECTRICA [40%]; SOLDADURA CELLOCORD [80%] | 3.6h | 85.71 | 02.05.04 | 000000000000107 |  | 15.65 | 125.2 | 10 |
| 118 | 1.3.5.5 | ARANDELA DE 5/8" C/OJO CHINO DE 1" | 1d | 2024-04-30 | 2024-05-01 | 117SS | 85d | 0d | start no earlier than 2022-05-16 | PINTURA ESMALTE [8%]; PINTURA ANTICORROSIVA [8%]; THINNER [8%]; OPERARIO [16%]; PEON [16%]; SOLDADORA ELECTRICA [8%]; FIERRO LISO DE 5/8" [3240%]; SOLDADURA CELLOCORD [80%] | 2h | 177.05 | 02.05.05 | 000000000000108 |  | 25.27 | 202.16 | 50 |
| 119 | 1.3.5.6 | ARRIOSTRES DE SAN ANDRES ENTRE TIJERALES Ø 3/8" | 1d | 2024-04-30 | 2024-05-01 | 118SS | 85d | 0d | start no earlier than 2022-05-16 | PINTURA ESMALTE [60%]; PINTURA ANTICORROSIVA [60%]; THINNER [300%]; OPERARIO [28.6%]; PEON [28.6%]; SOLDADORA ELECTRICA [50%]; SOLDADURA CELLOCORD [600%]; FIERRO LISO DE 1/2" X 6.00 m. [1080%] | 5.36h | 539.67 | 02.05.06 | 000000000000109 | 60 | 15.58 | 934.8 | 20 |
| 120 | 1.3.5.7 | APOYO FIJO DE ARCO | 1d | 2024-04-30 | 2024-05-01 | 119SS | 85d | 0d | start no earlier than 2022-05-16 | PINTURA ESMALTE [24%]; PINTURA ANTICORROSIVA [20%]; THINNER [0.4%]; OPERARIO; OFICIAL; SOLDADORA ELECTRICA [10%]; SOLDADURA CELLOCORD [340%]; PLANCHA DE FIERRO E=1/2" X 1.20 X 2.40 [140%]; PERNOS DE ANCLAJE 5/8" X 0.3M [1600%]; TUERCA HEXAGONAL 5/8" [1600%]; FIERRO LISO DE 1/2" X 6.00 m. | 10.5h | 1,099.89 | 02.05.07 | 000000000000354 |  | 314.01 | 1256.04 |  |
| 121 | 1.3.5.8 | APOYO MOVIL DE ARCO | 1d | 2024-04-30 | 2024-05-01 | 120SS | 85d | 0d | start no earlier than 2022-05-16 | PINTURA ESMALTE [24%]; PINTURA ANTICORROSIVA [20%]; OPERARIO [66.7%]; OFICIAL [66.7%]; SOLDADORA ELECTRICA [6.7%]; SOLDADURA CELLOCORD [340%]; PLANCHA DE FIERRO E=1/2" X 1.20 X 2.40 [140%]; PERNOS DE ANCLAJE 5/8" X 0.3M [1600%]; TUERCA HEXAGONAL 5/8" [1600%] | 7h | 997.06 | 02.05.08 | 000000000000355 |  | 341.54 | 1366.16 |  |
| 122 | 1.3.5.9 | MONTAJE DE TIJERALES T-2 | 1d | 2024-05-02 | 2024-05-02 | 121 | 85d | 0d | start no earlier than 2022-05-16 | OPERARIO [200%]; OFICIAL; PEON [400%]; GRUA [50%]; ANDAMIO METALICO; TECLE 5 TON | 47.5h | 1,400 | 02.05.09 | 000000000000110 |  | 1137.7 | 4550.8 |  |
| 123 | 1.3.5.10 | COBERTURA CALAMINON Cu 06 PERALTE=27 MM. INC. ANTICORR. Y ESMALTE | 1d | 2024-05-02 | 2024-05-03 | 122 | 85d |  | start no earlier than 2022-05-16 | PINTURA ESMALTE [1296%]; PINTURA ANTICORROSIVA CROMATO DE ZINC [1152%]; OPERARIO [180%]; OFICIAL [90%]; PEON [180%]; ANDAMIO METALICO [900%]; MADERA TORNILLO [7200%]; CALAMINON CU 06(CURVO) 1.08X180 E=0.4MM [7920%]; TOPE DE TUBO SEL [57600%]; GANCHO CON SOMBRERO TIPO "J" 1/4" X 4" [57600%] | 67.5h | 11,264.56 | 02.05.10 | 000000000000111 | 144 | 157.07 | 22618.08 | 20 |
| 124 | 1.4 | **ARQUITECTURA** | 240d | 2023-12-01 | 2024-07-27 |  | 0d |  |  |  | 3868h | 949,930.33 | 03 | 000000000000112 |  |  |  |  |
| 125 | 1.4.1 | **MUROS DE ALBAÑILERIA** | 30d | 2024-01-28 | 2024-02-27 |  | 0d |  |  |  | 344.43h | 104,300.7 | 03.01 | 000000000000113 |  |  |  |  |
| 126 | 1.4.1.1 | MURO DE LADRILLO KK DE ARCILLA CABEZA M: 1:4 e=1.5 CM. | 15d | 2024-01-28 | 2024-02-12 | 74 | 0d |  | start no earlier than 2022-05-16 | CEMENTO PORTLAND TIPO MS (42.5 kg) [30772.9%]; OPERARIO; PEON [74.9%]; ANDAMIO METALICO [49.9%]; CLAVOS PARA MADERA CON CABEZA DE 3" [1206.8%]; ARENA GRUESA [4223.7%]; AGUA [1206.8%]; LADRILLO KK TIPO IV DE 24X13X9 CM. | 168.44h | 48,341.09 | 03.01.01 | 000000000000114 | 603.39 | 131.58 | 79394.06 | 6.5 |
| 127 | 1.4.1.2 | MURO DE LADRILLO KK DE ARCILLA SOGA M: 1:4 e=1.5 CM. | 15d | 2024-02-12 | 2024-02-27 | 126 | 151d |  | start no earlier than 2022-05-16 | CEMENTO PORTLAND TIPO MS (42.5 kg) [28600.7%]; OPERARIO [99.4%]; PEON [74.6%]; ANDAMIO METALICO [49.7%]; CLAVOS P/ MADERA CON CABEZA 2" 2 1/2" 3" 4" [2487%]; ARENA GRUESA [3730.5%]; AGUA [1119.2%]; LADRILLO KK TIPO IV DE 24X13X9 CM. | 167.74h | 52,970.11 | 03.01.02 | 000000000000115 | 1243.51 | 81.1 | 100848.66 |  |
| 128 | 1.4.1.3 | ACERO DE REFUERZO HORIZONTAL EN MUROS | 1d | 2024-01-28 | 2024-01-29 | 126SS | 180d |  | start no earlier than 2022-05-16 | OPERARIO [82.4%]; OFICIAL [82.4%]; ALAMBRE NEGRO N° 16 [3090.6%]; ACERO Fy = 4200 KG/CM2 (GRADO 60) [64902.6%] | 8.24h | 2,989.5 | 03.01.03 | 000000000000116 | 618.12 | 6.08 | 3758.17 | 250 |

| ID | WBS | Task | Duration | Start | Finish | Predecessors | Total slack | Free slack | Constraint | Resources | Work | Cost | Text1 | Text8 | Text2 | Text3 | Text4 | Text6 |
| --- | --- | --- | --- | --- | --- | --- | --- | --- | --- | --- | --- | --- | --- | --- | --- | --- | --- | --- |
| 129 | 1.4.2 | **REVOQUES ENLUCIDOS Y MOLDURAS** | 19d | 2024-03-14 | 2024-04-02 |  | 0d |  |  |  | 309.96h | 54,151.36 | 03.02 | 000000000000117 |  |  |  |  |
| 130 | 1.4.2.1 | TARRAJEO RAYADO PRIMARIO | 1d | 2024-03-14 | 2024-03-15 | 131SS | 131d | 0d | start no earlier than 2022-05-16 | CEMENTO PORTLAND TIPO MS (42.5 kg) [2090.1%]; OPERARIO [99.2%]; PEON [49.6%]; CLAVOS P/ MADERA CON CABEZA 2" 2 1/2" 3" 4" [393%]; ARENA FINA [303.7%]; AGUA [89.3%]; MADERA TORNILLO [10361.1%] | 7.44h | 1,659.92 | 03.02.01 | 000000000000118 | 178.64 | 27.82 | 4969.76 | 15 |
| 131 | 1.4.2.2 | TARRAJEO MUROS Y SOBRECIMIENTOS C:A 1:5 e= 1.5 CM. | 15d | 2024-03-14 | 2024-03-29 | 90 | 0d |  | start no earlier than 2022-05-16 | CEMENTO PORTLAND TIPO MS (42.5 kg) [21788.8%]; OPERARIO [99.5%]; PEON [49.7%]; CLAVOS P/ MADERA CON CABEZA 2" 2 1/2" 3" 4" [4097%]; ARENA FINA [3724.6%]; AGUA [931.1%]; MADERA TORNILLO [108013%] | 111.92h | 18,312.29 | 03.02.02 | 000000000000119 | 1862.29 | 32.79 | 61064.49 | 12 |
| 132 | 1.4.2.3 | TARRAJEO DE COLUMNAS C:A 1:5,e=1.5 CM. | 5d | 2024-03-14 | 2024-03-19 | 131SS | 0d |  | start no earlier than 2022-05-16 | CEMENTO PORTLAND TIPO MS (42.5 kg) [29232.7%]; OPERARIO; PEON [49.8%]; CLAVOS P/ MADERA CON CABEZA 2" 2 1/2" 3" 4" [3572.9%]; ARENA FINA [3248.1%]; AGUA [649.6%]; MADERA TORNILLO [94194.3%] | 37.38h | 17,482.63 | 03.02.03 | 000000000000120 | 1624.04 | 42.74 | 69411.47 |  |
| 133 | 1.4.2.4 | TARRAJEO DE VIGAS C:A 1:5,e=1.5 CM. | 10d | 2024-03-19 | 2024-03-29 | 132 | 0d |  | start no earlier than 2022-05-16 | CEMENTO PORTLAND TIPO MS (42.5 kg) [17566.6%]; OPERARIO; PEON [50%]; ANDAMIO METALICO [50%]; CLAVOS P/ MADERA CON CABEZA 2" 2 1/2" 3" 4" [2147%]; ARENA FINA [1951.8%]; AGUA [390.4%] | 99.99h | 7,917.9 | 03.02.04 | 000000000000121 | 975.92 | 47.63 | 46483.07 |  |
| 134 | 1.4.2.5 | VESTIDURA DE DERRAMES C/MEZCLA 1:5 E =2CM | 4d | 2024-03-29 | 2024-04-02 | 140 | 116d |  | start no earlier than 2022-05-16 | CEMENTO PORTLAND TIPO MS (42.5 kg) [14485.3%]; OPERARIO [98.1%]; PEON [49.1%]; CLAVOS P/ MADERA CON CABEZA 2" 2 1/2" 3" 4" [1609.5%]; ARENA FINA [1609.5%]; AGUA [321.9%] | 29.44h | 5,546.92 | 03.02.05 | 000000000000123 | 804.74 | 20.67 | 16633.98 | 20 |
| 135 | 1.4.2.6 | REVESTIMIENTO DE PASOS Y CONTRAPASOS DE ESCALERA | 1d | 2024-03-30 | 2024-03-31 | 141 | 116d | 0d | start no earlier than 2022-05-16 | CEMENTO PORTLAND TIPO MS (42.5 kg) [1544%]; OPERARIO [95.3%]; PEON [47.7%]; CLAVOS P/ MADERA CON CABEZA 2" 2 1/2" 3" 4" [171.6%]; ARENA FINA [171.6%]; AGUA [34.3%] | 7.15h | 686.18 | 03.02.06 | 000000000000124 | 85.78 | 35.28 | 3026.32 | 10 |
| 136 | 1.4.2.7 | REVESTIMIENTO C/ CERAMICO 0.30 X 0.30 m. | 1d | 2024-03-14 | 2024-03-15 | 83 | 134d | 0d | start no earlier than 2022-05-16 | PEGAMENTO DE CERAMICO (25 KG) [1107.2%]; OPERARIO [92.3%]; OFICIAL [46.1%]; PORCELANA DE COLOR [1107.2%]; CERAMICO 0.30 X 0.30 m. [4650.4%]; AGUA [22.1%] | 6.92h | 1,543.3 | 03.02.07 | 000000000000125 | 44.29 | 56.11 | 2485.11 | 12 |
| 137 | 1.4.2.8 | RODOPLAST EN ARISTAS | 1d | 2024-03-14 | 2024-03-15 | 136SS | 134d |  | start no earlier than 2022-05-16 | OPERARIO [54%]; RODOPLAST [5459.1%] | 2.7h | 436.53 | 03.02.08 | 000000000000126 | 54.05 | 11.09 | 599.41 | 50 |
| 138 | 1.4.2.9 | TARRAJEO CON IMPERMEABILIZANTE | 1d | 2024-03-31 | 2024-04-01 | 135 | 117d |  | start no earlier than 2022-05-16 | CEMENTO PORTLAND TIPO MS (42.5 kg) [673.2%]; ADITIVO IMPERMEABILIZANTE [299.2%]; OPERARIO [93.5%]; PEON [46.8%]; CLAVOS P/ MADERA CON CABEZA 2" 2 1/2" 3" 4" [74.8%]; ARENA FINA [112.2%]; AGUA [37.4%] | 7.01h | 565.68 | 03.02.09 | 000000000000122 | 37.4 | 39.93 | 1493.38 | 10 |
| 139 | 1.4.3 | **CIELO RASOS** | 11d | 2024-03-19 | 2024-03-30 |  | 0d |  |  |  | 131.03h | 10,470.52 | 03.03 | 000000000000127 |  |  |  |  |
| 140 | 1.4.3.1 | CIELO RASO C/ MEZCLA C:A 1:4 e=1.5 CM. | 10d | 2024-03-19 | 2024-03-29 | 133SS | 0d |  | start no earlier than 2022-05-16 | CEMENTO PORTLAND TIPO MS (42.5 kg) [22147.2%]; OPERARIO; PEON; ANDAMIO METALICO [49.9%]; CLAVOS PARA MADERA CON CABEZA DE 3" [11073.6%]; ARENA FINA [2460.8%]; AGUA [492.2%] | 124.84h | 10,189.5 | 03.03.01 | 000000000000128 | 1230.4 | 57.43 | 70661.87 |  |
| 141 | 1.4.3.2 | REVESTIMIENTO EN FONDO DE ESCALERA | 1d | 2024-03-29 | 2024-03-30 | 140 | 116d | 0d | start no earlier than 2022-05-16 | CEMENTO PORTLAND TIPO MS (42.5 kg) [401.4%]; OPERARIO [82.6%]; PEON [41.3%]; CLAVOS P/ MADERA CON CABEZA 2" 2 1/2" 3" 4" [44.6%]; ARENA FINA [44.6%]; AGUA [8.9%] | 6.19h | 281.02 | 03.03.02 | 000000000000129 | 22.3 | 38.54 | 859.44 |  |
| 142 | 1.4.4 | **PISOS Y PAVIMENTOS** | 46d | 2024-02-23 | 2024-04-09 |  | 35d |  |  |  | 1810.22h | 163,373.8 | 03.04 | 000000000000130 |  |  |  |  |
| 143 | 1.4.4.1 | CONTRAPISO DE e= 35 mm. | 5d | 2024-03-29 | 2024-04-03 | 140 | 0d |  | start no earlier than 2022-05-16 | CEMENTO PORTLAND TIPO MS (42.5 kg) [25886%]; OPERARIO [90.8%]; PEON [545%]; ARENA GRUESA [4541.4%]; AGUA [90.8%]; MADERA TORNILLO [9082.8%] | 158.95h | 14,114.95 | 03.04.01 | 000000000000131 | 908.28 | 23.46 | 21308.25 | 100 |
| 144 | 1.4.4.2 | PISO CERAMICO 0.30 X 0.30 m. C/ CLARO | 2d | 2024-04-03 | 2024-04-05 | 143 | 112d | 0d | start no earlier than 2022-05-16 | PEGAMENTO DE CERAMICO (25 KG) [1889.5%]; OPERARIO [90%]; OFICIAL [45%]; PORCELANA DE COLOR [1889.5%]; CERAMICO 0.30 X 0.30 m. [7935.9%]; AGUA [37.8%] | 13.5h | 2,674.65 | 03.04.02 | 000000000000132 | 75.58 | 56.11 | 4240.79 | 12 |
| 145 | 1.4.4.3 | PISO CERAMICO 0.45 X 0.45 m. C/ CLARO | 10d | 2024-03-29 | 2024-04-08 | 143SS | 0d |  | start no earlier than 2022-05-16 | PEGAMENTO DE CERAMICO (25 KG) [19632%]; OPERARIO [99.2%]; OFICIAL [49.6%]; PORCELANA DE COLOR [19632%]; CERAMICO 0.45 X 0.45 m. [82454.4%]; AGUA [392.6%] | 74.36h | 27,853.08 | 03.04.03 | 000000000000133 | 785.28 | 58.23 | 45726.85 | 12 |
| 146 | 1.4.4.4 | PISO DE CEMENTO PULIDO Y BRUÑADO S/COLOREAR | 1d | 2024-04-08 | 2024-04-09 | 145 | 83d | 0d | start no earlier than 2022-05-16 | CEMENTO PORTLAND TIPO MS (42.5 kg) [1018.4%]; OPERARIO [84.9%]; PEON [42.4%]; ARENA FINA [50.9%]; AGUA [50.9%]; MADERA TORNILLO [509.2%] | 6.36h | 501.94 | 03.04.04 | 000000000000134 | 50.92 | 21.53 | 1096.31 | 20 |
| 147 | 1.4.4.5 | VEREDA, CONCRETO F´c=175 Kg/cm2 e=0.10 m. INC. ACABADO Y BRUÑADO | 10d | 2024-02-23 | 2024-03-04 | 46 | 116d | 0d | start no earlier than 2022-05-16 | CEMENTO PORTLAND TIPO MS (42.5 kg) [63176.1%]; OPERARIO [374.7%]; OFICIAL [93.7%]; PEON [562.1%]; VIBRADOR DE CONCRETO 4 HP 2.4" [46.8%]; MEZCLADORA DE 9-11P3 [93.7%]; PIEDRA CHANCADA 1/2" [6744.8%]; ARENA FINA [749.4%]; ARENA GRUESA [5995.4%]; AGUA [1386.4%]; MADERA TORNILLO [43466.4%] | 585.48h | 43,897.07 | 03.04.05 | 000000000000135 | 749.42 | 63.64 | 47693.09 | 100 |
| 148 | 1.4.4.6 | UÑAS DE VEREDA, CONCRETO F'c=175 Kg/cm2 | 10d | 2024-02-23 | 2024-03-04 | 147SS | 144d | 0d | start no earlier than 2022-05-16 | CEMENTO PORTLAND TIPO MS (42.5 kg) [25576.6%]; OPERARIO [84.3%]; OFICIAL [84.3%]; PEON [674.2%]; VIBRADOR DE CONCRETO 4 HP 2.4" [42.1%]; MEZCLADORA DE 9-11P3 [84.3%]; PIEDRA CHANCADA 1/2" [1972.1%]; ARENA GRUESA [1638.4%]; AGUA [561.3%] | 484.6h | 19,386.38 | 03.04.06 | 000000000000136 | 30.34 | 487.37 | 14786.81 | 12 |
| 149 | 1.4.4.7 | VEREDAS, ENCOFRADO Y DESENCOFRADO | 10d | 2024-02-23 | 2024-03-04 | 148SS | 144d | 0d | start no earlier than 2022-05-16 | OPERARIO [97.3%]; OFICIAL [97.3%]; ALAMBRE NEGRO N° 16 [4451.7%]; CLAVOS P/ MADERA CON CABEZA 2" 2 1/2" 3" 4" [3237.6%]; MADERA TORNILLO [72846%] | 97.28h | 8,066.72 | 03.04.07 | 000000000000137 | 202.35 | 52.72 | 10667.89 | 16 |
| 150 | 1.4.4.8 | VEREDAS, JUNTA DE DILATACION e=1" | 1d | 2024-03-04 | 2024-03-05 | 149 | 144d |  | start no earlier than 2022-05-16 | ASFALTO RC-250 [3223.3%]; OPERARIO [80.8%]; PEON [161.6%]; ARENA GRUESA [484.7%]; TECNOPOR DE 1" [848.2%] | 12.12h | 1,085.17 | 03.04.08 | 000000000000138 | 242.35 | 8.65 | 2096.33 | 100 |
| 151 | 1.4.4.9 | VEREDAS, CURADO C/ ADITIVO | 10d | 2024-02-23 | 2024-03-04 | 147SS | 139d | 0d | start no earlier than 2022-05-16 | CURADOR MENBRANIL [3747.1%]; PEON [93.7%]; MOCHILA PULVERIZADORA [93.7%]; AGUA [74.9%] | 93.68h | 2,302.21 | 03.04.09 | 000000000000139 | 749.42 | 3.61 | 2705.41 | 100 |
| 152 | 1.4.4.10 | PATIO, CONCRETO F'c=175 kg/cm2, e= 0.10 m. INC. ACABADO Y BRUÑADO | 1d | 2024-03-04 | 2024-03-05 | 151 | 141d | 0d | start no earlier than 2022-05-16 | CEMENTO PORTLAND TIPO MS (42.5 kg) [7587%]; OPERARIO [360%]; OFICIAL [90%]; PEON [540%]; VIBRADOR DE CONCRETO 4 HP 2.4" [45%]; MEZCLADORA DE 9-11P3 [90%]; PIEDRA CHANCADA 1/2" [810%]; ARENA FINA [90%]; ARENA GRUESA [720%]; AGUA [166.5%]; MADERA TORNILLO [5220%] | 56.25h | 4,983 | 03.04.10 | 000000000000140 | 90 | 63.64 | 5727.6 | 100 |
| 153 | 1.4.4.11 | UÑAS DE PATIO, CONCRETO F'c=175 Kg/cm2 | 1d | 2024-03-04 | 2024-03-05 | 152SS | 143d | 0d | start no earlier than 2022-05-16 | CEMENTO PORTLAND TIPO MS (42.5 kg) [1458.4%]; OPERARIO [14.4%]; OFICIAL [14.4%]; PEON [115.3%]; VIBRADOR DE CONCRETO 4 HP 2.4" [7.2%]; MEZCLADORA DE 9-11P3 [14.4%]; PIEDRA CHANCADA 1/2" [131.5%]; ARENA GRUESA [96.9%]; AGUA [32%] | 8.29h | 763.5 | 03.04.11 | 000000000000141 | 1.73 | 499.08 | 863.41 | 12 |
| 154 | 1.4.4.12 | PATIO, ENCOFRADO Y DESENCOFRADO | 1d | 2024-03-04 | 2024-03-05 | 153SS | 143d | 0d | start no earlier than 2022-05-16 | OPERARIO [89.2%]; OFICIAL [89.2%]; ALAMBRE NEGRO N° 16 [314.2%]; CLAVOS P/ MADERA CON CABEZA 2" 2 1/2" 3" 4" [228.5%]; MADERA TORNILLO [5140.8%] | 8.93h | 617.46 | 03.04.12 | 000000000000142 | 14.28 | 52.72 | 752.84 | 16 |
| 155 | 1.4.4.13 | PATIO, JUNTA DE DILATACION e=1" | 1d | 2024-03-05 | 2024-03-06 | 154 | 143d |  | start no earlier than 2022-05-16 | ASFALTO RC-250 [362.4%]; OPERARIO [27.2%]; PEON [54.5%]; ARENA GRUESA [54.5%]; TECNOPOR DE 1" [95.4%] | 4.09h | 179.65 | 03.04.13 | 000000000000143 | 27.25 | 8.65 | 235.71 | 100 |
| 156 | 1.4.4.14 | PATIO, CURADO C/ ADITIVO | 1d | 2024-03-04 | 2024-03-05 | 152SS | 141d | 0d | start no earlier than 2022-05-16 | CURADOR MENBRANIL [450%]; PEON [90%]; MOCHILA PULVERIZADORA [90%]; AGUA [9%] | 9h | 244.83 | 03.04.14 | 000000000000144 | 90 | 3.61 | 324.9 | 100 |
| 157 | 1.4.4.15 | LOSA DEP., CONCRETO F'c=175 kg/cm2, e= 0.10 m. FROT. Y BRUÑADO | 2d | 2024-03-05 | 2024-03-07 | 156 | 141d | 0d | start no earlier than 2022-05-16 | CEMENTO PORTLAND TIPO MS (42.5 kg) [53952%]; OPERARIO [365.7%]; OFICIAL [91.4%]; PEON [548.6%]; VIBRADOR DE CONCRETO 4 HP 2.4" [45.7%]; MEZCLADORA DE 9-11P3 [91.4%]; PIEDRA CHANCADA 1/2" [5760%]; ARENA FINA [640%]; ARENA GRUESA [5120%]; AGUA [1184%]; MADERA TORNILLO [37120%] | 114.29h | 29,568.64 | 03.04.15 | 000000000000145 | 640 | 63.64 | 40729.6 | 100 |
| 158 | 1.4.4.16 | UÑAS DE LOSA, CONCRETO F'c=175 Kg/cm2 | 2d | 2024-03-05 | 2024-03-07 | 157SS | 141d | 0d | start no earlier than 2022-05-16 | CEMENTO PORTLAND TIPO MS (42.5 kg) [3945.2%]; OPERARIO [39%]; OFICIAL [39%]; PEON [312%]; VIBRADOR DE CONCRETO 4 HP 2.4" [19.5%]; MEZCLADORA DE 9-11P3 [39%]; PIEDRA CHANCADA 1/2" [355.7%]; ARENA GRUESA [262.1%]; AGUA [86.6%] | 44.85h | 2,485.33 | 03.04.16 | 000000000000146 | 4.68 | 499.08 | 2335.69 | 12 |
| 159 | 1.4.4.17 | LOSA DEP., ENCOFRADO Y DESENCOFRADO | 2d | 2024-03-05 | 2024-03-07 | 158SS | 141d | 0d | start no earlier than 2022-05-16 | OPERARIO [81.5%]; OFICIAL [81.5%]; ALAMBRE NEGRO N° 16 [1434.4%]; CLAVOS P/ MADERA CON CABEZA 2" 2 1/2" 3" 4" [1043.2%]; MADERA TORNILLO [23472%] | 16.3h | 2,247.21 | 03.04.17 | 000000000000147 | 65.2 | 52.72 | 3437.34 | 16 |
| 160 | 1.4.4.18 | LOSA DEP., JUNTA DE DILATACION e=1" | 1d | 2024-03-07 | 2024-03-08 | 159 | 141d |  | start no earlier than 2022-05-16 | ASFALTO RC-250 [4522%]; OPERARIO [85%]; PEON [170%]; ARENA GRUESA [680%]; TECNOPOR DE 1" [1190%] | 12.75h | 1,432.53 | 03.04.18 | 000000000000148 | 340 | 8.65 | 2941 | 100 |
| 161 | 1.4.4.19 | LOSA DEP., CURADO C/ ADITIVO | 1d | 2024-03-05 | 2024-03-06 | 157SS | 143d |  | start no earlier than 2022-05-16 | CURADOR MENBRANIL [3200%]; PEON [91.4%]; MOCHILA PULVERIZADORA [91.4%]; AGUA [64%] | 9.14h | 969.46 | 03.04.19 | 000000000000149 | 640 | 3.61 | 2310.4 | 100 |

| ID | WBS | Task | Duration | Start | Finish | Predecessors | Total slack | Free slack | Constraint | Resources | Work | Cost | Text1 | Text8 | Text2 | Text3 | Text4 | Text6 |
| --- | --- | --- | --- | --- | --- | --- | --- | --- | --- | --- | --- | --- | --- | --- | --- | --- | --- | --- |
| 162 | 1.4.5 | **ZOCALOS Y CONTRAZOCALOS** | 21d | 2024-03-15 | 2024-04-05 |  | 113d |  |  |  | 65.93h | 12,926.68 | 03.05 | 000000000000150 |  |  |  |  |
| 163 | 1.4.5.1 | ZOCALO DE CERAMIC0 0.20 X 0.30 m. C/ CLARO | 2d | 2024-03-15 | 2024-03-17 | 130 | 131d | 0d | start no earlier than 2022-05-16 | PEGAMENTO DE CERAMICO (25 KG) [4466%]; OPERARIO [99.2%]; OFICIAL [49.6%]; PORCELANA DE COLOR [4466%]; CERAMICO 0.20 X 0.30 m. [18757.2%] | 14.89h | 6,281.11 | 03.05.01 | 000000000000151 | 178.64 | 63.21 | 11291.83 | 10 |
| 164 | 1.4.5.2 | CONTRAZOCALO S/COLOREAR H=20CM. MZ 1:2 e=1.5 CM. | 5d | 2024-03-29 | 2024-04-03 | 131 | 113d | 0d | start no earlier than 2022-05-16 | CEMENTO PORTLAND TIPO MS (42.5 kg) [1637.3%]; OPERARIO [96.3%]; PEON [48.2%]; ARENA FINA [98.2%]; AGUA [32.8%] | 36.12h | 1,363.26 | 03.05.02 | 000000000000152 | 327.47 | 16.2 | 5305.01 | 20 |
| 165 | 1.4.5.3 | CONTRAZOCALO MAD. CEDRO 3/4"X4" + RODON 3/4" | 2d | 2024-04-03 | 2024-04-05 | 164 | 113d |  | start no earlier than 2022-05-16 | OPERARIO [99.5%]; PEON [49.7%]; MADERA CEDRO [43775%]; TORNILLOS 1" [131325%]; TARUGO DE PVC [131325%] | 14.92h | 5,282.3 | 03.05.03 | 000000000000153 | 437.75 | 18.57 | 8129.02 | 40 |
| 166 | 1.4.6 | **CUBIERTAS** | 6d | 2024-04-09 | 2024-04-15 |  | 83d |  |  |  | 122.08h | 117,162.35 | 03.06 | 000000000000154 |  |  |  |  |
| 167 | 1.4.6.1 | COBERTURA C/ PLANCHA THERMO AISLANTE e=25 mm. | 5d | 2024-04-09 | 2024-04-14 | 146 | 83d | 0d | start no earlier than 2022-05-16 | ADITIVO DE FIJACION [241.2%]; ROTOMARTILLO [24.5%]; OPERARIO [196.1%]; PEON [98.1%]; SELLO BUTYL DE 3/32" x 3/4" [126657%]; CALAMINON TAT TERMO AISLANTE e=25 MM. [126657%]; TIRAFON DE 1/4" X 4" [361878%]; ARANDELA DE 1/4" [361878%]; SOMBRERO P/ TIRAFON DE 1/4" [361878%] | 79.68h | 100,859.19 | 03.06.01 | 000000000000155 | 1206.26 | 102.55 | 123701.96 | 30 |
| 168 | 1.4.6.2 | CORREAS DE MADERA 2" X 2" INC. TIRAFON 1/4"X4" | 5d | 2024-04-09 | 2024-04-14 | 167SS | 83d | 0d | start no earlier than 2022-05-16 | OPERARIO [98.3%]; PEON [49.1%]; MADERA TORNILLO [196512%] | 36.85h | 15,040.7 | 03.06.02 | 000000000000156 | 1572.1 | 14.86 | 23361.41 | 50 |
| 169 | 1.4.6.3 | CUBIERTA DE LADRILLO PASTELERO | 1d | 2024-04-14 | 2024-04-15 | 168 | 83d | 0d | start no earlier than 2022-05-16 | CEMENTO PORTLAND TIPO MS (42.5 kg) [415.4%]; OPERARIO [74%]; PEON [37%]; ARENA GRUESA [71%]; AGUA [17.8%]; LADRILLO PASTELERO DE 24 X 24 X 3 cm [56800%] | 5.55h | 1,262.46 | 03.06.03 | 000000000000432 | 35.5 | 50.15 | 1780.33 | 16 |
| 170 | 1.4.7 | **CARPINTERIA DE MADERA** | 145d | 2023-12-01 | 2024-04-23 |  | 95d |  |  |  | 210.39h | 81,243.11 | 03.07 | 000000000000157 |  |  |  |  |
| 171 | 1.4.7.1 | PUERTA CEDRO MACHIMBRADA - 1HOJA | 10d | 2024-04-08 | 2024-04-18 | 145 | 0d |  | start no earlier than 2022-05-16 | COLA SINTETICA [969.1%]; OPERARIO [99.4%]; OFICIAL [49.7%]; CLAVOS PARA MADERA C/C 2" [387.6%]; CLAVOS PARA MADERA C/C 1" [775.3%]; MADERA CEDRO [325618%]; LIJA PARA MADERA [4845.5%] | 74.55h | 37,627.36 | 03.07.01 | 000000000000158 | 96.91 | 489.83 | 47469.43 | 2.5 |
| 172 | 1.4.7.2 | VENTANA CEDRO C/ VARILLA DE F° LISO DE SEGURIDAD | 15d | 2024-04-08 | 2024-04-23 | 171SS | 0d |  | start no earlier than 2022-05-16 | COLA SINTETICA [1433.3%]; PINTURA ESMALTE [143.3%]; PINTURA ANTICORROSIVA [143.3%]; OPERARIO [98.8%]; OFICIAL [49.4%]; CLAVOS PARA MADERA C/C 2" [573.3%]; CLAVOS PARA MADERA C/C 1" [286.7%]; MADERA CEDRO [288810%]; LIJA PARA MADERA [7309.8%]; FIERRO LISO DE 1/2" X 6.00 m. [6449.9%] | 111.2h | 36,207.77 | 03.07.02 | 000000000000159 | 143.33 | 354.03 | 50743.12 | 2.5 |
| 173 | 1.4.7.3 | PUERTA MELAMINE e= 18mm. EN S.H. | 1d | 2024-04-18 | 2024-04-19 | 171 | 98d | 0d | start no earlier than 2022-05-16 | OPERARIO [76.8%]; OFICIAL [76.8%]; CANTONERA DE PVC e=18 mm. [787.2%]; PERFIL "L" DE 1"X1"X1/8" [614.4%]; TABLERO MELAMINE e=18 mm. [368.6%]; TORNILLOS 1" [1152%]; REMACHE [1536%]; TARUGO DE PVC [1152%] | 7.68h | 403.5 | 03.07.03 | 000000000000160 | 3.84 | 135.4 | 519.94 |  |
| 174 | 1.4.7.4 | MUEBLES DE MELAMINE e= 18mm. | 1d | 2024-04-18 | 2024-04-19 | 173SS | 98d | 0d | start no earlier than 2022-05-16 | OPERARIO [88.6%]; OFICIAL [88.6%]; CANTONERA DE PVC e=18 mm. [7265.2%]; PERFIL "L" DE 1"X1"X1/8" [5670.4%]; TABLERO MELAMINE e=18 mm. [3402.2%]; TORNILLOS 1" [10632%]; REMACHE [14176%]; TARUGO DE PVC [10632%] | 8.86h | 2,273 | 03.07.04 | 000000000000161 | 35.44 | 135.4 | 4798.58 |  |
| 175 | 1.4.7.5 | SUMINISTRO E INST. DE PIZARRA ACRILICA (3.00 X1.20 m.) | 1d | 2023-12-01 | 2023-12-02 |  | 239d |  | start no earlier than 2022-05-16 | OPERARIO [81.2%]; PEON [81.2%]; PIZARRA ACRILICA INC. ACCESORIOS [1300%] | 8.1h | 4,731.47 | 03.07.05 | 000000000000162 | 13 | 442.33 | 5750.29 |  |
| 176 | 1.4.8 | **CARPINTERIA METALICA Y HERRERIA** | 91d | 2024-03-17 | 2024-06-16 |  | 37d |  |  |  | 455.05h | 49,227.31 | 03.08 | 000000000000163 |  |  |  |  |
| 177 | 1.4.8.1 | PUERTA DE INGRESO PRINCIPAL C/PERFILES DE 3/16" | 5d | 2024-04-23 | 2024-04-28 | 172 | 0d |  | start no earlier than 2022-05-16 | OPERARIO [200%]; OFICIAL; PEON; SOLDADORA ELECTRICA; ACERO Fy = 4200 KG/CM2 (GRADO 60) [600%]; SOLDADURA CELLOCORD [1200%]; ANGULO 2" x 2" x 3/16" [4560%]; PLATINA DE FIERRO 2" X 3/16" [22080%]; PLATINA DE FIERRO 3" X 3/16" [8400%]; PLANCHA DE ACERO 4"X8"X1/16" [240%]; BISAGRA CON EJE 5/8" [1680%]; CERROJO 1/2"X1"X5" [1440%]; RUEDA CON SOPORTE Y GUIA [384%] | 125h | 5,656.25 | 03.08.01 | 000000000000164 | 24 | 416.24 | 9989.76 |  |
| 178 | 1.4.8.2 | BARRA DE TUBO DE ACERO INOX. DE 1 1/2" EN S.H. L=0.90 m. | 1d | 2024-03-17 | 2024-03-18 | 163 | 131d |  | start no earlier than 2022-05-16 | OPERARIO [50%]; PEON [50%]; BARRA DE ACERO INOX. Ø 1 1/2" L=0.90 m. INC. SOPORTE Y FI JACION [400%] | 5h | 594.45 | 03.08.02 | 000000000000165 |  | 166.76 | 667.04 |  |
| 179 | 1.4.8.3 | PASAMANO DE TUBO F°G° 2", EN ESCALERA | 1d | 2024-04-01 | 2024-04-02 | 180 | 116d |  | start no earlier than 2022-05-16 | PINTURA ESMALTE [12.8%]; PINTURA ANTICORROSIVA [12.8%]; THINNER [12.8%]; OPERARIO [80%]; PEON [40%]; SOLDADORA ELECTRICA [80%]; SOLDADURA CELLOCORD [76.8%]; TUBO DE F°G° DE Ø 1 1/2" [256%]; TUBO DE F°G° DE Ø 2" [1344%] | 10h | 633.3 | 03.08.03 | 000000000000166 | 12.8 | 85.27 | 1091.46 |  |
| 180 | 1.4.8.4 | CANTONERA DE ALUMINIO EN ESCALERA | 1d | 2024-03-31 | 2024-04-01 | 135 | 116d | 0d | start no earlier than 2022-05-16 | OPERARIO [95%]; CANTONERA DE ALUMINIO [3838%] | 4.75h | 1,452.35 | 03.08.04 | 000000000000167 | 38 | 56.53 | 2148.14 | 10 |
| 181 | 1.4.8.5 | REJILLA METALICA PARA CUNETA | 5d | 2024-06-01 | 2024-06-06 | 207 | 0d |  | start no earlier than 2022-05-16 | OPERARIO [94.3%]; PEON [188.6%]; SOLDADORA ELECTRICA [47.2%]; REJILLA METALICA S/ DISEÑO [15240.9%] | 82.52h | 16,151.72 | 03.08.05 | 000000000000168 | 150.9 | 154.23 | 23273.31 | 10 |
| 182 | 1.4.8.6 | CERCO DE F° C/ MALLA METALICA, INC. SUMINISTRO E INSTALACION | 5d | 2024-06-06 | 2024-06-11 | 181 | 0d |  | start no earlier than 2022-05-16 | PINTURA ESMALTE [421.3%]; PINTURA ANTICORROSIVA [421.3%]; THINNER [210.6%]; OPERARIO [95.7%]; OFICIAL [95.7%]; PEON [191.5%]; SOLDADORA ELECTRICA [95.7%]; SOLDADURA CELLOCORD [4212.6%]; ANGULO 1 1/2" x 1 1/2" x 1/8 [36860.2%]; MALLA DE ALAMBRE GALV. # 10 DE 2" X 2" [21273.6%]; TUBO DE ACERO NEGRO DE Ø 2 1/2" [2738.2%] | 119.68h | 17,408.04 | 03.08.06 | 000000000000169 | 210.63 | 112.03 | 23596.88 | 20 |
| 183 | 1.4.8.7 | PUERTA DE F° C/ MALLA METALICA, INC. SUMINISTRO E INST. | 1d | 2024-06-11 | 2024-06-12 | 182 | 34d | 0d | start no earlier than 2022-05-16 | PINTURA ESMALTE [5.6%]; PINTURA ANTICORROSIVA [5.6%]; THINNER [2.8%]; OPERARIO [70%]; OFICIAL [70%]; PEON [70%]; SOLDADORA ELECTRICA [70%]; SOLDADURA CELLOCORD [56%]; ANGULO 1 1/2" x 1 1/2" x 1/8 [490%]; MALLA DE ALAMBRE GALV. # 10 DE 2" X 2" [282.8%]; TUBO DE ACERO NEGRO DE Ø 3" [78.4%]; TUBO DE ACERO NEGRO DE Ø 2" [126%]; BISAGRA DE ACERO [1120%]; CERROJO DE FIERRO [280%] | 14h | 997.97 | 03.08.07 | 000000000000170 | 2.8 | 420.67 | 1177.88 |  |
| 184 | 1.4.8.8 | PUERTA CASETA, CTO. GE, CTO. SISTEMA SOLAR | 2d | 2024-06-12 | 2024-06-14 | 183 | 34d | 0d | start no earlier than 2022-05-16 | OPERARIO [73.4%]; PEON [73.4%]; SOLDADORA ELECTRICA [36.7%]; PUERTA METALICA S/ DISEÑO [889.8%] | 18.35h | 2,608.64 | 03.08.08 | 000000000000356 | 8.81 | 359.83 | 3170.1 |  |
| 185 | 1.4.8.9 | VENTANA METALICA TIPO REJA | 1d | 2024-06-12 | 2024-06-13 | 184SS | 34d | 0d | start no earlier than 2022-05-16 | OPERARIO [85%]; PEON [85%]; SOLDADORA ELECTRICA [42.5%]; VENTANA METALICA INCLUYENDO ACCESORIOS [343.4%] | 10.62h | 840.48 | 03.08.09 | 000000000000357 | 3.4 | 289.13 | 983.04 |  |
| 186 | 1.4.8.10 | ESCALERA TUB F.GDO. DE 1 1/2" Y 1" | 2d | 2024-06-13 | 2024-06-15 | 185 | 41d | 0d | start no earlier than 2022-05-16 | DILUYENTE PARA ESMALTE EPOXICO [1.3%]; PINTURA ANTICORROSIVA CROMATO DE ZINC [14%]; IMPRIMANTE VINILICO P/SUPERFICIE GALVANIZADO [21%]; OPERARIO [87.5%]; OFICIAL [87.5%]; PEON [87.5%]; ELECTRODO E-6011-CELLOCORD [210%]; TUBERIA DE FIERRO GALVANIZADO DE 1" [1400%]; TUBO FO.GALV.ST.ISO-I 1 1/2" [1470%]; PERNOS DE EXPANSION DE 3/8"X3" C/ARANDELA [1470%]; LIJA DE FIERRO #8 [350%] | 26.25h | 904.59 | 03.08.10 | 000000000000359 |  | 114.84 | 803.88 |  |
| 187 | 1.4.8.11 | ESCALERA DE ALUMINIO EN CISTERNA | 1d | 2024-06-15 | 2024-06-16 | 186 | 41d | 0d | start no earlier than 2022-05-16 | OPERARIO; PEON [50%]; TUBO DE ALUMINIO DE 30MM. E=3MM. [600%]; CODO DE ALUMINIO DE 30MM [1400%] | 7.5h | 317.52 | 03.08.11 | 000000000000358 |  | 432.56 | 432.56 |  |
| 188 | 1.4.8.12 | TAPA METALICA DE 0.60 X 0.60 m. | 1d | 2024-06-15 | 2024-06-16 | 187SS | 41d |  | start no earlier than 2022-05-16 | OPERARIO [40%]; PEON [20%]; TAPA METALICA DE 0.60X0.60 m. [200%] | 3h | 431.01 | 03.08.12 | 000000000000360 |  | 238.5 | 477 |  |
| 189 | 1.4.8.13 | BARANDA DE PROYECCION EN TANQUE ELEVADO (H=0.90 m.) | 1d | 2024-06-13 | 2024-06-14 | 185 | 43d |  | start no earlier than 2022-05-16 | DILUYENTE PARA ESMALTE EPOXICO [1.4%]; PINTURA ANTICORROSIVA CROMATO DE ZINC [16%]; IMPRIMANTE VINILICO P/SUPERFICIE GALVANIZADO [24%]; OPERARIO [80%]; OFICIAL [80%]; PEON [80%]; ELECTRODO E-6011-CELLOCORD [240%]; TUBERIA DE FIERRO GALVANIZADO DE 1" [3200%]; PERNOS DE EXPANSION DE 3/8"X3" C/ARANDELA [1680%]; LIJA DE FIERRO #8 [400%] | 12h | 601.92 | 03.08.13 | 000000000000434 |  | 96.44 | 771.52 | 10 |
| 190 | 1.4.8.14 | PROTECCION DE ESCALERA DE GATO CON PERFILES METALICOS | 2d | 2024-06-13 | 2024-06-15 | 185 | 34d | 0d | start no earlier than 2022-05-16 | DILUYENTE PARA ESMALTE EPOXICO [1.2%]; PINTURA ANTICORROSIVA CROMATO DE ZINC [13.1%]; IMPRIMANTE VINILICO P/SUPERFICIE GALVANIZADO [19.6%]; OPERARIO [54.6%]; OFICIAL [54.6%]; PEON [54.6%]; ELECTRODO E-6011-CELLOCORD [196.5%]; PLATINA DE FIERRO 1/8" X 1" [3962.8%]; LIJA DE FIERRO #8 [327.5%]; FIERRO LISO DE 1/2" X 6.00 m. [327.5%] | 16.37h | 629.07 | 03.08.14 | 000000000000433 | 6.55 | 131.39 | 860.6 |  |

| ID | WBS | Task | Duration | Start | Finish | Predecessors | Total slack | Free slack | Constraint | Resources | Work | Cost | Text1 | Text8 | Text2 | Text3 | Text4 | Text6 |
| --- | --- | --- | --- | --- | --- | --- | --- | --- | --- | --- | --- | --- | --- | --- | --- | --- | --- | --- |
| 191 | 1.4.9 | **CERRAJERIA** | 25d | 2024-04-18 | 2024-05-13 |  | 10d |  |  |  | 50.01h | 7,644.32 | 03.09 | 000000000000171 |  |  |  |  |
| 192 | 1.4.9.1 | BISAGRA ALUMINIZADA DE 4" PESADA EN PUERTA | 1d | 2024-04-18 | 2024-04-19 | 171 | 99d |  | start no earlier than 2022-05-16 | OPERARIO [82.2%]; BISAGRA ALUMINIZADA PESADA 4"X4" [14800%] | 4.11h | 1,617.24 | 03.09.01 | 000000000000172 | 148 | 13.79 | 2040.92 | 60 |
| 193 | 1.4.9.2 | BISAGRA ALUMINIZADO DE 2 1/2" X 2 1/2" | 1d | 2024-04-18 | 2024-04-19 | 173SS | 99d |  | start no earlier than 2022-05-16 | OPERARIO [10%]; BISAGRA ALUMINIZADA DE 2 1/2" X 2 1/2" [800%] | 0.5h | 57.9 | 03.09.02 | 000000000000173 |  | 8.3 | 66.4 | 80 |
| 194 | 1.4.9.3 | BISAGRA TIPO CANGREJO | 1d | 2024-04-18 | 2024-04-19 | 174SS | 99d | 0d | start no earlier than 2022-05-16 | OPERARIO [93.3%]; BISAGRA ALUMINIZADA PESADA 4"X4" [5600%] | 4.67h | 693.39 | 03.09.03 | 000000000000174 | 56 | 13.79 | 772.24 | 60 |
| 195 | 1.4.9.4 | BISAGRAS TIPO PIN DE ROTULACION | 1d | 2024-04-18 | 2024-04-19 | 194SS | 99d |  | start no earlier than 2022-05-16 | OPERARIO [2%]; BISAGRA PIN DE ROTULACION [200%] | 0.1h | 17.62 | 03.09.04 | 000000000000175 |  | 9.66 | 19.32 | 100 |
| 196 | 1.4.9.5 | CERRADURA DOS GOLPES C/ TIRADOR EN PUERTA | 1d | 2024-04-28 | 2024-04-29 | 177 | 0d |  | start no earlier than 2022-05-16 | OPERARIO; CERRADURA 2 GOLPES TIPO FORTE (INC. TIRADOR) [4200%] | 5h | 2,314.95 | 03.09.05 | 000000000000176 | 42 | 87.97 | 3694.74 |  |
| 197 | 1.4.9.6 | CERROJO TIPO SAPITO | 1d | 2024-04-23 | 2024-04-24 | 172 | 94d |  | start no earlier than 2022-05-16 | OPERARIO [98%]; CERROJO "SAPITO" DE BRONCE [29400%] | 4.9h | 1,598.34 | 03.09.06 | 000000000000177 | 294 | 22.81 | 6706.14 | 12 |
| 198 | 1.4.9.7 | MANIJA DE BRONCE 4" PARA PUERTA | 1d | 2024-04-19 | 2024-04-20 | 173 | 98d |  | start no earlier than 2022-05-16 | OPERARIO [33.3%]; MANIJA DE BRONCE 4" P/PUERTA [400%] | 1.67h | 104.05 | 03.09.07 | 000000000000178 |  | 33.08 | 132.32 | 12 |
| 199 | 1.4.9.8 | TIRADOR DE ACERO INOXIDABLE | 1d | 2024-04-19 | 2024-04-20 | 174 | 98d |  | start no earlier than 2022-05-16 | OPERARIO [88.9%]; TIRADOR DE ACERO INOXIDABLE [6400%] | 4.44h | 769.21 | 03.09.08 | 000000000000179 | 64 | 28.18 | 1803.52 | 12 |
| 200 | 1.4.9.9 | CANDADO DE 60 mm. | 1d | 2024-04-29 | 2024-04-29 | 177 | 89d |  | start no earlier than 2022-05-16 | CANDADO DE 60 mm. INC. ALDABAS [400%] | 20h | 184 | 03.09.09 | 000000000000180 |  | 46 | 184 | 12 |
| 201 | 1.4.9.10 | TOPES DE GOMA PARA PUERTA | 1d | 2024-05-12 | 2024-05-13 | 205 | 75d |  | start no earlier than 2022-05-16 | OPERARIO [92.5%]; TOPE DE GOMA PARA PUERTA [3700%] | 4.62h | 287.63 | 03.09.10 | 000000000000181 | 37 | 15.29 | 565.73 | 20 |
| 202 | 1.4.10 | **VIDRIOS, CRISTALES Y SIMILARES** | 5d | 2024-04-29 | 2024-05-04 |  | 0d |  |  |  | 49.27h | 18,700.33 | 03.10 | 000000000000182 |  |  |  |  |
| 203 | 1.4.10.1 | VIDRIO SEMIDOBLE COLOR TRANSPARENTE C/ LAMINA DE 4 MICRAS | 5d | 2024-04-29 | 2024-05-04 | 196 | 0d |  | start no earlier than 2022-05-16 | OPERARIO [98.5%]; PEON [49.3%]; ANDAMIO METALICO [49.3%]; VIDRIO SEMIDOBLE INC. LAMINA DE 4 MICRAS [297155%]; SILICONA [2207.3%] | 49.27h | 18,700.33 | 03.10.01 | 000000000000183 | 275.91 | 72.47 | 19995.2 | 40 |
| 204 | 1.4.11 | **PINTURAS** | 43d | 2024-05-04 | 2024-06-16 |  | 0d |  |  |  | 235.32h | 52,846.17 | 03.11 | 000000000000184 |  |  |  |  |
| 205 | 1.4.11.1 | PINTURA LATEX A 2 MANOS EN CIELORASO Y VIGAS | 8d | 2024-05-04 | 2024-05-12 | 203 | 0d |  | start no earlier than 2022-05-16 | PINTURA LATEX [10131.6%]; IMPRIMANTE [26342.2%]; OPERARIO [99.3%]; PEON [49.7%]; LIJA [50658%] | 59.6h | 15,023.53 | 03.11.01 | 000000000000185 | 2026.32 | 16.38 | 33191.12 | 30 |
| 206 | 1.4.11.2 | PINTURA LATEX A 2 MANOS EN MUROS Y COLUMNAS | 15d | 2024-05-12 | 2024-05-27 | 205 | 0d |  | start no earlier than 2022-05-16 | PINTURA LATEX [17495.2%]; IMPRIMANTE [45487.7%]; OPERARIO; PEON [49.8%]; LIJA [87476.2%] | 112.15h | 26,161.26 | 03.11.02 | 000000000000186 | 3499.05 | 16.47 | 57629.35 | 30 |
| 207 | 1.4.11.3 | PINTURA BARNIZ EN CARPINTERIA DE MADERA | 5d | 2024-05-27 | 2024-06-01 | 206 | 0d |  | start no earlier than 2022-05-16 | THINNER [4282.9%]; BARNIZ MARINO [1784.5%]; TAPAPOROS DE MADERA ACABADA C/BARNIZ O LACA [2855.3%]; OPERARIO [99.1%]; PEON [49.6%]; LIJA PARA MADERA [7138.2%] | 37.18h | 3,552.19 | 03.11.03 | 000000000000187 | 356.91 | 22.13 | 7898.42 | 20 |
| 208 | 1.4.11.4 | PINTURA BARNIZ EN CONTRAZOCALOS DE MADERA H=0.10m. | 1d | 2024-06-01 | 2024-06-02 | 207 | 54d | 0d | start no earlier than 2022-05-16 | THINNER [437.8%]; BARNIZ MARINO [1751%]; TAPAPOROS DE MADERA ACABADA C/BARNIZ O LACA [1751%]; OPERARIO [87.5%]; PEON [43.8%]; LIJA PARA MADERA [8755%] | 6.57h | 1,687.33 | 03.11.04 | 000000000000188 | 437.75 | 6.44 | 2819.11 | 100 |
| 209 | 1.4.11.5 | PINTURA ESMALTE A 2 MANOS EN CONTRAZOCALOS | 1d | 2024-06-02 | 2024-06-03 | 208 | 54d |  | start no earlier than 2022-05-16 | PINTURA ESMALTE [1637.3%]; THINNER [327.5%]; IMPRIMANTE [2619.8%]; OPERARIO [93.6%]; PEON [46.8%]; LIJA [8186.8%] | 7.02h | 2,049.54 | 03.11.05 | 000000000000189 | 327.47 | 17.46 | 5717.63 | 25 |
| 210 | 1.4.11.6 | PINTURA ANTICOR. Y ESMALTE A 2 MANOS EN CARP. MET. | 1d | 2024-06-15 | 2024-06-16 | 190 | 34d | 0d | start no earlier than 2022-05-16 | PINTURA ESMALTE [181.1%]; PINTURA ANTICORROSIVA [289.7%]; THINNER [36.2%]; OPERARIO [72.4%]; PEON [36.2%]; LIJA DE FIERRO #8 [905.2%] | 5.43h | 386.32 | 03.11.06 | 000000000000190 | 36.21 | 18.82 | 681.47 | 25 |
| 211 | 1.4.11.7 | DEMARCACION DE LOSA DEPORTIVA | 1d | 2024-05-27 | 2024-05-28 | 206 | 60d |  | start no earlier than 2022-05-16 | PINTURA ESMALTE [3200%]; THINNER [1280%]; IMPRIMANTE [5120%]; OPERARIO [98.5%]; PEON [49.2%]; LIJA [16000%] | 7.38h | 3,985.99 | 03.11.07 | 000000000000191 | 640 | 17.67 | 11308.8 | 25 |
| 212 | 1.4.12 | **VARIOS,LIMPIEZA Y JARDINERIA** | 238d | 2023-12-03 | 2024-07-27 |  | 0d |  |  |  | 84.31h | 277,883.69 | 03.12 | 000000000000192 |  |  |  |  |
| 213 | 1.4.12.1 | LIMPIEZA PERMANENTE Y FINAL DE OBRA | 2d | 2024-07-26 | 2024-07-27 | 395 | 0d |  | start no earlier than 2022-05-16 | LIMPIEZA PERMANENTE DE OBRA | 10h | 900 | 03.12.01 | 000000000000193 |  | 900 | 900 | 200 |
| 214 | 1.4.12.2 | JUNTA DE DILATACION CON ESPUMA PLASTICA Y JEBE MICROPOROSO | 2d | 2024-05-27 | 2024-05-29 | 206 | 59d |  | start no earlier than 2022-05-16 | PEGAMENTO EN BASE A CAUCHO SISNTETICO [558.6%]; OPERARIO [93.1%]; JEBE MICROPOROSO 1"X1CM [558.6%]; ESPUMA PLASTICA DURA A/DENSIDAD 2.00x1.00 M. E=2" [1117.2%] | 9.31h | 2,045.31 | 03.12.02 | 000000000000194 | 186.2 | 18.31 | 3409.32 | 25 |
| 215 | 1.4.12.3 | SUMINISTRO E INST. DE ARCOS DE FULBITO Y TABLERO DE BASQUET | 5d | 2024-06-17 | 2024-06-21 | 210 | 34d | 0d | start no earlier than 2022-05-16 | ARCOS DE FULBITO [200%] | 50h | 7,000 | 03.12.03 | 000000000000195 |  | 3500 | 7000 |  |
| 216 | 1.4.12.4 | SUMINISTRO E INST. DE NET PARA VOLEY | 1d | 2024-06-22 | 2024-06-22 | 215 | 34d | 0d | start no earlier than 2022-05-16 | NET DE VOLEY INC. TUBOS METALICOS | 5h | 900 | 03.12.04 | 000000000000196 |  | 900 | 900 |  |
| 217 | 1.4.12.5 | SUMINISTRO E INST. DE EXTINTORES Y GABINETES | 1d | 2024-06-22 | 2024-06-23 | 216 | 34d |  | start no earlier than 2022-05-16 | OPERARIO; EXTINTOR DE POLVO SECO [600%]; GABINETE METALICO PARA EXTINTOR [600%] | 5h | 1,151.91 | 03.12.05 | 000000000000197 |  | 1236.77 | 1236.77 |  |
| 218 | 1.4.12.6 | FLETE TERRESTRE | 1d | 2023-12-03 | 2023-12-03 | 9 | 237d |  | start no earlier than 2022-05-16 | FLETE TERRESTRE | 5h | 265,886.47 | 03.12.06 | 000000000000198 |  | 265886.47 | 265886.47 |  |

| ID | WBS | Task | Duration | Start | Finish | Predecessors | Total slack | Free slack | Constraint | Resources | Work | Cost | Text1 | Text8 | Text3 | Text4 | Text2 | Text6 |
| --- | --- | --- | --- | --- | --- | --- | --- | --- | --- | --- | --- | --- | --- | --- | --- | --- | --- | --- |
| 219 | 1.5 | **INSTALACIONES SANITARIAS** | 106d | 2024-03-05 | 2024-06-18 |  | 39d |  |  |  | 598.16h | 73,933.78 | 04 | 000000000000199 |  |  |  |  |
| 220 | 1.5.1 | **APARATOS Y ACCESORIOS SANITARIOS** | 7d | 2024-06-11 | 2024-06-18 |  | 0d |  |  |  | 29.54h | 7,271.19 | 04.01 | 000000000000200 |  |  |  |  |
| 221 | 1.5.1.1 | SUMINISTRO DE INODORO TANQUE BAJO BLANCO INC. ACCESORIOS | 1d | 2024-06-11 | 2024-06-12 | 182 | 0d |  | start no earlier than 2022-05-16 | OPERARIO [88.9%]; PEON [22.2%]; CINTA TEFLON [200%]; INODORO TANQUE BAJO NORMAL INC. ACCESORIOS [800%] | 5.56h | 1,876.02 | 04.01.01 | 000000000000201 | 302.1 | 2416.8 |  |  |
| 222 | 1.5.1.2 | SUMINISTRO DE URINARIOS DE LOSA VITRIFICADA INC. ACC. | 1d | 2024-06-12 | 2024-06-13 | 221 | 39d | 0d | start no earlier than 2022-05-16 | OPERARIO [40%]; PEON [10%]; CINTA TEFLON [50%]; URINARIO PICO BLANCO INC. ACCESORIOS [200%] | 2.5h | 519.62 | 04.01.02 | 000000000000202 | 279.8 | 559.6 |  |  |
| 223 | 1.5.1.3 | SUMINISTRO DE LAVATORIO LOSA VITRIFICADA INC. ACCESORIOS | 1d | 2024-06-13 | 2024-06-14 | 222 | 39d | 0d | start no earlier than 2022-05-16 | OPERARIO [81.2%]; PEON [20.3%]; CINTA TEFLON [325%]; LAVATORIO DE LOSA VITRIFICADA INC. ACCESORIOS [1300%] | 5.08h | 1,807.06 | 04.01.03 | 000000000000203 | 192.92 | 2507.96 | 13 |  |
| 224 | 1.5.1.4 | LAVADERO ACERO INOX. DE 2 POZAS C/ ESCURRIDERA DE 18"x35" | 1d | 2024-06-14 | 2024-06-15 | 223 | 39d | 0d | start no earlier than 2022-05-16 | OPERARIO [50%]; PEON [12.5%]; CINTA TEFLON [50%]; LAVADERO ACERO INOX. DE 2 POZAS C/ ESCURRIDERA DE 18"x35" ACCESORIOS [200%]; LLAVE TIPO GANZO [200%] | 3.12h | 760.85 | 04.01.04 | 000000000000204 | 405.42 | 810.84 |  |  |
| 225 | 1.5.1.5 | LAVADERO ACERO INOX. 1 POZA DE 18"x18" C/GRIF. AF | 1d | 2024-06-15 | 2024-06-16 | 224 | 39d | 0d | start no earlier than 2022-05-16 | OPERARIO [62.5%]; PEON [15.6%]; CINTA TEFLON [125%]; LAVADERO ACERO INOX. 1 POZA DE 18"x18" [500%]; LLAVE TIPO GANZO [500%] | 3.91h | 1,129.72 | 04.01.05 | 000000000000205 | 270.22 | 1351.1 |  |  |
| 226 | 1.5.1.6 | LAVARROPA LOSA VITRIFIACADA DE 18"x22" C/GRIF. AF | 1d | 2024-06-16 | 2024-06-17 | 225 | 39d | 0d | start no earlier than 2022-05-16 | OPERARIO [50%]; PEON [12.5%]; CINTA TEFLON [50%]; LAVARROPA DE LOSA VITRIFICADA INC. ACCESORIOS [200%] | 3.12h | 735.85 | 04.01.06 | 000000000000446 | 392.92 | 785.84 |  |  |
| 227 | 1.5.1.7 | DUCHA CROMADA | 1d | 2024-06-16 | 2024-06-17 | 226SS | 39d | 0d | start no earlier than 2022-05-16 | OPERARIO [25%]; CINTA TEFLON [50%]; DUCHA CROMADA INC. ACCESORIOS [200%] | 1.25h | 143.47 | 04.01.07 | 000000000000206 | 82.35 | 164.7 |  |  |
| 228 | 1.5.1.8 | SUMINISTRO DE PAPELERA DE LOSA Y BARRA PLASTICA | 1d | 2024-06-17 | 2024-06-18 | 227 | 39d |  | start no earlier than 2022-05-16 | OPERARIO [80%]; PEON [20%]; PORTA ROLLO PAPEL DE 18 CM [800%] | 5h | 298.59 | 04.01.08 | 000000000000207 | 72.73 | 581.84 |  |  |
| 229 | 1.5.2 | **SISTEMA DE AGUA FRIA** | 95d | 2024-03-16 | 2024-06-18 |  | 39d |  |  |  | 169.57h | 8,486.78 | 04.02 | 000000000000208 |  |  |  |  |
| 230 | 1.5.2.1 | EXCAVACION MANUAL DE ZANJAS | 2d | 2024-03-16 | 2024-03-17 | 272 | 116d | 0d | start no earlier than 2022-05-16 | PEON [184.6%] | 18.46h | 343.86 | 04.02.01 | 000000000000209 | 38.38 | 1983.48 | 51.68 |  |
| 231 | 1.5.2.2 | REFINE Y NIVELACION DE ZANJA P/ TUBERIA | 2d | 2024-03-16 | 2024-03-17 | 230SS | 116d | 0d | start no earlier than 2022-05-16 | PEON [86.1%] | 8.61h | 160.46 | 04.02.02 | 000000000000210 | 1.53 | 131.78 | 86.13 | 100 |
| 232 | 1.5.2.3 | CAMA DE APOYO DE ARENA e=0.10 m. | 2d | 2024-03-17 | 2024-03-19 | 231 | 116d | 0d | start no earlier than 2022-05-16 | PEON [86.1%]; CINTA SEÑALIZADORA AMARILLA [9474.3%]; ARENA GRUESA [1076.6%] | 8.61h | 862.42 | 04.02.03 | 000000000000211 | 11.23 | 967.24 | 86.13 | 50 |
| 233 | 1.5.2.4 | RELLENO DE ZANJAS C/ MATERIAL ZARANDEADO | 2d | 2024-03-19 | 2024-03-21 | 232 | 126d | 0d | start no earlier than 2022-05-16 | PEON [89.7%]; PLANCHA COMPACTADORA VIBRAT. 7 HP [89.7%]; AGUA [43.1%] | 17.94h | 281.99 | 04.02.04 | 000000000000212 | 42.32 | 1822.3 | 43.06 |  |
| 234 | 1.5.2.5 | ACARREO DE MATERIAL EXCEDENTE Dp= 30 M. | 1d | 2024-03-22 | 2024-03-22 | 233 | 126d | 0d | start no earlier than 2022-05-16 | PEON [89.8%] | 4.49h | 83.6 | 04.02.05 | 000000000000213 | 38.38 | 413.35 | 10.77 |  |
| 235 | 1.5.2.6 | ELIMINACIÓN DE MATERIAL EXCEDENTE C/EQUIPO Dp=5 KM. | 1d | 2024-03-23 | 2024-03-23 | 234 | 126d |  | start no earlier than 2022-05-16 | OPERARIO [3.6%]; PEON [7.2%]; VOLQUETE DE 10M3 [7.2%]; CARGADOR FRONTAL [3.6%] | 1.08h | 120.9 | 04.02.06 | 000000000000214 | 18.01 | 193.97 | 10.77 | 300 |
| 236 | 1.5.2.7 | SALIDA DE AGUA FRIA C/ TUBERIA PVC-SAP DE Ø1/2" | 5d | 2024-03-27 | 2024-04-01 | 245 | 116d | 0d | start no earlier than 2022-05-16 | PEGAMENTO PARA PVC [6.6%]; OPERARIO [91.7%]; OFICIAL [22.9%]; TUBERIA PVC C-10 Ø 1/2" X 5M. [4950%]; CODO PVC DE 1/2" X 90° [6600%]; TEE PVC DE 1/2" [3300%]; CINTA TEFLON [660%] | 28.64h | 1,072.37 | 04.02.07 | 000000000000215 | 53.77 | 1774.41 | 33 |  |
| 237 | 1.5.2.8 | SUMINISTRO E INST. TUBERIA PVC DE AGUA 1/2" C-10 | 5d | 2024-03-21 | 2024-03-26 | 238 | 116d | 0d | start no earlier than 2022-05-16 | PEGAMENTO PARA PVC [20.2%]; OPERARIO [50.5%]; OFICIAL [50.5%]; TUBERIA PVC C-10 Ø 1/2" X 5M. [10605%]; TEE PVC DE 1/2" [1010%] | 25.25h | 1,008.34 | 04.02.08 | 000000000000216 |  | 808 | 101 | 100 |
| 238 | 1.5.2.9 | SUMINISTRO E INST. TUBERIA PVC DE AGUA 1" C-10 | 2d | 2024-03-19 | 2024-03-21 | 232 | 116d | 0d | start no earlier than 2022-05-16 | PEGAMENTO PARA PVC [34.4%]; OPERARIO [86.1%]; PEON [86.1%]; TUBERIA PVC C-10 Ø 1" X 5M. [18086.2%] | 17.23h | 1,640.91 | 04.02.09 | 000000000000217 | 14.67 | 2526.91 | 172.25 | 50 |
| 239 | 1.5.2.10 | PRUEBA HIDRAULICA Y DESINFECCION P/ TUBERIA DE AGUA | 1d | 2024-03-26 | 2024-03-27 | 237 | 122d |  | start no earlier than 2022-05-16 | OPERARIO [68.3%]; OFICIAL [68.3%]; MOTOBOMBA [34.2%]; HIPOCLORITO DE CALCIO 70% [273.2%]; AGUA [273.2%] | 8.54h | 243.43 | 04.02.10 | 000000000000218 | 2.45 | 669.46 | 273.25 | 200 |
| 240 | 1.5.2.11 | VALVULA COMPUERTA DE 1/2" | 1d | 2024-04-01 | 2024-04-02 | 236 | 116d |  | start no earlier than 2022-05-16 | OPERARIO [72.2%]; PEON [18.1%]; CODO PVC DE 1/2" X 90° [5200%]; ADAPTADOR PVC DE 1/2" [2600%]; UNION UNIVERSAL PVC DE 1/2" [2600%]; NIPLE PVC 1/2" X 2" [2600%]; CINTA TEFLON [32.5%]; VALVULA COMPUERTA DE 1/2" [1300%] | 4.51h | 670.21 | 04.02.11 | 000000000000219 | 85.35 | 1109.55 | 13 |  |
| 241 | 1.5.2.12 | VALVULA COMPUERTA DE BRONCE DE 1" | 1d | 2024-03-27 | 2024-03-28 | 246 | 121d |  | start no earlier than 2022-05-16 | OPERARIO [16.7%]; PEON [4.2%]; ADAPTADOR PVC DE 1" [300%]; UNION UNIVERSAL PVC DE 1" [200%]; NIPLE PVC 1" [200%]; CINTA TEFLON [15%]; VALVULA CHECK HORIZONTAL DE 1"; VALVULA COMPUERTA DE BRONCE ROSCADA DE 1" | 1.04h | 169.79 | 04.02.12 | 000000000000220 | 186.45 | 186.45 |  |  |
| 242 | 1.5.2.13 | CODO PVC-SAP DE Ø1" | 1d | 2024-03-26 | 2024-03-27 | 237 | 121d | 0d | start no earlier than 2022-05-16 | PEGAMENTO PARA PVC [2.2%]; OPERARIO [73.3%]; CODO PVC 1" X 90° [1100%]; CINTA TEFLON [220%] | 3.67h | 149.19 | 04.02.13 | 000000000000222 | 19.22 | 211.42 | 11 | 15 |
| 243 | 1.5.2.14 | CODO PVC-SAP DE Ø1/2" | 1d | 2024-03-26 | 2024-03-27 | 237 | 116d | 0d | start no earlier than 2022-05-16 | PEGAMENTO PARA PVC [5.8%]; OPERARIO [72.5%]; CODO PVC DE 1/2" X 90° [2900%]; CINTA TEFLON [580%] | 3.62h | 162.59 | 04.02.14 | 000000000000223 | 13.12 | 380.48 | 29 | 20 |
| 244 | 1.5.2.15 | TEE PVC-SAP DE Ø1" | 1d | 2024-03-26 | 2024-03-27 | 242SS | 121d | 0d | start no earlier than 2022-05-16 | PEGAMENTO PARA PVC [1.8%]; OPERARIO [60%]; TEE PVC DE 1" [900%]; CINTA TEFLON [180%] | 3h | 121.88 | 04.02.15 | 000000000000224 | 19.2 | 172.8 |  | 15 |
| 245 | 1.5.2.16 | TEE PVC-SAP DE Ø1/2" | 1d | 2024-03-26 | 2024-03-27 | 243SS | 116d | 0d | start no earlier than 2022-05-16 | PEGAMENTO PARA PVC [1%]; OPERARIO [25%]; TEE PVC DE 1/2" [500%]; CINTA TEFLON | 1.25h | 42.7 | 04.02.16 | 000000000000225 | 12.78 | 63.9 |  | 20 |
| 246 | 1.5.2.17 | REDUCCION PVC-SAP DE Ø 1" A 1/2" | 1d | 2024-03-26 | 2024-03-27 | 244SS | 121d | 0d | start no earlier than 2022-05-16 | PEGAMENTO PARA PVC [1.8%]; OPERARIO [60%]; REDUCCION PVC DE 1" A 1/2" [900%]; CINTA TEFLON [180%] | 3h | 93.26 | 04.02.17 | 000000000000226 | 16.02 | 144.18 |  | 15 |
| 247 | 1.5.2.18 | CAJA P/VALVULAS DE 0.35X0.15M + TAPA DE MADERA | 1d | 2024-03-17 | 2024-03-18 | 163 | 131d |  | start no earlier than 2022-05-16 | CEMENTO PORTLAND TIPO MS (42.5 kg) [13%]; OFICIAL [81.2%]; ARENA FINA [26%]; AGUA; TAPA DE MADERA 0.20 X 0.25 M. C/ MARCO ALUMINIO 3/4" X 3/4" [1300%] | 4.06h | 356.53 | 04.02.18 | 000000000000227 | 42.21 | 548.73 | 13 |  |
| 248 | 1.5.2.19 | CAJA DE CONTROL 0.60X0.60X0.45 C/ TAPA F'C=175 KG/CM2 | 1d | 2024-03-27 | 2024-03-28 | 246 | 121d |  | start no earlier than 2022-05-16 | CEMENTO PORTLAND TIPO MS (42.5 kg) [200%]; OPERARIO [25%]; PEON [6.2%]; CLAVOS P/ MADERA CON CABEZA 2" 2 1/2" 3" 4" [30%]; PIEDRA CHANCADA 1/2" [50%]; ARENA GRUESA [40%]; AGUA [21%]; MADERA TORNILLO [950%]; TAPA DE CONCRETO DE 57X57 CM INC. ACCESORIOS; SUMIDERO DE BRONCE DE 3" | 1.56h | 302.34 | 04.02.19 | 000000000000228 | 327.34 | 327.34 |  |  |
| 249 | 1.5.2.20 | EMPALME CONEXION DE AGUA | 1d | 2024-06-18 | 2024-06-18 | 227 | 39d |  | start no earlier than 2022-05-16 | EMPALME DE AGUA POTABLE | 5h | 600 | 04.02.20 | 000000000000229 | 600 | 600 |  |  |

| ID | WBS | Task | Duration | Start | Finish | Predecessors | Total slack | Free slack | Constraint | Resources | Work | Cost | Text1 | Text8 | Text3 | Text4 | Text2 | Text6 |
| --- | --- | --- | --- | --- | --- | --- | --- | --- | --- | --- | --- | --- | --- | --- | --- | --- | --- | --- |
| 250 | 1.5.3 | **CISTERNA Y TANQUE ELEVADO** | 1d | 2024-06-17 | 2024-06-18 |  | 39d |  |  |  | 43.33h | 4,703.9 | 04.03 | 000000000000230 |  |  |  |  |
| 251 | 1.5.3.1 | SUM. E INST EQ. BOMBEO, 02 ELECTROBOMBAS CENTRIFUGAS | 1d | 2024-06-17 | 2024-06-18 | 226 | 39d | 0d | start no earlier than 2022-05-16 | OPERARIO; PEON [50%]; ELECTROBOMBA 1 HP INC. ACCESORIOS [200%] | 7.5h | 977.52 | 04.03.01 | 000000000000231 | 546.28 | 1092.56 |  |  |
| 252 | 1.5.3.2 | SUM. E. INST. DE LINEA DE SUCCION 11/2", INC. VALVULAS Y ACCES. | 1d | 2024-06-17 | 2024-06-18 | 251SS | 39d | 0d | start no earlier than 2022-05-16 | PINTURA ESMALTE [4%]; PINTURA ANTICORROSIVA [4%]; OPERARIO; PEON [50%]; TUBERIA PVC C-10 Ø 1 1/2" [500%]; TUBO DE ACERO SCH-40 DE Ø1 1/2" ROSCADA GALV. [150%]; LIJA DE FIERRO #80 [10%]; UNION UNIVERSAL PVC-SAP C/R 1 1/2" [200%]; CODO DE ACERO SCH-40 Ø1 1/2" X90° [200%]; BRIDA DE ACERO INOX. PARA SOLDAR ROMPE AGUA DE 1 1/2" [200%]; VALVULA DE PIE Y CANASTILLA DE BRONCE 11/2" [200%] | 7.5h | 536.2 | 04.03.02 | 000000000000232 | 651.23 | 651.23 |  |  |
| 253 | 1.5.3.3 | SUM. E. INST. DE LINEA DE IMPULSION 11/4", INC. VALVULAS Y ACCES. | 1d | 2024-06-17 | 2024-06-18 | 252SS | 39d | 0d | start no earlier than 2022-05-16 | PINTURA ESMALTE [2%]; PINTURA ANTICORROSIVA [2%]; OPERARIO; PEON [50%]; TUBO DE ACERO SCH-40 DE Ø1 1/4" ROSCADA GALV. [850%]; LIJA DE FIERRO #80 [13.2%]; TEE DE ACERO SCH-40 Ø1 1/4" [400%]; ABRAZADERA DE FIJACION DE 1.1/4" F°G° [600%]; CODO DE ACERO SCH-40 Ø1 1/4" X90° [400%]; UNION UNIVERSAL DE F° G° DE 3/4" [200%]; UNION UNIVERSAL DE F° G° DE 11 /4" [1000%]; TAPON HEMBRA DE FIERRO GALVANIZADO DE 3/4"; TAPON HEMBRA DE FIERRO GALVANIZADO DE 1 1/4" [200%]; REDUCCION EXCENTRICA DE ACERO SCH-40 DE 1 1/4" A 1" [200%]; REDUCCION EXCENTRICA DE ACERO SCH-40 DE 1 1/4" A 3/4"; BRIDA DE ACERO INOX. PARA SOLDAR ROMPE AGUA DE 1 1/4"; VALVULA CHECK 1 1/4" [200%]; VALVULA COMPUERTA DE BRONCE DE 3/4"; VALVULA COMPUERTA DE BRONCE DE 1 1/4" [300%]; APOYO METALICO EN CADA SOPORTE TEE Y CODO H=0.62-0.80 [300%] | 7.5h | 941.41 | 04.03.03 | 000000000000233 | 1056.45 | 1056.45 |  |  |
| 254 | 1.5.3.4 | SUM. E. INST. DE LINEA DE ALIMENTACION 2", INC. VALVULAS Y ACCES. | 1d | 2024-06-17 | 2024-06-18 | 253SS | 39d | 0d | start no earlier than 2022-05-16 | OPERARIO; PEON [50%]; TUBO DE ACERO SCH-40 DE Ø2" ROSCADA GALV. [1350%]; PROTECCION DE CONCRETO 0.15X0.15 M; TEE DE ACERO SCH-40 Ø2" [200%]; ABRAZADERA DE FIJACION DE 2" F°G° [600%]; CODO DE ACERO SCH-40 Ø2" X90° [600%]; UNION UNIVERSAL DE F° G° DE 2" [400%]; BRIDA DE ACERO INOX. PARA SOLDAR ROMPE AGUA DE 2"; VALVULA CHECK VERTICAL DE 2"; VALVULA COMPUERTA DE BRONCE DE 2"; UNION TRANSICION AC. A PVC DE 2" | 7.5h | 1,052.36 | 04.03.04 | 000000000000234 | 1167.39 | 1167.39 |  |  |
| 255 | 1.5.3.5 | SUM. E. INST. DE LINEA DE REBOSE Y LIMPIA 2", PARA TANQUE ELEVADO | 1d | 2024-06-17 | 2024-06-18 | 254SS | 39d | 0d | start no earlier than 2022-05-16 | PINTURA ESMALTE [0.4%]; PINTURA ANTICORROSIVA [0.6%]; OPERARIO; TUBO DE ACERO SCH-40 DE Ø2" ROSCADA GALV. [1265%]; LIJA DE FIERRO #80 [2%]; TEE DE ACERO SCH-40 Ø2" [200%]; ABRAZADERA DE FIJACION DE 2" F°G° [700%]; SOMBRERO DE VENTILACION PVC DE 2"; MALLA PARA SOLDAR 2"; CODO DE ACERO SCH-40 Ø2" X90° [500%]; UNION UNIVERSAL DE F° G° DE 2" [200%]; BRIDA DE ACERO INOX. PARA SOLDAR ROMPE AGUA DE 2" [200%]; VALVULA COMPUERTA DE BRONCE DE 2" | 5h | 745.75 | 04.03.05 | 000000000000235 | 830.62 | 830.62 |  |  |
| 256 | 1.5.3.6 | SUM. E. INST. DE LINEA DE REBOSE 3", PARA CISTERNA | 1d | 2024-06-17 | 2024-06-18 | 255SS | 39d | 0d | start no earlier than 2022-05-16 | PINTURA ESMALTE [0.4%]; PINTURA ANTICORROSIVA [0.6%]; OPERARIO; TUBO DE ACERO SCH-40 DE Ø3" ROSCADA GALV. [60%]; LIJA DE FIERRO #80 [2%]; MALLA PARA SOLDAR 3"; CODO DE ACERO SCH-40 Ø3" X90°; BRIDA DE ACERO INOX. PARA SOLDAR ROMPE AGUA DE 3" | 5h | 274.02 | 04.03.06 | 000000000000236 | 358.89 | 358.89 |  |  |
| 257 | 1.5.3.7 | CAJA DE CONCRETO CON REJILLA METALICA PARA REBOSE 0.3X0.6X0.25 | 1d | 2024-06-17 | 2024-06-18 | 256SS | 39d |  | start no earlier than 2022-05-16 | CEMENTO PORTLAND TIPO MS (42.5 kg); OPERARIO [33.3%]; PEON [33.3%]; CLAVOS P/ MADERA CON CABEZA 2" 2 1/2" 3" 4" [5%]; ELECTRODO E-6011-CELLOCORD [20%]; ANGULO 1 1/2" x 1 1/2" x 1/8 [200%]; PLATINA DE FIERRO 1/4" X 1" [800%]; ARENA FINA [1.5%]; ARENA GRUESA [6%]; AGUA [2%]; MADERA TORNILLO [150%] | 3.33h | 176.63 | 04.03.07 | 000000000000237 | 225.05 | 225.05 |  |  |
| 258 | 1.5.4 | **DESAGUE Y VENTILACION** | 33d | 2024-03-05 | 2024-04-06 |  | 112d |  |  |  | 184.31h | 11,492.04 | 04.04 | 000000000000238 |  |  |  |  |
| 259 | 1.5.4.1 | EXCAVACION MANUAL DE ZANJAS | 2d | 2024-03-05 | 2024-03-06 | 147 | 116d | 0d | start no earlier than 2022-05-16 | PEON [180.1%] | 18.01h | 335.57 | 04.04.01 | 000000000000240 | 38.38 | 1659.17 | 43.23 |  |
| 260 | 1.5.4.2 | REFINE Y NIVELACION DE ZANJA P/ TUBERIA | 2d | 2024-03-05 | 2024-03-06 | 259SS | 116d | 0d | start no earlier than 2022-05-16 | PEON [72%] | 7.21h | 134.23 | 04.04.02 | 000000000000241 | 1.53 | 110.24 | 72.05 | 100 |
| 261 | 1.5.4.3 | CAMA DE APOYO DE ARENA e=0.10 m. | 2d | 2024-03-06 | 2024-03-08 | 260 | 116d | 0d | start no earlier than 2022-05-16 | PEON [72%]; CINTA SEÑALIZADORA AMARILLA [7925.5%]; ARENA GRUESA [900.6%] | 7.21h | 721.43 | 04.04.03 | 000000000000242 | 11.23 | 809.12 | 72.05 | 50 |
| 262 | 1.5.4.4 | RELLENO DE ZANJAS C/ MATERIAL ZARANDEADO | 2d | 2024-03-08 | 2024-03-10 | 261 | 136d | 0d | start no earlier than 2022-05-16 | PEON [85.8%]; PLANCHA COMPACTADORA VIBRAT. 7 HP [85.8%]; AGUA [36%] | 17.16h | 269.34 | 04.04.04 | 000000000000243 | 42.32 | 1524.79 | 36.03 |  |
| 263 | 1.5.4.5 | ACARREO DE MATERIAL EXCEDENTE Dp= 30 M. | 1d | 2024-03-11 | 2024-03-11 | 262 | 136d | 0d | start no earlier than 2022-05-16 | PEON [75.1%] | 3.75h | 69.94 | 04.04.05 | 000000000000244 | 38.38 | 345.8 | 9.01 |  |
| 264 | 1.5.4.6 | ELIMINACIÓN DE MATERIAL EXCEDENTE C/EQUIPO Dp=5 KM. | 2d | 2024-03-12 | 2024-03-13 | 263 | 136d |  | start no earlier than 2022-05-16 | OPERARIO [3%]; PEON [6%]; VOLQUETE DE 10M3 [6%]; CARGADOR FRONTAL [3%] | 1.8h | 202.29 | 04.04.06 | 000000000000245 | 18.01 | 162.27 | 9.01 | 300 |
| 265 | 1.5.4.7 | SALIDA DESAGUE DE PVC SAP DE 2" | 2d | 2024-03-14 | 2024-03-16 | 266SS | 129d | 0d | start no earlier than 2022-05-16 | PEGAMENTO PARA PVC [20.5%]; OPERARIO [85.4%]; PEON [21.4%]; TUBERIA PVC P/ DESAGUE DE 2" [6150%]; CODO PVC SAP 2" X 90° [4100%] | 10.68h | 680.96 | 04.04.07 | 000000000000246 | 41.96 | 1720.36 | 41 |  |
| 266 | 1.5.4.8 | SALIDA DESAGUE DE PVC SAP DE 4" | 2d | 2024-03-14 | 2024-03-16 | 268 | 129d | 0d | start no earlier than 2022-05-16 | PEGAMENTO PARA PVC [8%]; OPERARIO; PEON [50%]; TUBERIA PVC P/ DESAGUE DE 4" [2400%]; CODO PVC SAP 4" X 90° [1600%]; TEE PVC SAP DE 4" [1600%] | 15h | 826.6 | 04.04.08 | 000000000000247 | 66.05 | 1056.8 | 16 |  |
| 267 | 1.5.4.9 | SALIDA DE VENTILACION PVC DE 2" | 2d | 2024-03-16 | 2024-03-18 | 265 | 129d | 0d | start no earlier than 2022-05-16 | PEGAMENTO PARA PVC [6%]; OPERARIO [75%]; PEON [18.8%]; TUBERIA PVC P/ DESAGUE DE 2" [7200%]; CODO PVC SAP 2" X 90° [1200%] | 9.38h | 608.42 | 04.04.09 | 000000000000248 | 63.2 | 758.4 | 12 |  |
| 268 | 1.5.4.10 | TUBERIA PVC-SAP DESAGUE Ø2", RED INTERIOR | 2d | 2024-03-12 | 2024-03-14 | 269 | 116d | 0d | start no earlier than 2022-05-16 | PEGAMENTO PARA PVC [38.6%]; OPERARIO [77.3%]; PEON [38.6%]; TUBERIA PVC P/ DESAGUE DE 2" [8116.5%] | 10.44h | 680.51 | 04.04.10 | 000000000000249 | 11.46 | 885.86 | 77.3 | 50 |
| 269 | 1.5.4.11 | TUBERIA PVC-SAP DESAGUE Ø4", RED INTERIOR | 2d | 2024-03-10 | 2024-03-12 | 271 | 116d | 0d | start no earlier than 2022-05-16 | PEGAMENTO PARA PVC [11.8%]; OPERARIO [47.4%]; PEON [23.7%]; TUBERIA PVC P/ DESAGUE DE 4" [2488.5%] | 7.11h | 447.53 | 04.04.11 | 000000000000250 | 17.63 | 417.83 | 23.7 | 50 |
| 270 | 1.5.4.12 | MONTANTE Y/O VENTIL. TUBERIA PVC-SAP Ø2" | 2d | 2024-03-14 | 2024-03-16 | 268 | 133d |  | start no earlier than 2022-05-16 | PEGAMENTO PARA PVC [25.8%]; OPERARIO [51.5%]; PEON [25.8%]; TUBERIA PVC P/ DESAGUE DE 2" [5407.5%] | 7.72h | 471.67 | 04.04.12 | 000000000000251 | 11.46 | 590.19 | 51.5 | 50 |
| 271 | 1.5.4.13 | TUBERIA PVC-SAP DESAGUE Ø4", RED EXTERIOR | 2d | 2024-03-08 | 2024-03-10 | 261 | 116d | 0d | start no earlier than 2022-05-16 | PEGAMENTO PARA PVC [72%]; OPERARIO [96.1%]; PEON [48%]; TUBERIA PVC P/ DESAGUE DE 4" [15130.5%] | 14.41h | 2,038.89 | 04.04.13 | 000000000000252 | 17.63 | 2540.48 | 144.1 | 50 |
| 272 | 1.5.4.14 | PRUEBA HIDRAULICA DE ESTANQUEIDAD Y ESCORRENTIA | 1d | 2024-03-14 | 2024-03-15 | 268 | 116d | 0d | start no earlier than 2022-05-16 | OPERARIO [61.3%]; OFICIAL [122.5%]; AGUA [245.1%] | 9.19h | 222.05 | 04.04.14 | 000000000000253 | 2.84 | 696.08 | 245.1 | 200 |
| 273 | 1.5.4.15 | SUMIDERO DE BRONCE 2" | 1d | 2024-04-05 | 2024-04-06 | 144 | 112d | 0d | start no earlier than 2022-05-16 | OPERARIO [75%]; CODO PVC SAP 2" X 90° [4500%]; SUMIDERO DE BRONCE DE 2" [1500%] | 3.75h | 319.01 | 04.04.15 | 000000000000254 | 36.3 | 544.5 | 15 | 10 |
| 274 | 1.5.4.16 | REGISTRO DE BRONCE 2" | 1d | 2024-04-05 | 2024-04-06 | 273SS | 112d | 0d | start no earlier than 2022-05-16 | OPERARIO [20%]; REGISTRO DE BRONCE DE 2" [200%] | 1h | 45.19 | 04.04.16 | 000000000000255 | 31.08 | 62.16 |  | 10 |
| 275 | 1.5.4.17 | REGISTRO DE BRONCE 4" | 1d | 2024-04-05 | 2024-04-06 | 274SS | 112d |  | start no earlier than 2022-05-16 | OPERARIO; REGISTRO DE BRONCE DE 4" [800%] | 5h | 291.59 | 04.04.17 | 000000000000256 | 47.06 | 376.48 |  |  |
| 276 | 1.5.4.18 | SOMBRERO DE VENTILACION 2" | 1d | 2024-03-18 | 2024-03-19 | 267 | 129d | 0d | start no earlier than 2022-05-16 | PEGAMENTO PARA PVC [2.4%]; OPERARIO; SOMBRERO DE VENTILACION PVC DE 2" [1200%] | 5h | 183.89 | 04.04.18 | 000000000000257 | 22.39 | 268.68 | 12 | 12 |
| 277 | 1.5.4.19 | CODO 2"X45° PVC-SAP | 1d | 2024-03-19 | 2024-03-20 | 276 | 129d | 0d | start no earlier than 2022-05-16 | OPERARIO [60%]; CODO PVC SAP 2" X 45° [1800%] | 3h | 122.67 | 04.04.19 | 000000000000258 | 16.84 | 303.12 | 18 | 15 |
| 278 | 1.5.4.20 | YEE 2" PVC-SAP | 1d | 2024-03-19 | 2024-03-20 | 277SS | 129d | 0d | start no earlier than 2022-05-16 | OPERARIO [90%]; YEE PVC SAP DE 2" [2700%] | 4.5h | 188.86 | 04.04.20 | 000000000000259 | 17.02 | 459.54 | 27 | 15 |
| 279 | 1.5.4.21 | YEE 4" PVC-SAP | 1d | 2024-03-19 | 2024-03-20 | 278SS | 129d | 0d | start no earlier than 2022-05-16 | OPERARIO [26.7%]; YEE PVC SAP DE 4" [400%] | 1.33h | 83.04 | 04.04.21 | 000000000000260 | 26.42 | 105.68 |  | 15 |
| 280 | 1.5.4.22 | YEE 4" A 2" PVC-SAP | 1d | 2024-03-19 | 2024-03-20 | 279SS | 129d | 0d | start no earlier than 2022-05-16 | OPERARIO [70%]; YEE PVC SAP DE 4" A 2" [2100%] | 3.5h | 344.29 | 04.04.22 | 000000000000261 | 26.42 | 554.82 | 21 | 15 |
| 281 | 1.5.4.23 | REDUCCION 4" A 2" PVC-SAP | 1d | 2024-03-19 | 2024-03-20 | 280SS | 129d |  | start no earlier than 2022-05-16 | OPERARIO [13.3%]; REDUCCION PVC SAP DE 4" A 2" [200%] | 0.67h | 35.86 | 04.04.23 | 000000000000262 | 23.59 | 47.18 |  | 15 |
| 282 | 1.5.4.24 | CAJA DE REG. CONCRETO. 12" x 24" (0.30x0.60) C/ TAPA CONCRETO REFORZADO | 2d | 2024-03-10 | 2024-03-12 | 271 | 134d | 0d | start no earlier than 2022-05-16 | OPERARIO [87.5%]; PEON [87.5%]; CAJA DE CONCRETO PREFABRICADA DE DESAGUE DE 12" X 24" [1400%] | 17.5h | 2,168.22 | 04.04.24 | 000000000000263 | 219.19 | 3068.66 | 14 |  |

| ID | WBS | Task | Duration | Start | Finish | Predecessors | Total slack | Free slack | Constraint | Resources | Work | Cost | Text1 | Text8 | Text2 | Text3 | Text4 | Text6 |
| --- | --- | --- | --- | --- | --- | --- | --- | --- | --- | --- | --- | --- | --- | --- | --- | --- | --- | --- |
| 283 | 1.5.5 | **BIODIGESTOR** | 3d | 2024-03-12 | 2024-03-15 |  | 134d |  |  |  | 57.7h | 18,451.56 | 04.05 | 000000000000264 |  |  |  |  |
| 284 | 1.5.5.1 | EXCAVACION MANUAL DE ZANJAS | 1d | 2024-03-13 | 2024-03-13 | 282 | 134d | 0d | start no earlier than 2022-05-16 | PEON [83.3%] | 4.16h | 77.55 | 04.05.01 | 000000000000265 | 14.57 | 43.86 | 639.04 | 3.5 |
| 285 | 1.5.5.2 | FILTRO DE GRAVA | 1d | 2024-03-13 | 2024-03-14 | 284 | 134d | 0d | start no earlier than 2022-05-16 | PEON [47.5%]; GRAVA [237.5%] | 2.38h | 193.87 | 04.05.02 | 000000000000266 | 1.9 | 117.13 | 222.55 |  |
| 286 | 1.5.5.3 | TUBERIA DE COLECTOR PVC Ø2" | 1d | 2024-03-14 | 2024-03-15 | 285 | 134d | 0d | start no earlier than 2022-05-16 | OPERARIO [8%]; PEON [4%]; TUBERIA PVC P/ DESAGUE DE 2" [420%] | 0.6h | 34.03 | 04.05.03 | 000000000000267 |  | 10.81 | 43.24 | 50 |
| 287 | 1.5.5.4 | TUBERIA DE COLECTOR PVC Ø4" | 1d | 2024-03-14 | 2024-03-15 | 286SS | 134d | 0d | start no earlier than 2022-05-16 | OPERARIO [12%]; PEON [6%]; TUBERIA PVC P/ DESAGUE DE 4" [630%] | 0.9h | 88.08 | 04.05.04 | 000000000000268 |  | 16.98 | 101.88 | 50 |
| 288 | 1.5.5.5 | CODO PVC DESAGUE Ø4" | 1d | 2024-03-14 | 2024-03-15 | 287SS | 134d |  | start no earlier than 2022-05-16 | OPERARIO [20%]; CODO PVC SAP 4" X 90° [200%] | 1h | 39.31 | 04.05.05 | 000000000000269 |  | 28.14 | 56.28 | 10 |
| 289 | 1.5.5.6 | CAJA DE REGISTRO (0.60X0.60X0.60 m.) | 1d | 2024-03-12 | 2024-03-13 | 282 | 136d |  | start no earlier than 2022-05-16 | OPERARIO [50%]; PEON [50%]; CAJA DE REGISTRO DE CONCRETO 0.50 x 0.80 m. [200%] | 5h | 509.21 | 04.05.06 | 000000000000270 |  | 290.91 | 581.82 |  |
| 290 | 1.5.5.7 | CAJA DE LODOS (0.80 X 0.80 m.), C° F'c=175KG/CM2 | 1d | 2024-03-12 | 2024-03-13 | 282 | 134d | 0d | start no earlier than 2022-05-16 | CEMENTO PORTLAND TIPO MS (42.5 kg) [1086%]; OPERARIO [80%]; OFICIAL [80%]; PEON [160%]; VIBRADOR PARA CONCRETO [40%]; MEZCLADORA DE 9-11P3 [80%]; ALAMBRE NEGRO N° 16 [440%]; ACERO Fy = 4200 KG/CM2 (GRADO 60) [4420%]; CLAVOS P/ MADERA CON CABEZA 2" 2 1/2" 3" 4" [50%]; PIEDRA CHANCADA 1/2" [80%]; ARENA GRUESA [60%]; AGUA [25%]; MADERA TORNILLO [2560%] | 22h | 1,238.73 | 04.05.07 | 000000000000271 |  | 751.69 | 1503.38 | 2.5 |
| 291 | 1.5.5.8 | VALVULA DE CONTROL TIPO BOLA D=Ø2" | 1d | 2024-03-13 | 2024-03-14 | 290 | 134d | 0d | start no earlier than 2022-05-16 | OPERARIO [33.3%]; VALVULA DE BOLA Ø2" [200%] | 1.67h | 121.45 | 04.05.08 | 000000000000272 |  | 74.87 | 149.74 |  |
| 292 | 1.5.5.9 | BIODIGESTOR DE 5,000 L | 1d | 2024-03-14 | 2024-03-15 | 291 | 134d |  | start no earlier than 2022-05-16 | OPERARIO; OFICIAL; PEON [200%]; BIODIGESTOR (5 000 L) [200%] | 20h | 16,149.33 | 04.05.09 | 000000000000273 |  | 8210.83 | 16421.66 |  |
| 293 | 1.5.6 | **SISTEMA DE EVACUACION PLUVIAL** | 10d | 2024-04-14 | 2024-04-24 |  | 94d |  |  |  | 113.7h | 23,528.32 | 04.06 | 000000000000274 |  |  |  |  |
| 294 | 1.5.6.1 | BAJADA DE DRENAJE PLUVIAL INC. TUBERIA PVC DE 4" | 5d | 2024-04-19 | 2024-04-24 | 295 | 94d |  | start no earlier than 2022-05-16 | PEGAMENTO PARA PVC [26%]; OPERARIO [81.2%]; OFICIAL [81.2%]; TUBERIA PVC P/ DESAGUE DE 4" [16900%]; ABRAZADERA DE F° P/TUBO DE 4" [7800%]; CODO PVC SAP 4" X 90° [2600%]; CODO PVC SAP 4" X 45° [5200%] | 40.62h | 4,570.51 | 04.06.01 | 000000000000275 | 26 | 187.42 | 4872.92 |  |
| 295 | 1.5.6.2 | CANALETA DE FºGº e= 1/27", INC. ABRAZADERA | 5d | 2024-04-14 | 2024-04-19 | 168 | 94d | 0d | start no earlier than 2022-05-16 | OPERARIO [97.4%]; PEON [97.4%]; SOLDADORA ELECTRICA [97.4%]; SOLDADURA CELLOCORD [25333%]; CANALETA METALICA 1/27 [26599.7%]; ABRAZADERA DE F°G° C/ DOS OREJAS 1" X 3/8" [50666%]; TIRAFON GALVANIZADO 1 1/2"X2" [101332%]; TARUGO DE PVC [101332%] | 73.08h | 18,957.8 | 04.06.02 | 000000000000276 | 253.33 | 93.55 | 23699.02 | 20 |
| 296 | 1.6 | **INSTALACIONES ELECTRICAS** | 144d | 2024-03-05 | 2024-07-26 |  | 1d |  |  |  | 669.82h | 178,224.21 | 05 | 000000000000277 |  |  |  |  |
| 297 | 1.6.1 | **MOVIMIENTO DE TIERRAS** | 8d | 2024-03-05 | 2024-03-12 |  | 121d |  |  |  | 50.2h | 1,668.6 | 05.01 | 000000000000280 |  |  |  |  |
| 298 | 1.6.1.1 | EXCAVACION MANUAL DE ZANJAS | 4d | 2024-03-05 | 2024-03-08 | 147 | 121d | 0d | start no earlier than 2022-05-16 | PEON [95.3%] | 19.06h | 355.09 | 05.01.01 | 000000000000281 | 60.04 | 43.86 | 2633.35 | 3.5 |
| 299 | 1.6.1.2 | REFINE Y NIVELACION DE ZANJA P/ TUBERIA | 4d | 2024-03-05 | 2024-03-08 | 298SS | 121d | 0d | start no earlier than 2022-05-16 | PEON [75%] | 15.01h | 279.64 | 05.01.02 | 000000000000361 | 75.05 | 1.53 | 114.83 | 100 |
| 300 | 1.6.1.3 | CAMA DE ARENA e=0.10 m. P/ RED ELECTRICA INC. SEÑALIZACION | 1d | 2024-03-08 | 2024-03-09 | 299 | 121d | 0d | start no earlier than 2022-05-16 | PEON [75%]; CINTA SEÑALIZADORA AMARILLA [8255.5%]; ARENA GRUESA [938.1%] | 3.75h | 681.56 | 05.01.03 | 000000000000283 | 75.05 | 11.23 | 842.81 | 50 |
| 301 | 1.6.1.4 | RELLENO DE ZANJAS C/ MATERIAL ZARANDEADO | 1d | 2024-03-09 | 2024-03-10 | 300 | 137d | 0d | start no earlier than 2022-05-16 | PEON [97.3%]; PLANCHA COMPACTADORA VIBRAT. 7 HP [48.7%]; AGUA [105.1%] | 7.3h | 127.72 | 05.01.04 | 000000000000282 | 52.54 | 34.05 | 1788.99 |  |
| 302 | 1.6.1.5 | ACARREO DE MATERIAL EXCEDENTE Dp= 30 M. | 1d | 2024-03-11 | 2024-03-11 | 301 | 137d | 0d | start no earlier than 2022-05-16 | PEON [78.2%] | 3.91h | 72.81 | 05.01.05 | 000000000000284 | 9.38 | 38.38 | 360 |  |
| 303 | 1.6.1.6 | ELIMINACIÓN DE MATERIAL EXCEDENTE C/EQUIPO Dp=5 KM. | 1d | 2024-03-12 | 2024-03-12 | 302 | 137d |  | start no earlier than 2022-05-16 | PEON [9.4%]; VOLQUETE DE 10M3 [9.4%]; CARGADOR FRONTAL [4.7%] | 1.17h | 151.78 | 05.01.06 | 000000000000285 | 9.38 | 25.93 | 243.22 | 100 |
| 304 | 1.6.2 | **TUBERIAS, DUCTOS Y BUZONES** | 100d | 2024-03-09 | 2024-06-17 |  | 23d | 0d |  |  | 60.1h | 16,237.09 | 05.02 | 000000000000286 |  |  |  |  |
| 305 | 1.6.2.1 | TUBERIA PVC-SAP ELECTRICA DE 50 mm | 2d | 2024-03-09 | 2024-03-11 | 300 | 121d | 0d | start no earlier than 2022-05-16 | PEGAMENTO PARA PVC [66.6%]; OPERARIO [95.1%]; PEON [47.6%]; TUBERIA PVC-SAP ELECTRICA DE 2" X 3 m (50 mm) [34965%]; CURVAS PVC-SAP ELECTRICAS 2" (50 mm) [3330%] | 14.27h | 5,264.82 | 05.02.01 | 000000000000287 | 333 | 20.76 | 6913.08 | 50 |
| 306 | 1.6.2.2 | BUZON DE CONCRETO 0.60X0.60X.80 m. | 5d | 2024-06-12 | 2024-06-17 | 221 | 0d |  | start no earlier than 2022-05-16 | OPERARIO [91.7%]; OFICIAL [91.7%]; BUZON DE C°0.60 x 0.60 x 0.80 m. P/ RED ELECTRICA [1100%] | 45.83h | 10,972.27 | 05.02.02 | 000000000000288 | 11 | 996.39 | 10960.29 |  |

| ID | WBS | Task | Duration | Start | Finish | Predecessors | Total slack | Free slack | Constraint | Resources | Work | Cost | Text1 | Text8 | Text2 | Text3 | Text4 | Text6 |
| --- | --- | --- | --- | --- | --- | --- | --- | --- | --- | --- | --- | --- | --- | --- | --- | --- | --- | --- |
| 307 | 1.6.3 | **SALIDA ELECTRICAS** | 17d | 2024-03-11 | 2024-03-28 |  | 121d |  |  |  | 154.45h | 22,447.05 | 05.03 | 000000000000289 |  |  |  |  |
| 308 | 1.6.3.1 | SALIDA PARA CENTRO DE LUZ | 8d | 2024-03-11 | 2024-03-19 | 305 | 121d | 0d | start no earlier than 2022-05-16 | PEGAMENTO PARA PVC [16.2%]; OPERARIO [96.4%]; PEON [48.2%]; TUBERIA PVC-SAP ELECTRICA DE 3/4" X 3 m (20 mm) [24300%]; CABLE 2.5 mm2 LSOH-80 [97200%]; CURVAS PVC-SAP ELECTRICAS 3/4" (20 mm) [24300%]; UNIONES PVC-SAP 3/4" ELECTRICAS (20 mm) [8100%]; CAJA DE PASE OCTOGONAL SAP 100 X 40 mm [8100%] | 57.86h | 3,448.02 | 05.03.01 | 000000000000290 | 81 | 50.04 | 4053.24 | 12 |
| 309 | 1.6.3.2 | SALIDA PARA BRAQUET (PARED) | 5d | 2024-03-19 | 2024-03-24 | 308 | 121d | 0d | start no earlier than 2022-05-16 | PEGAMENTO PARA PVC [11%]; OPERARIO [91.7%]; PEON [45.8%]; TUBERIA PVC-SAP ELECTRICA DE 3/4" X 3 m (20 mm) [16500%]; CABLE 2.5 mm2 LSOH-80 [66000%]; CURVAS PVC-SAP ELECTRICAS 3/4" (20 mm) [16500%]; UNIONES PVC-SAP 3/4" ELECTRICAS (20 mm) [5500%]; CAJA DE PASE OCTOGONAL SAP 100 X 40 mm [5500%] | 34.38h | 2,225 | 05.03.02 | 000000000000291 | 55 | 54.91 | 3020.05 | 10 |
| 310 | 1.6.3.3 | SALIDA PARA FAROLA | 1d | 2024-03-19 | 2024-03-20 | 309SS | 121d | 0d | start no earlier than 2022-05-16 | PEGAMENTO PARA PVC [16%]; OPERARIO [80%]; PEON [40%]; TUBERIA PVC-SAP ELECTRICA DE 3/4" X 3 m (20 mm) [160%]; CABLE 4 mm2 LSOH-80 [9600%]; CURVAS PVC-SAP ELECTRICAS 3/4" (20 mm) [2400%]; UNIONES PVC-SAP 3/4" ELECTRICAS (20 mm) [800%] | 6h | 371.05 | 05.03.03 | 000000000000292 |  | 58.45 | 467.6 | 10 |
| 311 | 1.6.3.4 | SALIDA PARA REFLECTOR | 1d | 2024-03-20 | 2024-03-21 | 310 | 121d | 0d | start no earlier than 2022-05-16 | PEGAMENTO PARA PVC [32%]; OPERARIO [80%]; PEON [40%]; TUBERIA PVC-SAP ELECTRICA DE 3/4" X 3 m (20 mm) [320%]; CABLE 4 mm2 LSOH-80 [200000%]; CURVAS PVC-SAP ELECTRICAS 3/4" (20 mm) [4800%]; UNIONES PVC-SAP 3/4" ELECTRICAS (20 mm) [1600%]; CAJA DE PASE OCTOGONAL SAP 100 X 40 mm [1600%] | 6h | 3,900.87 | 05.03.04 | 000000000000293 | 16 | 264.75 | 4236 | 10 |
| 312 | 1.6.3.5 | SALIDA PARA INTERRUPTOR SIMPLE | 2d | 2024-03-21 | 2024-03-23 | 311 | 121d | 0d | start no earlier than 2022-05-16 | PEGAMENTO PARA PVC [5.8%]; OPERARIO [80.6%]; PEON [40.3%]; TUBERIA PVC-SAP ELECTRICA DE 3/4" X 3 m (20 mm) [8700%]; CABLE 2.5 mm2 LSOH-80 [17400%]; CURVAS PVC-SAP ELECTRICAS 3/4" (20 mm) [8700%]; UNIONES PVC-SAP 3/4" ELECTRICAS (20 mm) [2900%]; INTERRUPTOR SIMPLE [2900%]; CAJA RECTANGULAR SAP DE 100 x 55 x 50 mm [2900%] | 12.08h | 1,334.68 | 05.03.05 | 000000000000294 | 29 | 60.54 | 1755.66 | 12 |
| 313 | 1.6.3.6 | SALIDA PARA INTERRUPTOR DOBLE | 2d | 2024-03-21 | 2024-03-23 | 312SS | 121d | 0d | start no earlier than 2022-05-16 | PEGAMENTO PARA PVC [26%]; OPERARIO [54.2%]; PEON [27.1%]; TUBERIA PVC-SAP ELECTRICA DE 3/4" X 3 m (20 mm) [260%]; CABLE 2.5 mm2 LSOH-80 [7800%]; CURVAS PVC-SAP ELECTRICAS 3/4" (20 mm) [3900%]; UNIONES PVC-SAP 3/4" ELECTRICAS (20 mm) [1300%]; INTERRUPTOR DOBLE [1300%]; CAJA RECTANGULAR SAP DE 100 x 55 x 50 mm [1300%] | 8.12h | 689.29 | 05.03.06 | 000000000000295 | 13 | 63.08 | 820.04 | 12 |
| 314 | 1.6.3.7 | SALIDA PARA INTERRUPTOR CONMUTADOR | 2d | 2024-03-21 | 2024-03-23 | 313SS | 121d | 0d | start no earlier than 2022-05-16 | OPERARIO [83.3%]; PEON [41.7%]; TUBERIA PVC-SAP ELECTRICA DE 3/4" X 3 m (20 mm) [400%]; CABLE 2.5 mm2 LSOH-80 [12000%]; CURVAS PVC-SAP ELECTRICAS 3/4" (20 mm) [6000%]; UNIONES PVC-SAP 3/4" ELECTRICAS (20 mm) [2000%]; CEMENTO PVC 32 OZ NARANJA [40%]; INTERRUPTOR DE CONMUTACION [2000%]; CAJA RECTANGULAR SAP DE 100 x 55 x 50 mm [2000%] | 12.5h | 1,096.56 | 05.03.07 | 000000000000296 | 20 | 64.88 | 1297.6 | 12 |
| 315 | 1.6.3.8 | SALIDA PARA TOMACORRIENTE DOBLE C/LINEA A TIERRA h=0.40 m. | 5d | 2024-03-23 | 2024-03-28 | 314 | 121d | 0d | start no earlier than 2022-05-16 | PEGAMENTO PARA PVC [290%]; OPERARIO [23.2%]; PEON [9.3%]; TUBERIA PVC-SAP ELECTRICA DE 3/4" X 3 m (20 mm) [2900%]; CABLE 4 mm2 LSOH-80 [174000%]; CURVAS PVC-SAP ELECTRICAS 3/4" (20 mm) [43500%]; UNIONES PVC-SAP 3/4" ELECTRICAS (20 mm) [14500%]; TOMACORRIENTE DOBLE C/LINEA TIERRA [14500%]; CAJA RECTANGULAR SAP DE 100 x 55 x 50 mm [14500%] | 8.14h | 8,073.11 | 05.03.08 | 000000000000297 | 145 | 60.22 | 8731.9 | 12 |
| 316 | 1.6.3.9 | SALIDA PARA TOMACORRIENTE DOBLE C/LINEA A TIERRA h=1.60 m. | 1d | 2024-03-23 | 2024-03-24 | 315SS | 125d | 0d | start no earlier than 2022-05-16 | PEGAMENTO PARA PVC [10%]; OPERARIO [50%]; PEON [25%]; TUBERIA PVC-SAP ELECTRICA DE 3/4" X 3 m (20 mm); CABLE 4 mm2 LSOH-80 [6000%]; CURVAS PVC-SAP ELECTRICAS 3/4" (20 mm) [1500%]; UNIONES PVC-SAP 3/4" ELECTRICAS (20 mm) [500%]; TOMACORRIENTE DOBLE C/LINEA TIERRA [500%]; CAJA RECTANGULAR SAP DE 100 x 55 x 50 mm [500%] | 3.75h | 360.4 | 05.03.09 | 000000000000298 |  | 84.15 | 420.75 | 10 |
| 317 | 1.6.3.10 | SALIDA PARA TOMACORRIENTE DOBLE C/LINEA A TIERRA h=2.20 m. | 1d | 2024-03-23 | 2024-03-24 | 316SS | 125d |  | start no earlier than 2022-05-16 | PEGAMENTO PARA PVC [30%]; OPERARIO [75%]; PEON [37.5%]; TUBERIA PVC-SAP ELECTRICA DE 3/4" X 3 m (20 mm) [300%]; CABLE 4 mm2 LSOH-80 [18000%]; CURVAS PVC-SAP ELECTRICAS 3/4" (20 mm) [4500%]; UNIONES PVC-SAP 3/4" ELECTRICAS (20 mm) [1500%]; TOMACORRIENTE DOBLE C/LINEA TIERRA [1500%]; CAJA RECTANGULAR SAP DE 100 x 55 x 50 mm [1500%] | 5.62h | 948.07 | 05.03.10 | 000000000000299 | 15 | 84.15 | 1262.25 | 10 |
| 318 | 1.6.4 | **ALIMENTADORES** | 9d | 2024-06-17 | 2024-06-26 |  | 0d |  |  |  | 45.98h | 7,408.49 | 05.04 | 000000000000301 |  |  |  |  |
| 319 | 1.6.4.1 | SUMINISTRO E INSTALACION DE CABLE 25 mm2 N2XOH | 1d | 2024-06-17 | 2024-06-18 | 306 | 0d |  | start no earlier than 2022-05-16 | OPERARIO [72%]; PEON [7.2%]; CABLE 25 mm2 N2XOH [3780%]; CINTA AISLANTE 1700 NEGRO [72%] | 3.96h | 728.2 | 05.04.01 | 000000000000305 | 36 | 22.04 | 793.44 | 50 |
| 320 | 1.6.4.2 | SUMINISTRO E INSTALACION DE CABLE 10 mm2 N2XOH | 4d | 2024-06-18 | 2024-06-22 | 319 | 0d |  | start no earlier than 2022-05-16 | OPERARIO [95%]; PEON [9.5%]; CABLE 10 mm2 N2XOH [57570%]; CINTA AISLANTE 1700 NEGRO [1140%] | 20.9h | 4,677.19 | 05.04.02 | 000000000000303 | 570 | 11.89 | 6777.3 | 50 |
| 321 | 1.6.4.3 | SUMINISTRO E INSTALACION DE CABLE 6 mm2 N2XOH | 4d | 2024-06-22 | 2024-06-26 | 320 | 0d |  | start no earlier than 2022-05-16 | OPERARIO [96%]; PEON [9.6%]; CABLE 6 mm2 N2XOH [30240%]; CINTA AISLANTE 1700 NEGRO [576%] | 21.12h | 2,003.1 | 05.04.03 | 000000000000302 | 288 | 9.71 | 2796.48 | 50 |
| 322 | 1.6.5 | **ARTEFACTOS DE ILUMINACION** | 12d | 2024-06-26 | 2024-07-08 |  | 19d |  |  |  | 94.52h | 34,944.59 | 05.05 | 000000000000308 |  |  |  |  |
| 323 | 1.6.5.1 | ARTEFACTO REJILLA MLTA 2X18W A.F.P. | 4d | 2024-06-26 | 2024-06-30 | 321 | 19d | 0d | start no earlier than 2022-05-16 | OPERARIO [81.2%]; PEON [40.6%]; ANDAMIO METALICO [16.2%]; CINTA AISLANTE 1700 NEGRO [26%]; ARTEFACTO FLUORESCENTE DE 2 X 18 W. A/F [1300%] | 27.62h | 2,560.11 | 05.05.01 | 000000000000309 | 13 | 188.63 | 2452.19 |  |
| 324 | 1.6.5.2 | ARTEFACTO REJILLA MLTA 2X36W A.F.P. | 4d | 2024-06-30 | 2024-07-04 | 323 | 19d | 0d | start no earlier than 2022-05-16 | OPERARIO [89.1%]; PEON [44.5%]; ANDAMIO METALICO [17.8%]; CINTA AISLANTE 1700 NEGRO [114%]; ARTEFACTO FLUORESCENTE DE 2 X 36 W. A/F [5700%] | 30.28h | 10,360.91 | 05.05.02 | 000000000000310 | 57 | 208.63 | 11891.91 |  |
| 325 | 1.6.5.3 | LUMINARIA FLUORESC. CIRCULAR C.LAMP. FLOURESC. 1X32W. AFP | 1d | 2024-07-04 | 2024-07-05 | 324 | 19d | 0d | start no earlier than 2022-05-16 | OPERARIO [93.8%]; PEON [46.9%]; ANDAMIO METALICO [18.8%]; CINTA AISLANTE 1700 NEGRO [30%]; FLUORESC. CIRCULAR . C/LAMP. FLOURESC.1x32W. AFP [1500%] | 7.97h | 1,676.55 | 05.05.03 | 000000000000311 | 15 | 138.63 | 2079.45 |  |
| 326 | 1.6.5.4 | LUMINARIA ADOSABLE EN MURO-BRAQUET | 1d | 2024-07-05 | 2024-07-06 | 325 | 19d | 0d | start no earlier than 2022-05-16 | OPERARIO [98.1%]; PEON [49.1%]; ANDAMIO METALICO [19.6%]; CINTA AISLANTE 1700 NEGRO [106%]; BRAQUETE C/EQUIPO Y LAMPARA DE 70 W [5300%] | 8.34h | 9,732 | 05.05.04 | 000000000000312 | 53 | 231.58 | 12273.74 |  |
| 327 | 1.6.5.5 | LUZ DE EMERGENCIA 2X20W HALOGENA 5H BAT. LIBRE MANTO | 1d | 2024-07-06 | 2024-07-07 | 326 | 19d | 0d | start no earlier than 2022-05-16 | OPERARIO [93.8%]; PEON [46.9%]; ANDAMIO METALICO [18.8%]; LUZ DE EMERGENCIA 2X20W HALOGENA 5H BAT. LIBRE MANTO [1500%] | 7.97h | 2,425.8 | 05.05.05 | 000000000000313 | 15 | 188.58 | 2828.7 |  |
| 328 | 1.6.5.6 | LUMINARIA TIPO FAROLA DE 70W. | 1d | 2024-07-07 | 2024-07-08 | 327 | 19d | 0d | start no earlier than 2022-05-16 | OPERARIO [66.7%]; PEON [33.3%]; ANDAMIO METALICO [13.3%]; BASE DE FAROLA TUBO DE 3"X 2.5 mm. [800%]; LUMINARIA FAROLA JP/250-72 70 W [800%] | 5.67h | 2,193.02 | 05.05.06 | 000000000000314 |  | 309.93 | 2479.44 |  |
| 329 | 1.6.5.7 | LUMINARIA TIPO REFLECTOR DE 200 W HALOGENURO METALICO (KIT COMPLETO) | 1d | 2024-07-07 | 2024-07-08 | 328SS | 19d |  | start no earlier than 2022-05-16 | OPERARIO [88.9%]; PEON [44.4%]; REFLECTOR METALICO LED C/EQUIPO Y LAMP. 200W [1600%] | 6.67h | 5,996.2 | 05.05.07 | 000000000000315 | 16 | 413.66 | 6618.56 |  |
| 330 | 1.6.6 | **TABLEROS ELECTRICOS** | 7d | 2024-06-26 | 2024-07-03 |  | 0d |  |  |  | 87.5h | 13,292.41 | 05.06 | 000000000000316 |  |  |  |  |
| 331 | 1.6.6.1 | SUMINISTRO E INST. DE TABLERO GENERAL S/ ESP. TEC. (TG) | 1d | 2024-06-26 | 2024-06-27 | 321 | 0d |  | start no earlier than 2022-05-16 | OPERARIO; OFICIAL [50%]; INTERRUPTOR TERMOMAGNETICO 3 X100 A; INTERRUPTOR TERMOMAGNETICO 3 X63 A. [200%]; INTERRUPTOR TERMOMAGNETICO 3 X30 A [600%]; GABINETE METALICO T.G. | 7.5h | 2,568.85 | 05.06.01 | 000000000000317 |  | 2687.08 | 2687.08 |  |
| 332 | 1.6.6.2 | SUMINISTRO E INST. DE TABLERO DISTRIB. CIS. S/ ESP.(TD-01) | 1d | 2024-06-26 | 2024-06-27 | 331SS | 29d | 0d | start no earlier than 2022-05-16 | OPERARIO; OFICIAL [50%]; INTERRUPTOR TERMOMAGNETICO 3 X30 A; INTERRUPTOR DIFERENCIAL 2X25 A/30mm A; INTERRUPTOR TIPO RIEL 2X20A; INTERRUPTOR TIPO RIEL 2X16A; TABLERO METALICO DE 12 POLOS | 7.5h | 547.36 | 05.06.02 | 000000000000318 |  | 665.59 | 665.59 |  |
| 333 | 1.6.6.3 | SUMINISTRO E INST. DE TABLERO DISTRIB. ADM. S/ ESP.(TD-02) | 1d | 2024-06-27 | 2024-06-28 | 331 | 0d |  | start no earlier than 2022-05-16 | OPERARIO; OFICIAL [50%]; INTERRUPTOR TERMOMAGNETICO 3 X30 A; INTERRUPTOR DIFERENCIAL 2X25 A/30mm A [300%]; INTERRUPTOR TIPO RIEL 2X20A; INTERRUPTOR TIPO RIEL 2X16A [200%]; TABLERO METALICO DE 12 POLOS | 7.5h | 743.06 | 05.06.03 | 000000000000319 |  | 861.29 | 861.29 |  |
| 334 | 1.6.6.4 | SUMINISTRO E INST. DE TABLERO DISTRIB. COMP(P) S/ ESP.(TD-03) | 1d | 2024-06-27 | 2024-06-28 | 333SS | 28d | 0d | start no earlier than 2022-05-16 | OPERARIO; OFICIAL [50%]; INTERRUPTOR TERMOMAGNETICO 3 X63 A.; INTERRUPTOR DIFERENCIAL 2X25 A/30mm A [500%]; INTERRUPTOR TIPO RIEL 2X20A [500%]; TABLERO METALICO DE 30 POLOS | 7.5h | 1,383.6 | 05.06.04 | 000000000000323 |  | 1501.83 | 1501.83 |  |
| 335 | 1.6.6.5 | SUMINISTRO E INST. DE TABLERO DISTRIB. SUM. S/ ESP.(TD-04) | 1d | 2024-06-28 | 2024-06-29 | 333 | 0d |  | start no earlier than 2022-05-16 | OPERARIO; OFICIAL [50%]; INTERRUPTOR TERMOMAGNETICO 3 X30 A; INTERRUPTOR DIFERENCIAL 2X25 A/30mm A [300%]; INTERRUPTOR TIPO RIEL 2X20A; INTERRUPTOR TIPO RIEL 2X16A [200%]; INTERRUPTOR TIPO RIEL 2X30A; TABLERO METALICO DE 12 POLOS | 7.5h | 806.96 | 05.06.05 | 000000000000320 |  | 925.19 | 925.19 |  |
| 336 | 1.6.6.6 | SUMINISTRO E INST. DE TABLERO DISTRIB. AULA(P) S/ ESP.(TD-05) | 1d | 2024-06-29 | 2024-06-30 | 335 | 0d |  | start no earlier than 2022-05-16 | OPERARIO; OFICIAL [50%]; INTERRUPTOR TERMOMAGNETICO 3 X30 A; INTERRUPTOR DIFERENCIAL 2X25 A/30mm A [400%]; INTERRUPTOR TIPO RIEL 2X20A [200%]; INTERRUPTOR TIPO RIEL 2X16A [200%]; TABLERO METALICO DE 12 POLOS | 7.5h | 857.41 | 05.06.06 | 000000000000321 |  | 975.64 | 975.64 |  |
| 337 | 1.6.6.7 | SUMINISTRO E INST. DE TABLERO DISTRIB. AULAS.(S)/ ESP.(TD-06) | 1d | 2024-06-30 | 2024-07-01 | 336 | 0d |  | start no earlier than 2022-05-16 | OPERARIO; OFICIAL [50%]; INTERRUPTOR TERMOMAGNETICO 3 X30 A; INTERRUPTOR DIFERENCIAL 2X25 A/30mm A [400%]; INTERRUPTOR TIPO RIEL 2X20A [200%]; INTERRUPTOR TIPO RIEL 2X16A [200%]; INTERRUPTOR TIPO RIEL 2X30A; TABLERO METALICO DE 12 POLOS | 7.5h | 921.31 | 05.06.07 | 000000000000324 |  | 1039.54 | 1039.54 |  |
| 338 | 1.6.6.8 | SUMINISTRO E INST. DE TABLERO DISTRIB. AULAS.(S)/ ESP.(TD-07) | 1d | 2024-06-30 | 2024-07-01 | 337SS | 26d |  | start no earlier than 2022-05-16 | OPERARIO; OFICIAL [50%]; INTERRUPTOR TERMOMAGNETICO 3 X30 A; INTERRUPTOR DIFERENCIAL 2X25 A/30mm A [400%]; INTERRUPTOR TIPO RIEL 2X20A [200%]; INTERRUPTOR TIPO RIEL 2X16A [200%]; TABLERO METALICO DE 12 POLOS | 7.5h | 857.41 | 05.06.08 | 000000000000325 |  | 975.64 | 975.64 |  |
| 339 | 1.6.6.9 | SUMINISTRO E INST. DE TABLERO DISTRIB. LAB. S/ ESP.(TD-08) | 1d | 2024-07-01 | 2024-07-02 | 337 | 0d |  | start no earlier than 2022-05-16 | OPERARIO; OFICIAL [50%]; INTERRUPTOR TERMOMAGNETICO 3 X63 A.; INTERRUPTOR DIFERENCIAL 2X25 A/30mm A [400%]; INTERRUPTOR TIPO RIEL 2X20A; INTERRUPTOR TIPO RIEL 2X16A [200%]; INTERRUPTOR TIPO RIEL 2X30A; TABLERO METALICO DE 12 POLOS | 7.5h | 954.91 | 05.06.09 | 000000000000322 |  | 1073.14 | 1073.14 |  |
| 340 | 1.6.6.10 | SUMINISTRO E INST. DE TABLERO DISTRIB. RESD. S/ ESP.(TD-09) | 1d | 2024-07-02 | 2024-07-03 | 339 | 0d |  | start no earlier than 2022-05-16 | OPERARIO; OFICIAL [50%]; INTERRUPTOR TERMOMAGNETICO 3 X30 A; INTERRUPTOR DIFERENCIAL 2X25 A/30mm A [300%]; INTERRUPTOR TIPO RIEL 2X20A; INTERRUPTOR TIPO RIEL 2X16A [200%]; TABLERO METALICO DE 12 POLOS | 7.5h | 743.06 | 05.06.10 | 000000000000328 |  | 861.29 | 861.29 |  |
| 341 | 1.6.6.11 | TABLERO DE CONTROL Y MANDO DE ELECTROBOMBA | 1d | 2024-06-27 | 2024-06-28 | 332 | 29d | 0d | start no earlier than 2022-05-16 | TABLERO DE CONTROL Y MANDO DE ELECTROBOMBA; OPERARIO; PEON [50%] | 7.5h | 777.52 | 05.06.11 | 000000000000330 |  | 892.56 | 892.56 |  |
| 342 | 1.6.6.12 | ESTABILIZADOR VOLTAJE 15KVA,3/220V, 60Hz | 1d | 2024-06-28 | 2024-06-29 | 334 | 28d |  | start no earlier than 2022-05-16 | OPERARIO; UPS-ESTABILIZADOR VOLTAJE 15KVA 3/220V 60Hz | 5h | 2,130.95 | 05.06.12 | 000000000000333 |  | 2215.81 | 2215.81 |  |

| ID | WBS | Task | Duration | Start | Finish | Predecessors | Total slack | Free slack | Constraint | Resources | Work | Cost | Text1 | Text8 | Text3 | Text4 | Text2 | Text6 |
| --- | --- | --- | --- | --- | --- | --- | --- | --- | --- | --- | --- | --- | --- | --- | --- | --- | --- | --- |
| 343 | 1.6.7 | **EQUIPOS ELECTROMECANICOS** | 1d | 2024-06-27 | 2024-06-28 |  | 29d |  |  |  | 1.25h | 84.42 | 05.07 | 000000000000334 |  |  |  |  |
| 344 | 1.6.7.1 | SISTEMA AUTOMATICO DE NIVEL P/ CISTERNA Y TANQ. ELEV. | 1d | 2024-06-27 | 2024-06-28 | 341SS | 29d |  | start no earlier than 2022-05-16 | OPERARIO [5%]; PEON [20%]; AUTOMATICOS DE NIVEL | 1.25h | 84.42 | 05.07.01 | 000000000000335 | 100.74 | 100.74 |  |  |
| 345 | 1.6.8 | **POZO DE PUESTA A TIERRA** | 5d | 2024-07-03 | 2024-07-08 |  | 0d |  |  |  | 75h | 8,561.25 | 05.08 | 000000000000336 |  |  |  |  |
| 346 | 1.6.8.1 | POZO DE TIERRA | 5d | 2024-07-03 | 2024-07-08 | 340 | 0d |  | start no earlier than 2022-05-16 | DOSIS ECOGEL 8KG. [3000%]; OPERARIO; PEON [200%]; TIERRA DE CULTIVO [1500%]; CONECTORES DE COBRE TIPO A/B [1000%]; VARILLA DE COBRE DE 3/4" X 2.40 m [1000%]; REGISTRO C/ TAPA POZO DE PUESTA A TIERRA [1000%]; CARBON VEJETAL (25KG) [1000%]; BENTONITA SODICA (50 KG) [1000%] | 75h | 8,561.25 | 05.08.01 | 000000000000337 | 1230.48 | 12304.8 | 10 |  |
| 347 | 1.6.9 | **PRUEBAS Y PUESTA EN SERVICIO** | 1d | 2024-07-26 | 2024-07-26 |  | 1d |  |  |  | 4h | 1,200 | 05.09 | 000000000000338 |  |  |  |  |
| 348 | 1.6.9.1 | PRUEBA Y PUESTA EN SERVICIO DE LAS INST. ELECTRICAS | 1d | 2024-07-26 | 2024-07-26 | 394 | 1d |  | start no earlier than 2022-05-16 | PRUEBA ELECTRICA Y PUESTA EN SERVICIO | 4h | 1,200 | 05.09.01 | 000000000000340 | 1200 | 1200 |  |  |
| 349 | 1.6.10 | **SISTEMA GRUPO ELECTROGENO** | 11d | 2024-07-08 | 2024-07-19 |  | 0d |  |  |  | 96.81h | 72,380.31 | 05.10 | 000000000000341 |  |  |  |  |
| 350 | 1.6.10.1 | TUBERIA DE ACERO CEDULA SCH-40 DE Ø 3/4" | 1d | 2024-07-08 | 2024-07-09 | 346 | 0d |  | start no earlier than 2022-05-16 | OPERARIO [45%]; PEON [45%]; TUBO DE ACERO SCH-40 DE Ø 3/4" [945%]; CODO DE ACERO SCH-40 DE Ø 3/4" [405%] | 4.5h | 303.35 | 05.10.01 | 000000000000437 | 40.97 | 368.73 |  | 20 |
| 351 | 1.6.10.2 | VALVULA DE CIERRE Ø 3/4" | 1d | 2024-07-08 | 2024-07-09 | 350SS | 0d |  | start no earlier than 2022-05-16 | OPERARIO [40%]; VALVULA DE CIERRE Ø 3/4" [200%] | 2h | 232.38 | 05.10.02 | 000000000000438 | 133.16 | 266.32 |  |  |
| 352 | 1.6.10.3 | VALVULA DE PIE CON CANASTILLA Ø 3/4" | 1d | 2024-07-09 | 2024-07-10 | 351 | 17d |  | start no earlier than 2022-05-16 | OPERARIO [20%]; VALVULA DE PIE CON CANASTILLA Ø 3/4" | 1h | 176.19 | 05.10.03 | 000000000000439 | 193.16 | 193.16 |  |  |
| 353 | 1.6.10.4 | VALVULA DE SOBRELLENADO Ø 4" | 1d | 2024-07-09 | 2024-07-10 | 351 | 0d |  | start no earlier than 2022-05-16 | OPERARIO [20%]; VALVULA DE SOBRELLENADO Ø 4" | 1h | 526.19 | 05.10.04 | 000000000000440 | 543.16 | 543.16 |  |  |
| 354 | 1.6.10.5 | SOPORTE DE FIERRO CON ANGULO 1 1/2" X 1 1/2" X 1/8" | 1d | 2024-07-10 | 2024-07-11 | 353 | 0d |  | start no earlier than 2022-05-16 | OPERARIO; PEON [50%]; SOLDADORA ELECTRICA [50%]; SOLDADURA CELLOCORD [250%]; ANGULO 1 1/2" x 1 1/2" x 1/8 [525%] | 10h | 309.95 | 05.10.05 | 000000000000441 | 89.48 | 447.4 |  |  |
| 355 | 1.6.10.6 | SUMINISTRO E INST. DE TANQUE DE SUMINISTRO DIARIO DE COMBUSTIBLE DE 300 GAL. | 1d | 2024-07-11 | 2024-07-12 | 354 | 0d |  | start no earlier than 2022-05-16 | OPERARIO; OFICIAL; PEON [200%]; TANQUE METALICO e=3 mm. PARA COMBUSTIBLE | 20h | 8,620.25 | 05.10.06 | 000000000000436 | 8892.57 | 8892.57 |  |  |
| 356 | 1.6.10.7 | SENSOR CONTROL DE NIVEL DE TANQUE | 1d | 2024-07-12 | 2024-07-13 | 355 | 0d |  | start no earlier than 2022-05-16 | OPERARIO [50%]; SENSOR CONTROL DE NIVEL DE COMBUSTIBLE [200%] | 2.5h | 695.48 | 05.10.07 | 000000000000442 | 368.95 | 737.9 |  |  |
| 357 | 1.6.10.8 | ELECTROBOMBA DE PETROLEO TIPO ROTATIVA DE ENGRANAJES | 1d | 2024-07-13 | 2024-07-14 | 356 | 0d |  | start no earlier than 2022-05-16 | OPERARIO [50%]; PEON [25%]; ELECTROBOMBA DE PETROLEO 1HP INC. ACCESORIOS | 3.75h | 2,938.76 | 05.10.08 | 000000000000443 | 2996.28 | 2996.28 |  |  |
| 358 | 1.6.10.9 | SUMINISTRO E INST. CABLE 2X1X35mm2 N2XOH | 1d | 2024-07-14 | 2024-07-15 | 357 | 0d |  | start no earlier than 2022-05-16 | OPERARIO [92%]; PEON [9.2%]; CABLE 35mm2 N2XOH [28060%]; CINTA AISLANTE 1700 NEGRO [184%] | 5.06h | 6,282.37 | 05.10.09 | 000000000000435 | 71.5 | 6578 | 92 | 50 |
| 359 | 1.6.10.10 | GRUPO ELECTROGENO 25kW,Vn=380VAC, Trifasico, Insonoro | 2d | 2024-07-15 | 2024-07-17 | 358 | 0d |  | start no earlier than 2022-05-16 | SISTEMA DE EVACUACION DE GASES DE COMBUSTION; OPERARIO [200%]; OFICIAL; GRUPO ELECTROGENO 25kW Vn=380VAC Trifasico Insonoro. | 24h | 45,413.84 | 05.10.10 | 000000000000424 | 45431.36 | 45431.36 |  |  |
| 360 | 1.6.10.11 | GRUPO ELECTROGENO 5kW | 1d | 2024-07-17 | 2024-07-18 | 359 | 0d |  | start no earlier than 2022-05-16 | OPERARIO [50%]; OFICIAL [50%]; GRUPO ELECTROGENO 5kW Inc. Accesorios | 5h | 4,115.98 | 05.10.11 | 000000000000447 | 4191.77 | 4191.77 |  |  |
| 361 | 1.6.10.12 | TUBERIA DE ESCAPE Ø 6" | 1d | 2024-07-17 | 2024-07-18 | 360SS | 9d |  | start no earlier than 2022-05-16 | OPERARIO [30%]; PEON [30%]; TUBO DE ACERO SCH-40 DE Ø 6" [630%]; CODO DE ACERO SCH-40 DE Ø 6" [300%] | 3h | 1,750.83 | 05.10.12 | 000000000000444 | 299.07 | 1794.42 |  | 20 |
| 362 | 1.6.10.13 | POZO DE TIERRA | 1d | 2024-07-18 | 2024-07-19 | 360 | 0d |  | start no earlier than 2022-05-16 | DOSIS ECOGEL 8KG. [300%]; OPERARIO; PEON [200%]; TIERRA DE CULTIVO [150%]; CONECTORES DE COBRE TIPO A/B; VARILLA DE COBRE DE 3/4" X 2.40 m; REGISTRO C/ TAPA POZO DE PUESTA A TIERRA; CARBON VEJETAL (25KG); BENTONITA SODICA (50 KG) | 15h | 1,014.75 | 05.10.13 | 000000000000428 | 1230.48 | 1230.48 |  |  |
| 363 | 1.7 | **INSTALACIONES DE COMUNICACIONES** | 40d | 2024-06-17 | 2024-07-27 |  | 0d |  |  |  | 1032.94h | 53,967.15 | 06 | 000000000000364 |  |  |  |  |
| 364 | 1.7.1 | **CANALETAS, CONDUCTOS Y/O TUBERÍAS** | 3d | 2024-06-17 | 2024-06-20 |  | 32d |  |  |  | 19.7h | 2,931.06 | 06.01 | 000000000000365 |  |  |  |  |
| 365 | 1.7.1.1 | TUBERIA PVC-SAP DE 25 mm | 2d | 2024-06-17 | 2024-06-19 | 304 | 32d | 0d | start no earlier than 2022-05-16 | PEGAMENTO PARA PVC [74.4%]; OPERARIO [93%]; PEON [46.5%]; TUBERIA PVC-SAP ELECTRICA DE 1" X 3 m (25 mm) [39039%]; CURVAS PVC-SAP ELECTRICAS 1" (25 mm) [2044.9%]; UNIONES PVC-SAP 1" ELECTRICAS (25 mm) [2044.9%] | 13.94h | 2,123.71 | 06.01.01 | 000000000000367 | 10.79 | 4011.72 | 371.8 | 50 |
| 366 | 1.7.1.2 | TUBERIA PVC-SAP DE 40 mm | 1d | 2024-06-19 | 2024-06-20 | 365 | 32d | 0d | start no earlier than 2022-05-16 | PEGAMENTO PARA PVC [15.3%]; OPERARIO [76.7%]; PEON [38.4%]; TUBERIA PVC-SAP ELECTRICA DE 1½" X 3 m (40 mm) [8053.5%]; CURVAS PVC-SAP ELECTRICAS 1½" (40 mm) [383.5%]; UNIONES PVC-SAP 1½" ELECTRICAS (40 mm) [383.5%] | 5.75h | 807.35 | 06.01.02 | 000000000000368 | 14.72 | 1129.02 | 76.7 | 50 |

| ID | WBS | Task | Type | Duration | Start | Finish | Predecessors | Total slack | Free slack | Constraint | Resources | Work | Cost | Text1 | Text8 | Text2 | Text3 | Text4 | Text6 |
| --- | --- | --- | --- | --- | --- | --- | --- | --- | --- | --- | --- | --- | --- | --- | --- | --- | --- | --- | --- |
| 367 | 1.7.2 | **SALIDA DE COMUNICACIONES** |  | 5d | 2024-06-20 | 2024-06-25 |  | 32d |  |  |  | 39.79h | 5,453.67 | 06.02 | 000000000000366 |  |  |  |  |
| 368 | 1.7.2.1 | **CAJAS PASE DE COMUNICACIONES** |  | 1d | 2024-06-20 | 2024-06-21 |  | 32d |  |  |  | 4.5h | 575.65 | 06.02.01 | 000000000000370 |  |  |  |  |
| 369 | 1.7.2.1.1 | CAJA DE PASE 150 X 150 X 80mm IP65 |  | 1d | 2024-06-20 | 2024-06-21 | 366 | 32d | 0d | start no earlier than 2022-05-16 | OPERARIO [70%]; CAJA DE PASE 150 X 150 X 80mm [1400%] | 3.5h | 413.67 | 06.02.01.01 | 000000000000375 | 14 | 45 | 630 | 10 |
| 370 | 1.7.2.1.2 | CAJA DE PASE 400 X 400 X 100mm IP65 |  | 1d | 2024-06-20 | 2024-06-21 | 369SS | 32d | 0d | start no earlier than 2022-05-16 | OPERARIO [20%]; CAJA DE PASE 400 X 400 X 100mm [200%] | 1h | 161.99 | 06.02.01.02 | 000000000000376 |  | 89.9 | 179.8 | 10 |
| 371 | 1.7.2.2 | **SISTEMA DE VOZ – DATA** |  | 4d | 2024-06-21 | 2024-06-25 |  | 32d |  |  |  | 35.29h | 4,878.02 | 06.02.02 | 000000000000369 |  |  |  |  |
| 372 | 1.7.2.2.1 | SALIDA PARA DATOS EN PARED |  | 2d | 2024-06-21 | 2024-06-23 | 370 | 32d | 0d | start no earlier than 2022-05-16 | PEGAMENTO PARA PVC [6.6%]; OPERARIO [82.5%]; PEON [41.2%]; TUBERIA PVC-SAP ELECTRICA DE 1" X 3 m (25 mm) [9900%]; CURVAS PVC-SAP ELECTRICAS 1" (25 mm) [6600%]; PLACA DE ALUMINIO ANODIZADO 1 CAVIDAD [3300%]; CAJA RECTANGULAR SAP DE 100 x 55 x 50 mm [3300%]; CONEXION A CAJA PVC ELECT. SAP 25 mm. [6600%]; TOMA PARA RED DATA (DADO) [3300%]; CONECTOR PVC 25 mm. [3300%] | 12.38h | 2,444.21 | 06.02.02.01 | 000000000000300 | 33 | 94.44 | 3116.52 | 10 |
| 373 | 1.7.2.2.2 | SALIDA DE PUNTO HDMI EN PARED |  | 2d | 2024-06-23 | 2024-06-25 | 372 | 32d | 0d | start no earlier than 2022-05-16 | PEGAMENTO PARA PVC [2.6%]; OPERARIO [81.2%]; PEON [40.6%]; TUBERIA PVC-SAP ELECTRICA DE 1" X 3 m (25 mm) [1300%]; CURVAS PVC-SAP ELECTRICAS 1" (25 mm) [1300%]; FACE PLATE HDMI [1300%]; CAJA RECTANGULAR SAP DE 100 x 55 x 50 mm [1300%]; CONECTOR HDMI [1300%] | 12.19h | 1,060.17 | 06.02.02.02 | 000000000000372 | 13 | 96.65 | 1256.45 |  |
| 374 | 1.7.2.2.3 | SALIDA DE PUNTO HDMI EN TECHO |  | 1d | 2024-06-23 | 2024-06-24 | 373SS | 32d | 0d | start no earlier than 2022-05-16 | PEGAMENTO PARA PVC [2.6%]; OPERARIO [72.2%]; PEON [36.1%]; TUBERIA PVC-SAP ELECTRICA DE 1" X 3 m (25 mm) [1300%]; CURVAS PVC-SAP ELECTRICAS 1" (25 mm) [1300%]; FACE PLATE HDMI [1300%]; CAJA RECTANGULAR SAP DE 100 x 55 x 50 mm [1300%]; CONECTOR HDMI [1300%] | 5.42h | 899.9 | 06.02.02.03 | 000000000000398 | 13 | 109.07 | 1417.91 |  |
| 375 | 1.7.2.2.4 | SALIDA PARA ACCESS POINT |  | 1d | 2024-06-24 | 2024-06-25 | 374 | 32d | 0d | start no earlier than 2022-05-16 | PEGAMENTO PARA PVC [0.6%]; OPERARIO [37.5%]; PEON [18.8%]; TUBERIA PVC-SAP ELECTRICA DE 1" X 3 m (25 mm) [900%]; CURVAS PVC-SAP ELECTRICAS 1" (25 mm) [600%]; PLACA DE ALUMINIO ANODIZADO 1 CAVIDAD [300%]; CAJA RECTANGULAR SAP DE 100 x 55 x 50 mm [300%]; CONEXION A CAJA PVC ELECT. SAP 25 mm. [600%]; TOMA PARA RED DATA (DADO) [300%]; CONECTOR PVC 25 mm. [300%] | 2.81h | 262.14 | 06.02.02.04 | 000000000000400 |  | 101.77 | 305.31 |  |
| 376 | 1.7.2.2.5 | SALIDA DE FUERZA PARA GABINETE DE COMUNICACIONES |  | 1d | 2024-06-24 | 2024-06-25 | 375SS | 32d |  | start no earlier than 2022-05-16 | PEGAMENTO PARA PVC [0.2%]; OPERARIO [25%]; PEON [25%]; TUBERIA PVC-SAP ELECTRICA DE 2" X 3 m (50 mm) [300%]; CURVAS PVC-SAP ELECTRICAS 2" (50 mm) [200%]; PLACA DE ALUMINIO ANODIZADO 1 CAVIDAD; CAJA DE 200 X 200 X 100 mm [200%]; TOMA PARA RED DATA (DADO) | 2.5h | 211.59 | 06.02.02.05 | 000000000000401 |  | 247.89 | 247.89 |  |
| 377 | 1.7.3 | **CONDUCTORES DE COMUNICACIONES** |  | 2d | 2024-07-19 | 2024-07-21 |  | 0d |  |  |  | 13.45h | 6,800.81 | 06.03 | 000000000000377 |  |  |  |  |
| 378 | 1.7.3.1 | CABLE UTP CAT 6 A 4 PARES |  | 1d | 2024-07-19 | 2024-07-20 | 362 | 0d |  | start no earlier than 2022-05-16 | OPERARIO [93.9%]; PEON [93.9%]; CABLE UTP CAT 6 A 4 [138012%] | 9.39h | 5,040.82 | 06.03.01 | 000000000000378 | 1314.4 | 5.53 | 7268.63 | 200 |
| 379 | 1.7.3.2 | CABLE HDMI 8M CON CONECTORES EN LOS EXTREMOS |  | 1d | 2024-07-20 | 2024-07-21 | 378 | 6d |  | start no earlier than 2022-05-16 | OPERARIO [81.2%]; CLAVE HDMI [31200%] | 4.06h | 1,760 | 06.03.02 | 000000000000379 | 26 | 90.58 | 2355.08 |  |
| 380 | 1.7.4 | **PATCH PANEL** |  | 2d | 2024-07-21 | 2024-07-22 |  | 0d |  |  |  | 370h | 5,193.2 | 06.04 | 000000000000380 |  |  |  |  |
| 381 | 1.7.4.1 | PATCH PANEL 110 DE 24 PUERTOS CAT 6A |  | 1d | 2024-07-21 | 2024-07-21 | 378 | 0d |  | start no earlier than 2022-05-16 | PATCH PANEL 110 DE 24 PUERTOS CAT 6A | 5h | 224 | 06.04.01 | 000000000000381 |  | 224 | 224 |  |
| 382 | 1.7.4.2 | PATCH PANEL 110 DE 48 PUERTOS CAT 6A |  | 1d | 2024-07-21 | 2024-07-21 | 381SS | 0d |  | start no earlier than 2022-05-16 | PATCH PANEL 110 DE 48 PUERTOS CAT 6A | 5h | 336 | 06.04.02 | 000000000000382 |  | 336 | 336 |  |
| 383 | 1.7.4.3 | PATCH CORD UTP 6A DE 1M LSZH |  | 1d | 2024-07-22 | 2024-07-22 | 382 | 5d | 0d | start no earlier than 2022-05-16 | CABLE PATCH CORD UTP 6A DE 1M LSZH [3600%] | 180h | 2,012.4 | 06.04.03 | 000000000000383 | 36 | 55.9 | 2012.4 |  |
| 384 | 1.7.4.4 | PATCH CORD UTP 6A DE 3M LSZH |  | 1d | 2024-07-22 | 2024-07-22 | 383SS | 5d |  | start no earlier than 2022-05-16 | CABLE PATCH CORD UTP 6A DE 3M LSZH [3600%] | 180h | 2,620.8 | 06.04.04 | 000000000000384 | 36 | 72.8 | 2620.8 |  |
| 385 | 1.7.5 | **RACK DE COMUNICACIONES** |  | 1d | 2024-07-22 | 2024-07-22 |  | 0d |  |  |  | 5h | 2,789 | 06.05 | 000000000000385 |  |  |  |  |
| 386 | 1.7.5.1 | RACK DE COMUNICACIONES DE 12 RU |  | 1d | 2024-07-22 | 2024-07-22 | 382 | 0d |  | start no earlier than 2022-05-16 | GABINETE DE COMUNICACIONES DE 12 RU C/ ACCESORIOS DE INSTALACION | 5h | 2,789 | 06.05.01 | 000000000000386 |  | 2789 | 2789 |  |
| 387 | 1.7.6 | **EQUIPOS Y PUESTA EN SERVICIO** |  | 5d | 2024-07-23 | 2024-07-27 |  | 0d |  |  |  | 585h | 30,799.4 | 06.06 | 000000000000387 |  |  |  |  |
| 388 | 1.7.6.1 | SWITCH 24 PUERTOS 10/100/1000 BASE-T PoE |  | 1d | 2024-07-23 | 2024-07-23 | 386 | 0d |  | start no earlier than 2022-05-16 | SWITCH 24 PUERTOS 10/100/1000 BASE-T PoE | 5h | 2,714 | 06.06.01 | 000000000000388 |  | 2714 | 2714 |  |
| 389 | 1.7.6.2 | SWITCH 48 PUERTOS 10/100/1000 BASE-T PoE |  | 1d | 2024-07-23 | 2024-07-23 | 388SS | 0d |  | start no earlier than 2022-05-16 | SWITCH 48 PUERTOS 10/100/1000 BASE-T PoE | 5h | 4,169 | 06.06.02 | 000000000000389 |  | 4169 | 4169 |  |
| 390 | 1.7.6.3 | ROUTER 10/100/1000 Mbit/s, MEMORIA 2048 MB |  | 1d | 2024-07-23 | 2024-07-23 | 389SS | 0d |  | start no earlier than 2022-05-16 | ROUTER 10/100/1000 Mbit/s MEMORIA 2048 MB | 5h | 2,540 | 06.06.03 | 000000000000390 |  | 2540 | 2540 |  |
| 391 | 1.7.6.4 | PUNTO DE ACCESO INALAMBRICO (ACCESS POINT) |  | 1d | 2024-07-23 | 2024-07-23 | 390SS | 0d |  | start no earlier than 2022-05-16 | ACCESS POINT [300%] | 15h | 8,685 | 06.06.04 | 000000000000391 |  | 2895 | 8685 |  |
| 392 | 1.7.6.5 | ADAPTADOR ETHERNET PARA ANTENA SATELITAL |  | 1d | 2024-07-24 | 2024-07-24 | 391 | 0d |  | start no earlier than 2022-05-16 | ADAPTADOR ETHERNET | 5h | 768 | 06.06.05 | 000000000000393 |  | 768 | 768 |  |
| 393 | 1.7.6.6 | ANTENA PARA SERVICIO SATELITAL MÍNIMO 200Mbps |  | 1d | 2024-07-24 | 2024-07-24 | 392SS | 0d |  | start no earlier than 2022-05-16 | ANTENA PARA SERVICIO SATELITAL | 5h | 1,895 | 06.06.06 | 000000000000394 |  | 1895 | 1895 |  |
| 394 | 1.7.6.7 | REPORTE DE PRUEBAS DEL SISTEMA DEL CABLEADO ESTRUCTURADO |  | 1d | 2024-07-25 | 2024-07-25 | 392 | 1d | 0d | start no earlier than 2022-05-16 | ETIQUETAS DE IDENTIFICACION SEÑALIZACION Y ORDENAMIENTO [3600%]; INSTALACION CONFIGURACION Y PUESTA EN FUNCIONAMIENTO [3600%]; CERTIFICACION DEL CABLEADO ESTRUCTURADO CAT 6 [3600%] | 540h | 9,248.4 | 06.06.07 | 000000000000395 | 36 | 256.9 | 9248.4 |  |
| 395 | 1.7.6.8 | CONTRATO DE SUMINISTRO DE DATOS CON SERVICIO SATELITAL |  | 1d | 2024-07-25 | 2024-07-25 | 393 | 0d |  | start no earlier than 2022-05-16 | CONTRATO DE SUMINISTRO DE DATOS CON SERVICIO SATELITAL | 5h | 780 | 06.06.08 | 000000000000396 |  | 780 | 780 |  |
| 396 | 1.7.6.9 | TERMINO DE OBRA | milestone | 0d | 2024-07-27 | 2024-07-27 | 213 | 0d |  |  |  |  |  |  |  |  |  |  |  |
